# 3GPP_Release-2000

Schedule from MS Project, 2000-01-03 to 2008-07-11, A marks actual dates.

## Calendars

- Standard: Mon-Fri 08:00-12:00, 13:00-17:00; Sat-Sun off.

## Resources

| Resource |
| --- |
| NP |
| N1 |
| N2 |
| N3 |
| N4 |
| N5 |
| TP |
| T1 |
| T2 |
| T3 |
| RP |
| R1 |
| R2 |
| R3 |
| R4 |
| SP |
| S1 |
| S2 |
| S3 |
| S4 |
| S5 |
| PCG |
| GP |
| No |
| CN4 |
| ? |
| WG G2 |
| G2 |
| G1 |
| G4 |
| G3 |
| All |
| Generic |
| MLST |
| G5 |
| S3; G2 |
| WG T2 |
| GP;G1 |
| G4;G5 |
| OMA |
| GP-G2 |
| Yes |
| GP; |
| N4; |
| GP; N1 |
| CT5 |
| C5 |
| C1 |
| C4 |
| C3 |
| C6 |
| G1; |
| 4 |
| ct |
| c;s;r |
| CT;RAN;SA |
| G2; |
| G1; G3 |
| CT6 |
| CT1 |
| CT1, CT3, CT4 |
| C1, C3, C4 |
| CP |

## Schedule

| ID | WBS | Task | Type | Duration | Start | Finish | Complete | Remaining | Baseline start | Baseline finish | Baseline duration | Total slack | Constraint | Resources | Work | Actual work | Text9 | Text6 | Text1 | Text4 | Text5 | Text7 | Text8 | Text12 |
| --- | --- | --- | --- | --- | --- | --- | --- | --- | --- | --- | --- | --- | --- | --- | --- | --- | --- | --- | --- | --- | --- | --- | --- | --- |
| 1 | 1 | VERSION 2007 January 18th |  | 1d | 2000-01-03 | 2000-01-03 |  |  | 2000-01-03 | 2000-01-03 | 1d | 2224d |  |  |  |  | 2044 |  |  |  |  |  |  |  |
| 2 | 2 | "CTRL + a" to display all the 3GPP fields |  | 1d | 2000-01-03 | 2000-01-03 |  |  | 2000-01-03 | 2000-01-03 | 1d | 2224d |  |  |  |  | 1462 |  |  |  |  |  |  |  |
| 3 | 3 | Content of Rel-7 and Rel-8 (not frozen) |  | 1d | 2000-01-03 | 2000-01-03 |  |  | 2000-01-03 | 2000-01-03 | 1d | 2224d |  |  |  |  | 2058 |  |  |  |  |  |  |  |
| 5 | 4 | Rel-7 Features |  | 1d? | 2000-01-03 | 2000-01-03 |  |  | 2000-01-03 | 2000-01-03 | 1d? | 2224d |  | CT;RAN;SA | 8h |  |  | Rel-7 |  |  |  |  |  |  |
| 6 | 8.5 | **Multiple Input Multiple Output antennas (MIMO)** |  | 1044d? | 2003-03-14 A | 2007-03-15 | 55% | 466.15d? | 2003-03-14 | 2007-03-15 | 1044d? | 347d |  | R1 | 38120h | 18575.6h | 2468 | Rel-7 | MIMO | Howard Huang, Lucent | hchuang@lucent.com | TSG | Claude |  |
| 7 | 5.1 | MIMO - Physical layer |  | 914d? | 2003-09-12 A | 2007-03-15 | 95% | 45.7d? | 2003-09-12 | 2007-03-15 | 914d? | 347d | finish no earlier than 2007-03-15 | R1 | 7312h | 6946.4h |  | Rel-7 | MIMO-Phys | Howard Huang, Lucent | hchuang@lucent.com | TSG | MCC_RAN |  |
| 8 | 5.2 | MIMO - Layer 2,3 aspects |  | 914d? | 2003-09-12 A | 2007-03-15 | 50% | 457d? | 2003-09-12 | 2007-03-15 | 914d? | 347d | finish no earlier than 2007-03-15 | R2 | 7312h | 3656h |  | Rel-7 | MIMO-L23 | Howard Huang, Lucent | hchuang@lucent.com | TSG | MCC_RAN |  |
| 9 | 5.3 | MIMO - Iub/Iur Protocol Aspects |  | 1044d? | 2003-03-14 A | 2007-03-15 | 50% | 522d? | 2003-03-14 | 2007-03-15 | 1044d? | 347d | finish no earlier than 2007-03-15 | R3 | 8352h | 4176h |  | Rel-7 | MIMO-IurIub | Howard Huang, Lucent | hchuang@lucent.com | TSG | MCC_RAN |  |
| 10 | 5.4 | MIMO - RF Radio Transmission/Reception, System Performance Requirements and Conformance Testing |  | 849d? | 2003-12-12 A | 2007-03-15 | 25% | 636.75d? | 2003-12-12 | 2007-03-15 | 849d? | 347d | finish no earlier than 2007-03-15 | R4 | 6792h | 1698h |  | Rel-7 | MIMO-RF | Man Hung Ng, Lucent | ngm@lucent.com | TSG | MCC_RAN |  |
| 11 | 6 | **Rel-7 Improvements of the Radio Interface** |  | 652d? | 2004-09-15 A | 2007-03-15 | 87% | 81.76d? | 2004-09-15 | 2007-03-15 | 652d? | 346d |  | RP | 30352h | 22520.4h |  | Rel-7 | RInImp |  |  |  | Claude |  |
| 12 | 6.1 | Extended UMTS 1.7/2.1 GHz |  | 198d? | 2006-03-15 A | 2006-12-15 A | 100% |  | 2006-03-15 | 2006-12-15 | 198d? |  | finish no earlier than 2006-12-15 | R4 | 1584h | 1584h |  | Rel-7 | RInImp-UMTS1721Ext | Johan Sköld | johan.skold@ericsson.com |  | MCC_RAN |  |
| 13 | 6.2 | UMTS 2.6 GHz 7.68 MHz TDD |  | 67d? | 2006-06-15 A | 2006-09-15 A | 100% |  | 2006-06-15 | 2006-09-15 | 67d? |  | finish no earlier than 2006-09-15 | R4 | 536h | 536h |  | Rel-7 | RInImp-UMTS26VHCRTDD | Shin Horng Wong , IPWireless | shwong@ipwireless.com |  | MCC_RAN |  |
| 14 | 6.3 | UMTS 2.6 GHz |  | 195d? | 2004-09-15 A | 2005-06-14 A | 100% |  | 2004-09-15 | 2005-06-14 | 195d? |  | finish no earlier than 2005-06-14 | R4 | 1560h | 1560h |  | Rel-7 | RInImp-UMTS2600 | Jussi Numminen, Nokia | jussi.numminen@nokia.com | TSG | Claude |  |
| 15 | 6.4 | UMTS 2.6 GHz TDD |  | 261d? | 2004-12-15 A | 2005-12-14 A | 100% |  | 2004-12-15 | 2005-12-14 | 261d? |  | finish no earlier than 2005-12-15 | R4 | 2088h | 2088h |  | Rel-7 | RInImp-UMTS2600TDD | Shin Horng Wong (IPWireless) | shwong@IPWIRELESS.COM | TSG | MCC_RAN |  |
| 16 | 6.5 | UMTS 900 MHz |  | 261d? | 2004-12-15 A | 2005-12-14 A | 100% |  | 2004-12-15 | 2005-12-14 | 261d? |  | finish no earlier than 2005-12-15 | R4 | 2088h | 2088h |  | Rel-7 | RInImp-UMTS900 | Yannick Li (Nortel) | yli@nortelnetworks.com | TSG | MCC_RAN |  |
| 17 | 6.6 | UMTS 1700 MHz |  | 197d? | 2005-03-15 A | 2005-12-14 A | 100% |  | 2005-03-15 | 2005-12-14 | 197d? |  | finish no earlier than 2005-12-15 | R4 | 1576h | 1576h |  | Rel-7 | RInImp-UMTS1700 | Takehiro Nakamura | NTT DoCoMo | TSG | MCC_RAN |  |
| 18 | 6.7 | UE Antenna Performance Evaluation Method and Requirements |  | 587d? | 2004-12-15 A | 2007-03-15 | 80% | 117.4d? | 2004-12-15 | 2006-12-15 | 523d? | 346d | finish no earlier than 2007-03-15 | R4 | 4696h | 3756.8h |  | Rel-7 | RInImp-UEAnt | Christian Bergljung (TeliaSonera) | Christian.Bergljung@TeliaSonera.com | TSG | MCC_RAN |  |
| 19 | 6.8 | Improved Performance Requirements for HSDPA UE based on Rx Diversity (type 1) & LMMSE equalizer (type 2) | milestone | 0d? | 2005-03-15 A | 2005-03-15 A | 100% |  | 2005-03-15 | 2005-03-15 | 0d? |  | finish no earlier than 2005-03-15 | R4 |  |  |  | Rel-7 | RInImp-HSPerf-Type3 | Marc Grant | marc.grant@cingular.com | TSG | MCC_RAN |  |
| 20 | 6.9 | **Additional minimum UE performance requirement for non-HSDPA channels based on type 1 enhanced receiver (Rx Diversity)** |  | 327d? | 2005-09-15 A | 2006-12-15 | 99% | 0d? | 2005-09-15 | 2007-03-15 | 391d? | 0d |  | R4 | 7344h | 5500.08h |  | Rel-7 | RInImp-RxDiv | Serge Willenegger | sergew@qualcomm.com |  | MCC_RAN |  |
| 21 | 6.9.1 | Additional minimum UE performance requirement for DL physical channels in support of DCH/HS-DSCH operation based on type 1 enhanced receiver (RX-Diversity) |  | 195d? | 2005-09-15 A | 2006-06-14 A | 100% |  | 2005-09-15 | 2006-06-14 | 195d? |  | finish no earlier than 2006-06-15 | R4 | 1560h | 1560h |  | Rel-7 | RInImp-RxDiv-DCH | Marc Grant | marc.grant@cingular.com | TSG | MCC_RAN |  |
| 22 | 6.9.2 | Additional minimum UE performance requirement for downlink physical channels in support of MTCH and MCCH operation based on type 1 enhanced receiver (Rx-Diversity) |  | 198d? | 2006-03-15 A | 2006-12-15 A | 100% |  | 2006-03-15 | 2007-03-15 | 262d? |  | finish no earlier than 2006-12-15 | R4 | 1584h | 1584h |  | Rel-7 | RInImp-RxDiv-MBMS | Serge Willenegger | sergew@qualcomm.com |  | MCC_RAN |  |
| 23 | 6.9.3 | Additional minimum UE performance requirement for downlink physical channels in support of E-DCH operation based on type 1 enhanced receiver (Rx-Diversity) |  | 198d? | 2006-03-15 A | 2006-12-15 A | 100% |  | 2006-03-15 | 2007-03-15 | 262d? |  | finish no earlier than 2006-12-15 | R4 | 1584h | 1584h |  | Rel-7 | RInImp-RxDiv-EDCH | Serge Willenegger | sergew@qualcomm.com |  | MCC_RAN |  |
| 24 | 6.10 | Improved support of gaming over HSDPA/EDCH |  | 262d? | 2005-12-15 A | 2006-12-15 | 40% | 157.2d? | 2005-12-15 | 2006-12-15 | 262d? | 410d | finish no earlier than 2006-12-15 | R2 | 2096h | 838.4h |  | Rel-7 | RInImp-Gaming | Don Zelmer, Cingular | don.zelmer@cingular.com |  | MCC_RAN |  |
| 25 | 6.11 | Interface to control Tower Mounted Amplifiers (TMAs) |  | 196d? | 2006-06-15 A | 2007-03-15 | 60% | 78.4d? | 2006-06-15 | 2006-12-15 | 132d? | 346d | finish no earlier than 2007-03-15 | R3 | 1568h | 940.8h |  | Rel-7 | RInImp-TMA | Alexej Kulakov, Vodafone |  |  | MCC_RAN |  |
| 26 | 6.12 | Deleted (not approved at PCG) - UMTS 2.6 GHz FDD DL External | milestone | 0d? | 2005-09-15 A | 2005-09-15 A | 100% |  | 2005-09-15 | 2005-09-15 | 0d? |  | finish no earlier than 2005-09-15 | R4 |  |  |  | Rel-7 | RInImp-UMTS2600Ext | Han van Bussel | han.van.bussel@t-mobile.de | TSG | MCC_RAN | RP-31 |

Notes:
- 6: hchuang@lucent.com / Text3: TR25.876,TR25.996
- 7: hchuang@lucent.com / Text3: 25.211, 25.212, 25.213, 25.214, 25.215, 25.221, 25
- 8: hchuang@lucent.com / Text3: TR 25.876
- 9: hchuang@lucent.com
- 10: ngm@lucent.com
- 12: Approved at RP#34 as RP-060681 / Text3: 25.806, 25.101, 25.104, 25.133, 24.141, 25.331, 25.306, 25.307, 25.423, 25.461, 25.463, 34.121
- 13: Approved at RP#33 as RP-060451 / Text3: 25.102, 25.105, 25.123, 25.113, 25.142, 34.124
- 14: Approved at RP#25 as RP-040377 / Text3: TS25.101, TS25.104, TS25.133, TS25.141, TS25.331, TS25.942, TS25.306, TS25.307, TS34.121
- 15: Text3: 25.102, 25.105, 25.113, 25.123, 25.142, 25.331, 25.942, 25.306, 25.307, 34.122, 34.124
- 16: Text3: 25.101, 25.104, 25.113, 25.133, 25.141, 25.331, 25.942, 25.306, 25.307, 34.121
- 17: Text3: 25.101, 25.104, 25.113, 25.133, 25.141, 25.306, 25.307, 25.331, 34.121
- 18: Text3: TS25.101
- 19: Text3: 25.101
- 21: Text3: 25.101
- 22: Approved at RP#34 as RP-060678 / Text3: 25.101
- 23: Approved at RP#34 as RP-060679 / Text3: 25.101
- 24: Closed at RP#34 as RP-060680
- 26: This item was conditionnaly approved pending decision of PCG 16 who decided not to approve it / Text3: 25.101, 25.104, 25.133, 25.141, 25.331, 25.942, 25.306, 25.307, 34.121

| ID | WBS | Task | Duration | Start | Finish | Complete | Remaining | Baseline start | Baseline finish | Baseline duration | Total slack | Constraint | Resources | Work | Actual work | Text1 | Text4 | Text5 | Text6 | Text7 | Text8 |
| --- | --- | --- | --- | --- | --- | --- | --- | --- | --- | --- | --- | --- | --- | --- | --- | --- | --- | --- | --- | --- | --- |
| 27 | 7 | **7.68Mcps TDD option** | 457d? | 2004-09-15 A | 2006-06-15 A | 100% |  | 2004-09-15 | 2006-06-15 | 457d? |  |  | RP | 19824h | 19824h | VHCRTDD | Martin Beale, IPWireless | mbeale@ipwireless.com | Rel-7 | TSG | Claude |
| 28 | 7.1 | VHCRTDD: Stage 2 | 391d? | 2004-09-15 A | 2006-03-15 A | 100% |  | 2004-09-15 | 2006-03-15 | 391d? |  | finish no earlier than 2006-03-15 | R1 | 3128h | 3128h | VHCRTDD-Stage2 | Martin Beale, IPWireless | mbeale@ipwireless.com | Rel-7 | TSG | MCC_RAN |
| 29 | 7.2 | VHCRTDD: Physical Layer | 391d? | 2004-09-15 A | 2006-03-15 A | 100% |  | 2004-09-15 | 2006-03-15 | 391d? |  | finish no earlier than 2006-03-15 | R1 | 3128h | 3128h | VHCRTDD-Phys | Martin Beale, IPWireless | mbeale@ipwireless.com | Rel-7 | TSG | MCC_RAN |
| 30 | 7.3 | VHCRTDD: Layer 2 and layer 3 protocol aspects | 391d? | 2004-09-15 A | 2006-03-15 A | 100% |  | 2004-09-15 | 2006-03-15 | 391d? |  | finish no earlier than 2006-03-15 | R2 | 3128h | 3128h | VHCRTDD-L23 | Derek Richards, IPWireless | drichards@ipwireless.com | Rel-7 | TSG | MCC_RAN |
| 31 | 7.4 | VHCRTDD: UTRAN Iub/Iur Protocol Aspects | 391d? | 2004-09-15 A | 2006-03-15 A | 100% |  | 2004-09-15 | 2006-03-15 | 391d? |  | finish no earlier than 2006-03-15 | R3 | 3128h | 3128h | VHCRTDD-IurIub | Peter Legg, IPWireless | plegg@ipwireless.com | Rel-7 | TSG | MCC_RAN |
| 32 | 7.5 | VHCRTDD: RF Radio Transmission/ Reception, System Performance Requirements and Conformance Testing | 457d? | 2004-09-15 A | 2006-06-15 A | 100% |  | 2004-09-15 | 2006-06-15 | 457d? |  | finish no earlier than 2006-06-15 | R4 | 3656h | 3656h | VHCRTDD-RF | Shin Horng Wong | shwong@ipwireless.com | Rel-7 | TSG | MCC_RAN |
| 33 | 8 | **Rel-7 RAN improvements** | 587d? | 2004-12-15 A | 2007-03-15 | 87% | 79.21d? | 2004-12-15 | 2006-12-15 | 523d? | 346d |  | RP | 24344h | 17689.2h | RANimp |  |  | Rel-7 | TSG | MCC_RAN |
| 34 | 8.1 | Optimisation of channelisation code utilisation for 1.28 Mcps TDD | 523d? | 2004-12-15 A | 2006-12-15 A | 100% |  | 2004-12-15 | 2006-12-15 | 523d? |  | finish no earlier than 2006-12-15 | R1 | 4184h | 4184h | RANimp-RABSE-CodOptLCRTDD | Ka Leong Lo | kaleong.lo@utstar.com | Rel-7 | TSG | MCC_RAN |
| 35 | 8.2 | Delay optimisation for procedures applicable to CS and PS Connections | 394d? | 2005-03-15 A | 2006-09-15 A | 100% |  | 2005-03-15 | 2006-09-15 | 394d? |  | finish no earlier than 2006-09-15 | R2 | 3152h | 3152h | RANimp-DelayOpt | Juho Pirskanen | juho.pirskanen@nokia.com | Rel-7 | TSG | MCC_RAN |
| 36 | 8.3 | UE Performance Requirements for MBMS (TDD) | 328d? | 2005-03-15 A | 2006-06-15 A | 100% |  | 2005-03-15 | 2006-06-15 | 328d? |  | finish no earlier than 2006-06-15 | R4 | 2624h | 2624h | MBMS-RAN-RF-TDD | Shin Horng Wong | shwong@ipwireless.com | Rel-7 | TSG | MCC_RAN |
| 37 | 8.4 | Continuous connectivity for packet data users | 524d? | 2005-03-14 A | 2007-03-15 | 90% | 52.4d? | 2005-03-14 | 2006-12-15 | 460d? | 346d | finish no earlier than 2007-03-15 | R1 | 4192h | 3772.8h | RANimp-CPC | Joern Krause | Joern.Krause@siemens.com | Rel-7 | TSG | MCC_RAN |
| 38 | 8.5 | Extended WCDMA Cell Range | 198d? | 2006-03-15 A | 2006-12-15 A | 100% |  | 2006-03-15 | 2006-12-15 | 198d? |  | finish no earlier than 2006-12-15 | R3 | 1584h | 1584h | RANimp-ExtCell | Ericsson |  | Rel-7 |  | MCC_RAN |
| 39 | 8.6 | 7.68 Mcps TDD Enhanced Uplink | 198d? | 2006-03-15 A | 2006-12-15 A | 100% |  | 2006-03-15 | 2006-12-15 | 198d? |  | finish no earlier than 2006-12-15 | R1 | 1584h | 1584h | RANimp-VHCRTDD-EDCH | Nicholas Anderson | nanderson@ipwireless.com | Rel-7 |  | MCC_RAN |
| 40 | 8.7 | Enhanced CELL_FACH State in FDD | 120d? | 2006-09-25 A | 2007-03-09 | 10% | 108d? | 2006-09-25 | 2007-03-09 | 120d? | 350d | start no earlier than 2006-09-22 | R2 | 960h | 96h | RANimp-EnhState | Juho Pirskanen, Nokia | juho.pirskanen@nokia.com | Rel-7 |  | MCC_RAN |
| 41 | 8.8 | 64QAM for HSDPA (FDD) | 53d? | 2006-12-15 | 2007-03-15 |  |  | 2006-09-25 | 2007-03-09 | 120d? | 346d | finish no earlier than 2007-03-15 | R1 | 424h |  | RANimp-64QamDownlink | Johan Bergman | Johan.Bergman@ericsson.com | Rel-7 |  | MCC_RAN |
| 42 | 8.9 | Improved L2 support for high data rates | 65d? | 2006-12-15 | 2007-03-15 |  |  | 2006-09-25 | 2007-03-09 | 120d? | 346d | finish no earlier than 2007-03-15 | R2 | 520h |  | RANimp-L2DataRates | Janne Peisa | Janne.Peisa@ericsson.com | Rel-7 |  | MCC_RAN |
| 43 | 8.10 | Introduction of 16QAM in HSUPA (FDD) | 53d? | 2006-12-15 | 2007-03-15 |  |  | 2006-09-25 | 2007-03-09 | 120d? | 346d | finish no earlier than 2007-03-15 | R1 | 424h |  | RANimp-16QamUplink | Karri Ranta-aho | karri.ranta-aho@nokia.com | Rel-7 |  | MCC_RAN |
| 44 | 9 | **3.84 Mcps TDD Enhanced Uplink** | 394d? | 2005-03-15 A | 2006-09-15 A | 100% |  | 2005-03-15 | 2006-09-15 | 394d? |  |  | RP | 18384h | 18384h | EDCHTDD | Nicholas Anderson | nanderson@ipwireless.com | Rel-7 | TSG | MCC_RAN |
| 45 | 9.1 | EDCHTDD: Stage 2 | 328d? | 2005-03-15 A | 2006-06-15 A | 100% |  | 2005-03-15 | 2006-06-15 | 328d? |  | finish no earlier than 2006-06-15 | R2 | 2624h | 2624h | EDCHTDD-Stage2 | Nicholas Anderson | nanderson@ipwireless.com | Rel-7 | TSG | MCC_RAN |
| 46 | 9.2 | EDCHTDD: Physical Layer | 394d? | 2005-03-15 A | 2006-09-15 A | 100% |  | 2005-03-15 | 2006-09-15 | 394d? |  | finish no earlier than 2006-09-15 | R1 | 3152h | 3152h | EDCHTDD-Phys | Nicholas Anderson | nanderson@ipwireless.com | Rel-7 | TSG | MCC_RAN |
| 47 | 9.3 | EDCHTDD: Layer 2 and 3 Protocol Aspects | 394d? | 2005-03-15 A | 2006-09-15 A | 100% |  | 2005-03-15 | 2006-09-15 | 394d? |  | finish no earlier than 2006-09-15 | R2 | 3152h | 3152h | EDCHTDD-L23 | Derek Richards | drichards@ipwireless.com | Rel-7 | TSG | MCC_RAN |
| 48 | 9.4 | EDCHTDD: UTRAN Iub/Iur Protocol Aspects | 394d? | 2005-03-15 A | 2006-09-15 A | 100% |  | 2005-03-15 | 2006-09-15 | 394d? |  | finish no earlier than 2006-09-15 | R3 | 3152h | 3152h | EDCHTDD-IurIub | Jim Miller | jim.miller@interdigital.com | Rel-7 | TSG | MCC_RAN |
| 49 | 9.5 | EDCHTDD: RF Radio Transmission/ Reception, System Performance Requirements and Conformance Testing | 394d? | 2005-03-15 A | 2006-09-15 A | 100% |  | 2005-03-15 | 2006-09-15 | 394d? |  | finish no earlier than 2006-09-15 | R4 | 3152h | 3152h | EDCHTDD-RF | Shin Horng Wong | shwong@ipwireless.com | Rel-7 | TSG | MCC_RAN |
| 50 | 10 | **1.28 Mcps TDD Enhanced Uplink** | 328d? | 2006-03-15 A | 2007-06-15 | 50% | 165.03d? | 2006-03-15 | 2007-03-15 | 262d? | 280d |  | RP | 11536h | 5058.27h | LCRTDD-EDCH | Haijing Hu (CATT) |  | Rel-7 |  | MCC_RAN |
| 51 | 10.1 | 1.28 Mcps TDD Enhanced Uplink: Physical Layer | 262d? | 2006-03-15 A | 2007-03-15 | 75% | 65.5d? | 2006-03-15 | 2006-12-15 | 198d? | 346d | finish no earlier than 2007-03-15 | R1 | 2096h | 1572h | LCRTDD-EDCH-Phys | Ke Wang (CATT) |  | Rel-7 |  | MCC_RAN |
| 52 | 10.2 | 1.28 Mcps TDD Enhanced Uplink: Layer 2 and 3 Protocol Aspects | 262d? | 2006-03-15 A | 2007-03-15 | 80% | 52.4d? | 2006-03-15 | 2006-12-15 | 198d? | 346d | finish no earlier than 2007-03-15 | R2 | 2096h | 1676.8h | LCRTDD-EDCH-L23 | Haiyang Quan (CATT) |  | Rel-7 |  | MCC_RAN |
| 53 | 10.3 | 1.28 Mcps TDD Enhanced Uplink: UTRAN Iub/Iur Protocol Aspects | 262d? | 2006-03-15 A | 2007-03-15 | 50% | 131d? | 2006-03-15 | 2006-12-15 | 198d? | 346d | finish no earlier than 2007-03-15 | R3 | 2096h | 1048h | LCRTDD-EDCH-IubIur | Yincheng Zhang (CATT) |  | Rel-7 |  | MCC_RAN |
| 54 | 10.4 | 1.28 Mcps TDD Enhanced Uplink: RF Radio Transmission/ Reception, System Performance Requirements and Conformance Testing | 328d? | 2006-03-15 A | 2007-06-15 | 5% | 311.6d? | 2006-03-15 | 2007-03-15 | 262d? | 280d | finish no earlier than 2007-06-15 | R4 | 2624h | 131.2h | LCRTDD-EDCH-RF | Yuexia Song (CATT) |  | Rel-7 |  | MCC_RAN |

Notes:
- 27: Approved at RP#25 as RP-040365
- 28: Feature completed and closed at RP#33 with the presentation of the test WI / Text3: TS25.202
- 29: Feature completed and closed at RP#33 with the presentation of the test WI / Text3: TS25.221, TS25.222, TS25.223, TS25.224,TS25.225
- 30: Feature completed and closed at RP#33 with the presentation of the test WI / Text3: TS25.301, TS25.302, TS25.305, TS25.306, TS25.321, TS25.331
- 31: Feature completed and closed at RP#33 with the presentation of the test WI / Text3: TS25.401, TS25.420, TS25.423, TS25.425, TS25.427, TS25.430, TS25.433, TS25.435
- 32: Feature completed and closed at RP#33 with the presentation of the test WI / Text3: TS25.102, TS25.105, TS25.123, TS25.133, TS25.142
- 33: Generic feature
- 34: Approved at RP#34 as RP-060682
- 35: Approved at RP#33 as RP-060453 / Text3: TS25.321, TS25.322, TS25.331
- 36: WI completed and closed with the presentation of the test WI / Text3: TS25.102, TS25.123
- 38: Approved at RP#34 as RP-060685 / Text3: 25.133, 25.423, 25.425, 25.433, 25.435, 25.453, 25.331
- 39: Approved at RP#34 as RP-060684 / Text3: 25.201, 25.202, 25.221, 25.222, 25.223, 25.224, 25.225, 25.331, 23.321, 25.306, 25.302, 25.401, 25.420, 25.423, 25.427, 25.433, 25.102, 25.105, 25.142
- 40: WI Acronym corrected / Text3: 25.308, 25.304, 25.306, 25.321, 25.331, 25.433, 25.435, 25.423, 25.425,
- 41: Text3: 25.308, 25.211, 25.212, 25.213, 25.306, 25.331, 25.433, 25.435, 25.423, 25.425, 25.101, 25.104, 25.141
- 42: Text3: 25.301, 25.306, 25.321, 25.322, 25.331, 25.433, 25.435, 25.423, 25.425
- 43: Text3: 25.319, 25.101, 25.104, 25.133, 25.141, 25.211, 25.212, 25.213, 25.214, 25.306, 25.321, 25.331, 25.423, 25.433
- 44: Approved at RP#33 as RP-060462
- 46: Text3: TS25.201, TS25.221,TS25.222, TS25.223, TS25.224, TS25.225
- 47: Text3: TS25.301, TS25.302, TS25.306, TS25.321, TS25.331
- 48: Text3: TS25.401, TS25.420, TS25.423, TS25.427, TS25.430, TS25.433, TS25.435
- 49: Text3: TS25.102, TS25.105, TS25.123, TS25.142
- 51: Text3: 25.201, 25.221, 25.222, 25.223, 25.224, 25.225
- 52: Text3: 25.301, 25.302, 25.306, 25.321, 25.331
- 53: Text3: 25.401, 25.420, 25.423, 25.425, 25.427, 25.430, 25.433, 25.435
- 54: Text3: 25.102, 25.105, 25.123, 25.142

| ID | WBS | Task | Type | Duration | Start | Finish | Complete | Remaining | Baseline start | Baseline finish | Baseline duration | Total slack | Constraint | Resources | Work | Actual work | Text1 | Text4 | Text6 | Text7 | Text8 | Text2 | Text3 | Text9 | Text5 | Text12 |
| --- | --- | --- | --- | --- | --- | --- | --- | --- | --- | --- | --- | --- | --- | --- | --- | --- | --- | --- | --- | --- | --- | --- | --- | --- | --- | --- |
| 55 | 11 | **PS domain and IMS impacts for supporting IMS Emergency calls** |  | 1694d? | 2000-09-18 A | 2007-03-15 | 82% | 311.96d? | 2000-09-18 | 2007-03-15 | 1694d? | 346d |  | S2 | 44685h | 35663.8h | EMC1 | Rainer Liebhart | Rel-7 | TSG | Maurice |  |  |  |  |  |
| 56 | 10.1.1 | Service Requirements for IP-based emergency calls |  | 985d | 2000-09-18 A | 2004-06-25 A | 100% |  | 2000-09-18 | 2004-06-25 | 985d |  | finish no earlier than 2004-06-25 | S1 | 7880h | 7880h | EMC1-s1 |  | Rel-7 |  |  | CCaR | 22.976 | 1314 |  |  |
| 57 | 11.2 | Study on Stage 2 for IMS-level solution |  | 668d? | 2003-02-26 A | 2005-09-16 A | 100% |  | 2003-02-26 | 2005-09-16 | 668d? |  | finish no earlier than 2005-09-16 | S2 | 5344h | 5344h | EMC1-FSIMS | Rainer Liebhart, Siemenws | Rel-7 | TSG |  |  | 23.228, 23.060, 23.002 |  |  |  |
| 58 | 11.3 | Study on Stage 2 for GPRS-level solution |  | 301d? | 2004-10-14 A | 2005-12-08 A | 100% |  | 2004-10-14 | 2005-12-08 | 301d? |  | finish no earlier than 2005-12-08 | S2 | 2408h | 2408h | EMC1-FSGPRS |  | Rel-7 |  |  |  |  |  |  |  |
| 59 | 11.4 | Stage 2 Specification Phase - IMS-level |  | 200d? | 2005-09-05 A | 2006-06-09 A | 100% |  | 2005-09-05 | 2006-06-09 | 200d? |  | finish no earlier than 2006-06-09 | S2 | 1600h | 1600h | EMC1-IMSs2 |  | Rel-7 |  |  |  |  |  |  |  |
| 60 | 11.5 | Stage 2 Specification Phase - GPRS-level |  | 390d? | 2005-09-05 A | 2007-03-02 | 75% | 97.5d? | 2005-09-05 | 2006-12-29 | 345d? | 355d | finish no earlier than 2007-03-02 | S2 | 3120h | 2340h | EMC1-GPRSs2 |  | Rel-7 |  |  |  |  |  |  |  |
| 61 | 10.1 | **Emergency Call Enhancements for IP& PS Based Calls – stage 3** |  | 309d | 2006-01-09 A | 2007-03-15 | 47% | 164.68d | 2006-01-09 | 2007-03-15 | 309d | 346d |  | C1 | 10781h | 5035.45h | EMC1 | Alf Heidermark (Ericsson) | Rel-7 |  |  | CCaR |  | 1653 | alf.heidermark@ericsson.com |  |
| 62 | 10.1.2 | CT1 IMS aspects to support IMS Emergency sessions |  | 284.82d | 2006-01-09 A | 2007-03-15 | 80% | 56.96d | 2006-01-09 | 2007-03-15 | 284.82d | 346d | finish no earlier than 2007-03-15 | C1 | 2278.56h | 1822.85h | EMC1-IMSc1 | Alf Heidermark (Ericsson) | Rel-7 |  |  | CCaR | 24.229 | 1315 | alf.heidermark@ericsson.com |  |
| 63 | 10.1.2 | CT3 IMS aspects to support IMS Emergency sessions |  | 95d | 2006-05-08 A | 2006-09-15 | 40% | 57d | 2006-05-08 | 2006-09-15 | 95d | 475d | finish no earlier than 2006-09-15 | C3 | 760h | 304h | EMC1-IMSc3 | Alf Heidermark (Ericsson) | Rel-7 |  |  | CCaR | 29.163 | 1315 | alf.heidermark@ericsson.com |  |
| 64 | 10.1.5 | CT3 PS domain aspects to support IMS Emergency sessions |  | 95d | 2006-05-08 A | 2006-09-15 | 40% | 57d | 2006-05-08 | 2006-09-15 | 95d | 475d | start no earlier than 2006-05-08 | C3 | 760h | 304h | EMC1-GPRSc3 | Alf Heidermark (Ericsson) | Rel-7 |  |  | CCaR | 29.061 | 1646 | alf.heidermark@ericsson.com |  |
| 65 | 10.1.5 | CT1 PS domain aspects to support IMS Emergency sessions |  | 283.9d | 2006-01-09 A | 2007-03-15 | 25% | 212.93d | 2006-01-09 | 2007-03-15 | 283.9d | 346d | finish no earlier than 2007-03-15 | C1 | 2271.2h | 567.8h | EMC1-GPRSc1 | Alf Heidermark (Ericsson) | Rel-7 |  |  | CCaR | 24.008, 24.234 | 1646 | alf.heidermark@ericsson.com |  |
| 66 | 10.1.5 | CT4 PS domain aspects to support IMS Emergency sessions |  | 305d | 2006-01-09 A | 2007-03-09 | 40% | 183d | 2006-01-09 | 2006-09-15 | 180d | 350d | finish no earlier than 2007-03-09 | C4 | 2440h | 976h | EMC1-GPRSc4 | Alf Heidermark (Ericsson) | Rel-7 |  |  | CCaR | 29.060 | 1646 | alf.heidermark@ericsson.com |  |
| 67 | 12 | **Access Class Barring and Overload Protection** |  | 650d? | 2004-03-15 A | 2006-09-08 A | 100% |  | 2004-03-15 | 2006-09-08 | 650d? |  |  | S2 | 8768h | 8768h | ACBOP | Chris Pudney, Vodafone | Rel-7 | TSG | Maurice |  | 23.898 |  |  |  |
| 68 | 12.1 | TR on Stage 2 |  | 274d? | 2004-03-15 A | 2005-03-31 A | 100% |  | 2004-03-15 | 2005-03-31 | 274d? |  | finish no earlier than 2005-03-31 | S2 | 2192h | 2192h | ACBOP-FS |  | Rel-7 | TSG |  |  |  |  |  |  |
| 69 | 12.2 | Stage 3 CN aspects of ACBOP |  | 172d? | 2005-06-06 A | 2006-01-31 A | 100% |  | 2005-06-06 | 2006-01-31 | 172d? |  | start no earlier than 2005-06-06 | C1 | 1376h | 1376h | ACBOP-c1 |  | Rel-7 |  |  |  | 24.008 |  |  |  |
| 70 | 12.3 | Deleted - Potential impact on Iu interface Overload functionality | milestone | 0d? | 2004-03-15 A | 2004-03-15 A | 100% |  | 2004-03-15 | 2004-03-15 | 0d? |  | finish no earlier than 2004-03-15 | RP |  |  |  |  | Rel-7 |  |  |  | 25.413 |  |  | RP-25 |
| 71 | 12.4 | Deleted - Extra ACBOP information in RAN | milestone | 0d? | 2004-03-15 A | 2004-03-15 A | 100% |  | 2004-03-15 | 2004-03-15 | 0d? |  | finish no earlier than 2004-03-15 | RP |  |  |  |  | Rel-7 |  |  |  | 25.331 |  |  | RP-25 |
| 72 | 12.5 | Deleted - Extra ACBOP information in GERAN | milestone | 0d? | 2006-09-08 A | 2006-09-08 A | 100% |  | 2006-09-08 | 2006-09-08 | 0d? |  | start no earlier than 2006-09-08 | GP |  |  |  |  | Rel-7 | TSG | Gert |  | 44.018 |  |  | RP-33 |
| 73 | 13 | **USSD message delivery and transfer to USIM** |  | 376d? | 2004-03-05 A | 2005-08-12 A | 100% |  | 2004-03-05 | 2005-08-12 | 376d? |  |  | S1 | 5698.4h | 5698.4h | USSD-USIM |  | Rel-7 | TSG | Michael |  | 22.090 |  |  |  |
| 74 | 13.1 | Stage 1 |  | 152d? | 2004-03-18 A | 2004-10-15 A | 100% |  | 2004-03-18 | 2004-10-15 | 152d? |  | start no earlier than 2004-03-18 | S1 | 1216h | 1216h | USSD-USIM |  | Rel-7 | TSG | Michael |  | 22.090 |  |  |  |
| 75 | 13.2 | Alignment with requirements regarding USSD usage |  | 193.3d? | 2004-03-05 A | 2005-08-12 A | 100% |  | 2004-03-05 | 2005-08-12 | 193.3d? |  | finish no earlier than 2005-08-12 | C6 | 1546.4h | 1546.4h | USSD-USIM | Christophe Dubois (Axalto) | Rel-7 | TSG |  |  |  |  | cdubois@axalto.com |  |
| 76 | 14 | **Location Services enhancements Rel-7** |  | 752d? | 2004-06-28 A | 2007-05-15 | 91% | 71.36d? | 2004-06-28 | 2007-03-15 | 709d? | 303d |  | S2 | 42117.6h | 30829.2h | LCS3 |  | Rel-7 |  | Maurice |  | 23.271 |  |  |  |
| 77 | 14.1 | Global Stage 2 for LCS3 (including IMS emergency location aspects) |  | 446d? | 2004-12-31 A | 2006-09-15 A | 100% |  | 2004-12-31 | 2006-09-15 | 446d? |  | finish no earlier than 2006-09-15 | S2 | 3568h | 3568h | LCS3-s2 | Ben Rodilitz, SiRF | Rel-7 | TSG | Maurice |  | 23.271 |  | brodilitz@sirf.com |  |
| 78 | 14.2 | CT4 aspects for LCS |  | 240d? | 2006-01-02 A | 2006-12-01 | 95% | 12d? | 2006-01-02 | 2006-04-03 | 66d? | 420d | finish no earlier than 2006-12-01 | C4 | 1920h | 1824h | LCS3-UEPos-LBS |  | Rel-7 | TSG |  |  |  |  |  |  |

Notes:
- 65: end date updated by CT1-chairman after CT#33
- 66: CRs Approved in WLAN 40 % done after CT4#33
- 69: NEW - inserted on 2/9/2004
- 77: Approved SA#27. Appropriate place forEmergency work to be found
- 78: CRs approved in CT4#30...

| ID | WBS | Task | Type | Duration | Start | Finish | Complete | Remaining | Baseline start | Baseline finish | Baseline duration | Total slack | Constraint | Resources | Work | Actual work | Text1 | Text6 | Text7 | Text8 | Text5 | Text12 |
| --- | --- | --- | --- | --- | --- | --- | --- | --- | --- | --- | --- | --- | --- | --- | --- | --- | --- | --- | --- | --- | --- | --- |
| 79 | 14.3 | **LCS for 3GPP Interworking WLAN** |  | 700d? | 2004-06-28 A | 2007-03-02 | 77% | 159.6d? | 2004-06-28 | 2006-12-08 | 640d? | 355d |  | S1 | 11901.6h | 4963.2h | LCS3-IWLAN | Rel-7 | TSG | Michael |  |  |
| 80 | 14.3.1 | FS on 3GPP system to WLAN Interworking with LCS |  | 512.7d? | 2004-06-28 A | 2006-06-30 A | 100% |  | 2004-06-28 | 2006-06-30 | 512.7d? |  | finish no earlier than 2005-09-29 | S1 | 4101.6h | 4101.6h | LCS3-IWLAN-FSs1 | Rel-7 |  |  |  |  |
| 81 | 14.3.2 | Study of work on an LCS architecture for I-WLAN. |  | 180d? | 2006-06-26 A | 2007-03-02 | 53% | 84.6d? | 2006-06-26 | 2006-12-08 | 120d? | 355d | finish no earlier than 2007-03-02 | S2 | 1440h | 763.2h | LCS3-IWLAN-FSs2 | Rel-7 |  | Maurice | dhshim@lge.com ; phede@lge.com |  |
| 82 | 14.3.3 | Stage 2 CRs for LCS architecture for I-WLAN. |  | 95d? | 2006-10-23 | 2007-03-02 |  |  | 2006-01-16 | 2006-09-15 | 175d? | 355d | finish no earlier than 2007-03-02 | S2 | 760h |  | LCS3-IWLAN-s2 | Rel-7 |  | Maurice |  |  |
| 83 | 14.4 | **UE positioning Rel-7** |  | 695d? | 2004-09-15 A | 2007-05-15 | 85% | 104.25d? | 2004-09-15 | 2007-03-15 | 652d? | 303d |  | RP | 11120h | 7436.84h | LCS3-UEpos | Rel-7 | TSG | Claude |  |  |
| 84 | 14.4.1 | Inclusion of Uplink TDOA UE positioning method in the UTRAN specifications |  | 695d? | 2004-09-15 A | 2007-05-15 | 85% | 104.25d? | 2004-09-15 | 2007-03-15 | 652d? | 303d | finish no earlier than 2007-05-15 | R2 | 5560h | 4726h | LCS3-UEPos-UTDOA | Rel-7 | TSG | MCC_RAN | rlgross@trueposition.com |  |
| 85 | 14.5 | UE positioning - Velocity |  | 394d? | 2005-03-15 A | 2006-09-15 A | 100% |  | 2005-03-15 | 2005-12-15 | 198d? |  | finish no earlier than 2006-09-15 | R2 | 3152h | 3152h | LCS3-UEPos-Velocity | Rel-7 | TSG | MCC_RAN | BRodilitz@SiRF.com |  |
| 86 | 14.6 | LCS Enhancements Related to Location-Based Services |  | 555d? | 2005-01-03 A | 2007-02-16 A | 100% |  | 2005-01-03 | 2007-02-16 | 555d? |  | finish no earlier than 2007-02-16 | GP | 4440h | 4440h | LCS3-LBS | Rel-7 | TSG | Paolo | kjudge@sirf.com |  |
| 87 | 14.7 | Deleted - RAN2 aspects for LBS | milestone | 0d? | 2005-06-15 A | 2005-06-15 A | 100% |  | 2005-06-15 | 2005-06-15 | 0d? |  | start no earlier than 2005-06-15 | R2 |  |  | LCS3-UEPos-LBS | Rel-7 | TSG | MCC_RAN | BRodilitz@SiRF.com | RP-31 |
| 88 | 15 | A-GPS Minimum Performance |  | 276d? | 2006-04-28 A | 2007-05-18 | 80% | 55.2d? | 2006-04-28 | 2007-04-27 | 261d? | 300d | finish no earlier than 2007-05-18 | G1; G3 | 2208h | 1766.4h | GAGR | Rel-7 |  | Paolo | richard.catmur@spirentcom.com |  |
| 89 | 16 | **Advanced Global Navigation Satellite System (A-GNSS) concept** |  | 709d? | 2004-06-28 A | 2007-03-15 | 42% | 412.45d? | 2004-06-28 | 2007-09-15 | 840d? | 346d |  | S1 | 13649.6h | 3487.2h | LCS3-AGNSS | Rel-7 | TSG | Michael | Michel.monnerat@space.alcatel.fr |  |
| 90 | 16.1 | Deleted - Towards A-GNSS Concept | milestone | 0d? | 2007-02-16 A | 2007-02-16 A | 100% |  | 2004-08-27 | 2006-05-31 | 459d? |  | start no earlier than 2007-02-16 | S1 |  |  | GNSS | Rel-7 | TSG | Paolo | richard.couty@space.alcatel.fr | SP-34 |
| 91 | 16.2 | Towards A-GNSS Concept |  | 671.2d? | 2004-06-28 A | 2007-02-16 | 50% | 335.6d? | 2004-06-28 | 2006-11-17 | 606.2d? | 365d | finish no earlier than 2007-02-16 | GP | 5369.6h | 2684.8h | AGNSS-GP | Rel-7 | TSG | Paolo | richard.couty@space.alcatel.fr |  |
| 92 | 16.3 | Global Navigation Satellite System (GNSS) in UTRAN |  | 326d? | 2005-12-15 A | 2007-03-15 | 25% | 244.5d? | 2005-12-15 | 2007-09-15 | 457d? | 346d | finish no earlier than 2007-03-15 | R2 | 2608h | 652h | LCS3-GNSS-UTRAN | Rel-7 |  | MCC_RAN | alain.abinakhoul@francetelecom.com |  |
| 93 | 17 | **Combinational Services** |  | 296d? | 2005-01-17 A | 2006-03-06 A | 100% |  | 2005-01-17 | 2006-03-06 | 296d? |  |  | S1 | 7544h | 7544h | CSICS | Rel-7 | TSG | Michael | Robert.Frank@teliasonera.com |  |
| 94 | 17.1 | Stage 1 for CSICS |  | 104d? | 2005-01-17 A | 2005-06-09 A | 100% |  | 2005-01-17 | 2005-06-09 | 104d? |  | start no earlier than 2005-01-17 | S1 | 832h | 832h | CSICS-s1 | Rel-7 | TSG |  |  |  |
| 95 | 17.2 | Stage 2 for CSICS |  | 130d? | 2005-01-17 A | 2005-07-15 A | 100% |  | 2005-01-17 | 2005-07-15 | 130d? |  | start no earlier than 2005-01-17 | S2 | 1040h | 1040h | CSICS-s2 | Rel-7 |  |  |  |  |
| 96 | 17.3 | Stage 3 for CSICS CN aspects |  | 221d? | 2005-05-02 A | 2006-03-06 A | 100% |  | 2005-05-02 | 2006-03-06 | 221d? |  | finish no earlier than 2006-03-06 | C1 | 1768h | 1768h | CSICS-c1 | Rel-7 | TSG | Andrijana |  |  |
| 97 | 17.4 | Stage 3 for codec aspects |  | 192d? | 2005-03-15 A | 2005-12-07 A | 100% |  | 2005-03-15 | 2005-12-07 | 192d? |  | finish no earlier than 2005-12-07 | S4 | 1536h | 1536h | CSICS-Codec | Rel-7 | TSG | Paolo | Per.Frojdh@ericsson.com |  |
| 98 | 18 | **System enhancements for fixed broadband access to IMS** |  | 1077d? | 2003-11-05 A | 2007-12-20 | 86% | 155.63d? | 2003-11-05 | 2007-03-15 | 876d? | 146d |  | S2 | 48113.6h | 32445h | FBI | Rel-7 | TSG | Maurice |  |  |
| 99 | 18.1 | **TISPAN Rel 1 related aspects** |  | 873d? | 2003-11-05 A | 2007-03-09 | 93% | 58.19d? | 2003-11-05 | 2006-12-08 | 808d? | 350d |  | S2 | 31568h | 23004.9h | FBI-TIS1 | Rel-7 |  |  |  |  |
| 100 | 18.1.1 | Stage 2 of FBI for TISPAN R1 |  | 365d? | 2004-10-14 A | 2006-03-08 A | 100% |  | 2004-10-14 | 2006-03-08 | 365d? |  | start no earlier than 2004-10-14 | S2 | 2920h | 2920h | FBI-TIS1-s2 | Rel-7 |  | Maurice |  |  |
| 101 | 18.1.2 | **Protocol impact of FBI for TISPAN R1** |  | 873d? | 2003-11-05 A | 2007-03-09 | 94% | 48.63d? | 2003-11-05 | 2006-12-08 | 808d? | 350d |  | C1 | 20720h | 19565.7h | FBI-TIS1-st3 | Rel-7 | TSG | Andrijana |  |  |
| 102 | 18.1.2.1 | CT1 aspects of FBI for TISPAN R1 |  | 802d? | 2003-11-05 A | 2006-11-30 A | 100% |  | 2003-11-05 | 2006-11-30 | 802d? |  | finish no earlier than 2006-11-30 | C1 | 6416h | 6416h | FBI-TIS1-st3-c1 | Rel-7 | TSG | Andrijana |  |  |
| 103 | 18.1.2.2 | CT3 aspects of FBI for TISPAN R1 |  | 808d? | 2003-11-05 A | 2006-12-08 | 98% | 16.16d? | 2003-11-05 | 2006-12-08 | 808d? | 415d | finish no earlier than 2006-12-08 | C3 | 6464h | 6334.72h | FBI-TIS1-st3-c3 | Rel-7 | TSG | Andrijana |  |  |
| 104 | 18.1.2.3 | CT4 aspects of FBI for TISPAN R1 |  | 301d? | 2006-01-13 A | 2007-03-09 | 70% | 90.3d? | 2003-11-05 | 2005-03-03 | 347d? | 350d | finish no earlier than 2007-03-09 | C4 | 2408h | 1685.6h | FBI-TIS1-st3-c4 | Rel-7 | TSG | Andrijana |  |  |
| 105 | 18.1.3 | Security Enhancements for FBI |  | 118d? | 2005-06-28 A | 2005-12-08 | 55% | 53.1d? | 2005-06-28 | 2005-12-08 | 118d? | 676d | start no earlier than 2005-06-28 | S3 | 944h | 519.2h | FBI-ISE | Rel-7 |  | Mike | Bengt.Sahlin@ericsson.com |  |

Notes:
- 79: Text3: 22.935 / Text4: Mike Loushine, (Telcordia)
- 80: DAB - Should be SA1 / Text3: 22.935
- 81: Updated WID at SA#32 to change "stage 2" to "study" , duplicated UID 320017 deleted. Exception Granted for Rel-7 until 03/07 / Text3: 23.837 / Text4: Donghee Shim (LG Electronics Inc.); Patrice HÉDÉ (LG Electronics Mobilecomm France)
- 82: WID at SA#55
- 84: Text3: TS25.305, TS25.453 / Text4: Robert Gross, TruePosition
- 85: Approved at RP#33 as RP-060459 / Text3: 25.305, 25.331, 25.410, 25.413, 25.453 / Text4: Ben Rodilitz
- 86: Approved at RP#33 as RP-060459 / Text3: 43.059, 44.031, 48.008, 49.031 / Text4: Kevin Judge, SiRF Technologies
- 87: Text3: 25.305, 25.331, 25.410, 25.413, 25.453 / Text4: Ben Rodilitz
- 88: Text3: 45.005, 51.010 / Text4: Richard Catmur, Spirent Communications
- 89: Text4: Michel MONNERAT
- 90: Text4: Richard Couty, ALCATEL SA
- 91: Started / Text4: Richard Couty, ALCATEL SA
- 92: Text3: TS 25.305,TS 25.331,TS 25.306,TS 25.413,TS 25.423,TS 25.433,TS 25.453,TS 25.171,TS 34.171 / Text4: Alain Abinakhoul, France Telecom
- 93: Text4: Robert Frank, TeliaSonera
- 94: Text3: 22.279
- 95: Text3: 23.279
- 96: Text3: New TS 24.279, 24.229, 24.008 / Text4: Peter Dawes (Vodafone)
- 97: Started / Text3: TS 26.141, 26.235, 26.236 / Text4: Per Fröjdh, Ericsson
- 101: Text3: new TR 24.819, 24.229, 29.229, 29.163, 29.209 / Text4: Peter Leis (Siemens)
- 102: end date updated by CT1-chairman after CT#33 / Text3: new TR 24.819, 24.229, 29.229, 29.163, 29.209 / Text4: Siemens
- 103: Text3: new TR, 29.229, 29.163 / Text4: Siemens
- 104: CT4#32: a set of CRs on FBI for cable labs / Text3: 29.209 / Text4: Siemens
- 105: Duplicated entry ("ACCSEC2", "Access Security Enhancements", SP-040865) deleted by A.Sultan / Text3: 33.102, 43.020 / Text4: Bengt Sahlin, Ericsson

| ID | WBS | Task | Type | Duration | Start | Finish | Complete | Remaining | Baseline start | Baseline finish | Baseline duration | Total slack | Constraint | Resources | Work | Actual work | Text1 | Text6 | Text3 | Text4 | Text5 | Text8 | Text7 | Text12 |
| --- | --- | --- | --- | --- | --- | --- | --- | --- | --- | --- | --- | --- | --- | --- | --- | --- | --- | --- | --- | --- | --- | --- | --- | --- |
| 106 | 18.2 | **PacketCable Related aspects** |  | 492d? | 2006-02-01 A | 2007-12-20 | 65% | 172.09d? | 2006-02-01 | 2007-03-15 | 291d? | 146d |  | S2 | 11032h | 4723.2h | FBI-PCBL | Rel-7 |  |  |  |  |  |  |
| 107 | 18.2.1 | Stage 2 of FBI for PacketCable |  | 228d? | 2006-02-01 A | 2006-12-15 A | 100% |  | 2006-02-01 | 2006-12-15 | 228d? |  | finish no earlier than 2006-12-15 | S2 | 1824h | 1824h | FBI-PCBL-s2 | Rel-7 |  |  |  |  |  |  |
| 108 | 18.2.2 | Protocol impact of FBI for PacketCable |  | 228d? | 2006-05-01 A | 2007-03-15 | 80% | 45.6d? | 2006-05-01 | 2007-03-15 | 228d? | 347d | finish no earlier than 2007-03-15 | C1 | 1824h | 1459.2h | FBI-PCBL-c1 | Rel-7 |  |  |  |  |  |  |
| 109 | 18.2.3 | SA5 Charging aspects of FBI for PacketCable |  | 180d? | 2006-03-31 A | 2006-12-07 A | 100% |  | 2006-03-31 | 2006-12-15 | 186d? |  | finish no earlier than 2006-12-07 | S5 | 1440h | 1440h | FBI-PCBL-CH | Rel-7 | 32.240, 32.260, 32.298, 32.299 | CableLabs | Bernie McKibben | Adrian |  |  |
| 110 | 18.2.4 | IMS Enhancements for Security Requirements in Support of Cable Deployments |  | 272d? | 2006-12-06 | 2007-12-20 |  |  | 2005-06-06 | 2006-12-15 | 400d? | 146d | finish no earlier than 2007-12-20 | S3 | 2176h |  | FBI-PCBL-Sec | Rel-8 | 33.203, 33.210, 33.220, 24.229 | Steve Dotson (Cablelabs) | s.dotson@cablelabs.com | Michael |  |  |
| 111 | 19 | Access Security Enhancements |  | 195d? | 2005-01-03 A | 2005-09-30 | 75% | 48.75d? | 2005-01-03 | 2005-09-30 | 195d? | 725d | finish no earlier than 2005-09-30 | S3 | 1560h | 1170h | ACCSEC2 | Rel-7 | 33.102, 43.020 | Bengt Sahlin, Ericsson | Bengt.Sahlin@ericsson.com | Michael | TSG |  |
| 112 | 20 | **Mp (MRFC - MRFP) interface** |  | 345d? | 2006-02-13 A | 2007-06-08 | 57% | 147.1d? | 2006-02-13 | 2007-03-23 | 290d? | 285d |  | C4 | 7128h | 4088.81h | Mp | Rel-7 |  | Emmanuel Gay (Orange) |  | Kimmo |  |  |
| 113 | 20.1 | CT1 aspects of Mp | milestone | 0d | 2006-02-13 | 2006-02-13 |  |  | 2006-02-13 | 2006-02-13 | 0d | 630d | finish no earlier than 2006-02-13 | C1 |  |  | Mp-c1 | Rel-7 | 24.229 | Orange |  |  |  |  |
| 114 | 20.2 | Deleted - CT3 aspects of Mp | milestone | 0d | 2006-09-22 | 2006-09-22 |  |  | 2006-02-13 | 2006-09-22 | 160d | 470d | start no earlier than 2006-09-22 | C3 |  |  |  | Rel-7 | 29.162 | Orange |  |  |  | CP-33 |
| 115 | 20.3 | Procedures description |  | 201d? | 2006-06-02 A | 2007-03-09 | 70% | 60.3d? | 2006-06-02 | 2006-12-15 | 141d? | 350d | finish no earlier than 2007-03-09 | C4 | 1608h | 1125.6h | Mp-PROCc4 | Rel-7 | 23.333 | Huang Hua, Huawei | h_hua@huawei.com | Kimmo |  |  |
| 116 | 20.4 | Stage 3 |  | 345d | 2006-02-13 A | 2007-06-08 | 50% | 172.5d | 2006-02-13 | 2007-03-23 | 290d | 285d | finish no earlier than 2007-06-08 | C4 | 2760h | 1380h | Mp-St3c4 | Rel-7 | 29.333 | Phil Hodges, Ericsson | philip.hodges@ericsson.com | Kimmo |  |  |
| 117 | 21 | IMS Stage 3 IETF Protocol alignment |  | 589d? | 2004-12-10 A | 2007-03-15 | 85% | 88.35d? | 2004-12-10 | 2007-03-15 | 589d? | 347d | finish no earlier than 2007-03-15 | C1 | 4712h | 4005.2h | IMSProtoc | Rel-7 | TR 24.930 |  |  |  |  |  |
| 118 | 22 | **Support of SMS over generic 3GPP IP access.** |  | 687d? | 2004-10-14 A | 2007-06-01 | 73% | 188.82d? | 2004-10-14 | 2007-03-15 | 630d? | 290d |  | S2 | 21520h | 12280.4h | SMSIP | Rel-7 | TR 23.abc, TS 23.abc | Wenlin Zhang (Huawei) | zhangwenlin@huawei.com | Maurice | TSG |  |
| 119 | 22.1 | FS on SMSIP |  | 173d? | 2004-10-14 A | 2005-06-13 A | 100% |  | 2004-10-14 | 2005-06-13 | 173d? |  | start no earlier than 2004-10-14 | S2 | 1384h | 1384h | SMSIP-FS | Rel-7 | 23.804 |  |  |  |  |  |
| 120 | 22.2 | Stage 2 for SMSIP |  | 333d? | 2005-06-08 A | 2006-09-15 | 85% | 49.95d? | 2005-06-08 | 2006-09-15 | 333d? | 475d | finish no earlier than 2006-09-15 | S2 | 2664h | 2264.4h | SMSIP-s2 | Rel-7 | 23.204 |  |  |  |  |  |
| 121 | 22.3 | **Stage 3 for SMSIP** |  | 518d? | 2005-06-08 A | 2007-06-01 | 63% | 189.52d? | 2005-06-08 | 2007-03-15 | 461d? | 290d |  | C4 | 11976h | 7455.58h | SMSIP-St3 | Rel-7 |  | Jari Jansson, Nokia | jari.jansson@nokia.com |  |  |  |
| 122 | 22.3.1 | CT1 aspects for SMSIP |  | 461d? | 2005-06-08 A | 2007-03-15 | 65% | 161.35d? | 2005-06-08 | 2007-03-15 | 461d? | 347d | finish no earlier than 2007-03-15 | C1 | 3688h | 2397.2h | SMSIP-St3-c1 | Rel-7 |  |  |  |  |  |  |
| 123 | 22.3.2 | CT4 aspects for SMSIP |  | 518d? | 2005-06-08 A | 2007-06-01 | 62% | 196.84d? | 2005-06-08 | 2007-03-09 | 458d? | 290d | finish no earlier than 2007-06-01 | C4 | 4144h | 2569.28h | SMSIP-St3-c4 | Rel-7 |  |  |  |  |  |  |
| 124 | 23 | **Evolution of Policy Control and Charging** |  | 631d? | 2004-10-14 A | 2007-03-15 | 65% | 222.47d? | 2004-10-14 | 2007-03-09 | 627d? | 346d |  | S2 | 23264h | 14421.5h | PCC | Rel-7 |  |  |  | Maurice | TSG |  |
| 125 | 23.1 | TR for PCC |  | 315d? | 2004-10-14 A | 2005-12-29 A | 100% |  | 2004-10-14 | 2005-12-29 | 315d? |  | finish no earlier than 2005-12-28 | S2 | 2520h | 2520h | PCC-FS | Rel-7 |  |  |  |  |  |  |
| 126 | 23.2 | Stage 2 for PCC |  | 315d? | 2005-07-04 A | 2006-09-15 A | 100% |  | 2005-07-04 | 2006-09-15 | 315d? |  | finish no earlier than 2006-09-15 | S2 | 2520h | 2520h | PCC-s2 | Rel-7 | 23.203 |  |  |  |  |  |
| 127 | 23.3 | Evolution of policy control and flow based bearer level charging |  | 109d? | 2006-08-01 | 2006-12-29 |  |  | 2006-08-01 | 2006-12-29 | 109d? | 400d | start no earlier than 2006-08-01 | S2 | 872h |  | PCC-BEARERs2 | Rel-7 | 23.207, 23.125, 23.002, 23.228 | Balazs Bertenyi (Nokia) | balazs.bertenyi@nokia.com |  |  |  |
| 128 | 23.4 | SA5 Charging aspects of PCC |  | 250d? | 2006-03-31 A | 2007-03-15 | 50% | 125d? | 2006-03-31 | 2006-12-15 | 186d? | 346d | finish no earlier than 2007-03-15 | S5 | 2000h | 1000h | PCC-CH | Rel-7 | 32.250, 32.251, 32.298, 32.299 | Orange | alain.bibas@orange-ft.com | Adrian |  |  |
| 129 | 23.5 | Gx reference point for Policy and Charging Control |  | 331d? | 2005-12-02 A | 2007-03-09 | 75% | 82.75d? | 2005-12-02 | 2007-03-09 | 331d? | 350d | finish no earlier than 2007-03-09 | C3 | 2648h | 1986h | PCC-Gx | Rel-7 | 29.210, 29.207, 29.208 | Thomas Belling (Siemens) | thomas.belling@siemens.com | Seung Don |  |  |

Notes:
- 109: 03/2006 SA#31 WID approved
- 111: WID approved SA#26. Record created after SA#27. It is about improved GERAN security
- 114: CT3 finally not involved in Mp interface definition (decided at CT#34)
- 116: indication in CT4#31 50%
- 117: TR 24.930: Signalling flows for the session setup in the IM CN subsystem based on Session Initiation Protocol (SIP)
- 118: Revised at SP#29
- 123: CT4#32: Stage 2 CR still outstanding....
- 127: Approved at SP#29. 23.125 will be discontinued from Release 7.
- 128: 03/2006 SA#31 WID approved
- 129: Approved at CP#30, Revised at CP#31, Revised at CP#33

| ID | WBS | Task | Type | Duration | Start | Finish | Complete | Remaining | Baseline start | Baseline finish | Baseline duration | Total slack | Constraint | Resources | Work | Actual work | Text1 | Text4 | Text5 | Text6 | Text8 | Text7 |
| --- | --- | --- | --- | --- | --- | --- | --- | --- | --- | --- | --- | --- | --- | --- | --- | --- | --- | --- | --- | --- | --- | --- |
| 130 | 23.6 | **Rx reference point for PCC CT3 aspects** |  | 335d? | 2005-12-02 A | 2007-03-15 | 41% | 198.16d? | 2005-12-02 | 2007-03-09 | 331d? | 346d |  | C3 | 7656h | 3127.27h | PCC-Rx | Javier Pastor (Ericsson) | j.javier.pastor@ericsson.com | Rel-7 | Seung Don |  |
| 131 | 23.6.1 | PCC-Rx CT3 aspects |  | 331d? | 2005-12-02 A | 2007-03-09 | 75% | 82.75d? | 2005-12-02 | 2007-03-09 | 331d? | 350d | finish no earlier than 2007-03-09 | C3 | 2648h | 1986h | PCC-Rx-c3 | Javier Pastor (Ericsson) | j.javier.pastor@ericsson.com | Rel-7 | Seung Don |  |
| 132 | 23.6.2 | PCC-Rx CT1 aspects |  | 291d? | 2005-12-02 A | 2007-03-15 | 2% | 285.18d? | 2005-12-02 | 2006-10-30 | 192d? | 346d | finish no earlier than 2007-03-15 | C1 | 2328h | 46.56h | PCC-Rx-c1 |  |  | Rel-7 |  |  |
| 133 | 24 | Video Codec Performance Requirements |  | 574d? | 2005-01-03 A | 2007-03-15 | 60% | 229.6d? | 2005-01-03 | 2006-12-07 | 504d? | 346d | finish no earlier than 2007-03-15 | S4 | 4592h | 2755.2h | VICPer | Juergen Pandel (Siemens AG) | juergen.pandel@siemens.com | Rel-7 | Paolo | TSG |
| 134 | 25 | DIAMETER on the GGSN Gi interface |  | 586d? | 2004-09-10 A | 2006-12-08 A | 100% |  | 2004-09-10 | 2006-12-08 | 586d? |  | finish no earlier than 2006-12-08 | C3 | 4688h | 4688h | DIAMGi | Nico Gabriele (Vodafone) | Nico.Gabriele@vodafone.com | Rel-7 | Seung Don | TSG |
| 135 | 26 | DIAMETER on the PDG Wi inteface |  | 586d? | 2004-09-10 A | 2006-12-08 A | 100% |  | 2004-09-10 | 2006-12-08 | 586d? |  | finish no earlier than 2006-12-08 | C3 | 4688h | 4688h | DIAMWi | Nico Gabriele (Vodafone) | Nico.Gabriele@vodafone.com | Rel-7 | Seung Don | TSG |
| 136 | 27 | **CAMEL Trunk Triggers** |  | 251d? | 2004-12-17 A | 2005-12-05 A | 100% |  | 2004-12-17 | 2005-12-05 | 251d? |  |  | S1 | 6024h | 6024h | TTCAMEL | Amar Deol, Nortel Networks | deola@nortelnetworks.com | Rel-7 | Michael | TSG |
| 137 | 27.1 | Stage 1 for CAMEL Trunk Triggers |  | 251d? | 2004-12-17 A | 2005-12-05 A | 100% |  | 2004-12-17 | 2005-12-05 | 251d? |  |  | S1 | 2008h | 2008h | TTCAMEL-s1 | Amar Deol, Nortel Networks | deola@nortelnetworks.com | Rel-7 | Michael | TSG |
| 138 | 27.2 | CAMEL Trunk Originated Trigger Detection Points |  | 251d? | 2004-12-17 A | 2005-12-05 A | 100% |  | 2004-12-17 | 2005-12-05 | 251d? |  | start no earlier than 2004-12-17 | C4 | 2008h | 2008h | CamelR7 | David Hutton, Nortel Networks | dhutton@nortel.com | Rel-7 | Kimmo | TSG |
| 139 | 28 | MS Antenna Performance Evaluation Method and Requirements |  | 536d? | 2005-01-28 A | 2007-02-16 | 75% | 134d? | 2005-01-28 | 2006-11-17 | 471d? | 365d | finish no earlier than 2007-02-16 | G1 | 4288h | 3216h | APEMR | Ulf.Tegth (TeliaSonera) | Ulf.Tegth@teliasonera.com | Rel-7 | Paolo | TSG |
| 140 | 29 | **Lower 700 MHz Inclusion in the GERAN Specifications** |  | 390d? | 2005-01-03 A | 2006-06-30 A | 100% |  | 2005-01-03 | 2006-06-30 | 390d? |  |  | GP | 7632h | 7632h | GSM710 | Dave Cotton (UTC) | dcotton@mtview.union-tel.com | Rel-7 | Paolo | TSG |
| 141 | 29.1 | Inclusion of the 698 – 746 MHz band into GERAN core specifications |  | 129d? | 2005-01-03 A | 2005-06-30 A | 100% |  | 2005-01-03 | 2005-06-30 | 129d? |  | finish no earlier than 2005-06-30 | G1 | 1032h | 1032h | GSM710-core |  |  | Rel-7 | Paolo |  |
| 142 | 29.2 | G1 aspects of GSM710 |  | 217.5d? | 2005-08-31 A | 2006-06-30 A | 100% |  | 2005-08-31 | 2006-06-30 | 217.5d? |  | finish no earlier than 2006-06-30 | G1 | 1740h | 1740h | GSM-710-test |  |  | Rel-7 | Paolo |  |
| 143 | 29.3 | G3 aspects of GSM710 |  | 217.5d? | 2005-08-31 A | 2006-06-30 A | 100% |  | 2005-08-31 | 2006-06-30 | 217.5d? |  | finish no earlier than 2006-06-30 | G3 | 1740h | 1740h | GSM-710-test |  |  | Rel-7 | Stoyan |  |
| 144 | 30 | **Enhancements of VGCS for public authority officials** |  | 646d? | 2004-08-27 A | 2007-02-16 | 94% | 39.54d? | 2004-08-27 | 2006-11-16 | 580d? | 365d |  | S1 | 22120h | 16176.8h | EVGCS | Siemens |  | Rel-7 | Andrijana | TSG |
| 145 | 30.1 | Stage 1 | milestone | 0d? | 2004-08-27 A | 2004-08-27 A | 100% |  | 2004-08-27 | 2004-08-27 | 0d? |  | finish no earlier than 2004-08-27 | S1 |  |  | EVGCS-s1 | Joerg Swetina (Siemens AG) | joerg.swetina@SIEMENS.COM | Rel-7 | Michael | TSG |
| 146 | 30.2 | **Architecture and protocol aspects** |  | 536d? | 2004-08-27 A | 2006-09-15 A | 100% |  | 2004-08-27 | 2006-09-15 | 536d? |  |  | C1 | 11784h | 11784h | EVGCS-St23 | Robert Zaus (Siemens) |  | Rel-7 |  |  |
| 147 | 30.2.1 | CT1 aspects of EVGCS |  | 536d? | 2004-08-27 A | 2006-09-15 A | 100% |  | 2004-08-27 | 2006-09-15 | 536d? |  | finish no earlier than 2006-09-15 | C1 | 4288h | 4288h | EVGCS-St23-c1 | Siemens |  | Rel-7 |  |  |
| 148 | 30.2.2 | CT4 aspects of EVGCS |  | 401d? | 2004-08-27 A | 2006-03-10 A | 100% |  | 2004-08-27 | 2006-03-10 | 401d? |  | finish no earlier than 2006-03-10 | C4 | 3208h | 3208h | EVGCS-St23-c4 | Siemens |  | Rel-7 |  |  |
| 149 | 30.3 | GERAN2 aspects |  | 646d? | 2004-08-27 A | 2007-02-16 | 85% | 96.9d? | 2004-08-27 | 2006-11-16 | 580d? | 365d | finish no earlier than 2007-02-16 | G2 | 5168h | 4392.8h | EVGCS-g2 | Ken Isaacs (Siemens) | kenneth.isaacs@roke.co.uk | Rel-7 | Gert | TSG |
| 150 | 31 | **Improvements of VGCS for parallel use of services** |  | 523d? | 2005-03-15 A | 2007-03-15 | 27% | 382.42d? | 2005-03-15 | 2007-03-15 | 523d? | 346d |  | S1 | 14886.2h | 2788.08h | IVGCS |  |  | Rel-7 |  |  |
| 151 | 31.1 | Service Requirements for VGCS improvements |  | 62d? | 2005-03-15 A | 2005-06-08 A | 100% |  | 2005-03-15 | 2005-06-08 | 62d? |  | finish no earlier than 2005-06-08 | S1 | 496h | 496h | IVGCS-s1 | Kurt Bischinger (T-Mobile) | kurt.bischinger@t-mobile.at | Rel-7 | Michael | TSG |
| 152 | 31.2 | Stage 2 modifications for VGCS improvements |  | 335d? | 2005-12-01 A | 2007-03-14 | 30% | 234.5d? | 2005-12-01 | 2006-09-15 | 207d? | 347d | start no earlier than 2005-12-01 | C1 | 2680h | 804h | IVGCS-s2 | Kurt Bischinger (T-Mobile) | kurt.bischinger@t-mobile.at | Rel-7 |  | TSG |
| 153 | 31.3 | **Protocol aspects** |  | 336d? | 2005-12-01 A | 2007-03-15 | 19% | 273.75d? | 2005-12-01 | 2007-03-15 | 336d? | 346d |  | C1 | 8032h | 1488.08h | IVGCS-St3 | Dieter Jacobsohn (T-Mobile) |  | Rel-7 |  |  |
| 154 | 31.3.1 | CT1 aspects of IVGCS |  | 336d? | 2005-12-01 A | 2007-03-15 | 23% | 258.72d? | 2005-12-01 | 2007-03-15 | 336d? | 346d | finish no earlier than 2007-03-15 | C1 | 2688h | 618.24h | IVGCS-St3-c1 | T-Mobile |  | Rel-7 |  |  |
| 155 | 31.3.2 | CT4 aspects of IVGCS |  | 332d? | 2005-12-01 A | 2007-03-09 | 14% | 285.52d? | 2005-12-01 | 2007-03-09 | 332d? | 350d | finish no earlier than 2007-03-09 | C4 | 2656h | 371.84h | IVGCS-St3-c4 | T-mobile |  | Rel-7 |  |  |

Notes:
- 130: Approved at CP#30, Revised at CP#31, Revised at CP#33 / Text3: 29.209, 29.211, 24.229
- 131: Approved at CP#30, Revised at CP#31 / Text3: 29.209, 29.211, 24.229
- 133: Text3: 26.234, 26.235, 26.346, 26.140
- 134: 13/12/2005 08:00, Revised at CP#33 / Text3: 29.061
- 135: 13/12/2005 08:00, Revised at CP#33 / Text3: 29.161
- 137: Text3: 22.078
- 138: Not started
- 139: Started / Text3: 25.9xx, 45.005
- 140: Text3: 24.008, 43.022, 44.018, 44.118, 45, 001, 45.005, 51.010, 51.021
- 141: Completed / Text3: 24.008, 43.022, 44.018, 44.118, 45, 001, 45.005,
- 142: Text3: 51.021
- 143: Text3: 51.010
- 144: Text3: 43.068, 44.068, 24.008, 29.002
- 145: Text3: 42.068, 43.068
- 146: Text3: 43.068, 44.068
- 147: Text3: 43.068, 44.068, 24.008
- 148: Text3: 29.002
- 151: "completeed" as from Chris S' e-mail / Text3: 42.068
- 152: Updated by CT1 chair / Text3: 43.068
- 153: Previous name (before CT32) was Architecture and protocol aspects / Text3: 44.068
- 154: end date updated by CT1-chairman after CT#33 / Text3: 43.068, 44.068, 24.008
- 155: CT4#33 stage 2 solution is still open. / Text3: 29.002

| ID | WBS | Task | Type | Duration | Start | Finish | Complete | Remaining | Baseline start | Baseline finish | Baseline duration | Total slack | Constraint | Resources | Work | Actual work | Text1 | Text4 | Text5 | Text6 | Text7 | Text8 | Text3 | Text10 |
| --- | --- | --- | --- | --- | --- | --- | --- | --- | --- | --- | --- | --- | --- | --- | --- | --- | --- | --- | --- | --- | --- | --- | --- | --- |
| 156 | 32 | **OSA Rel-7** |  | 519d? | 2005-03-15 A | 2007-03-09 | 79% | 109.67d? | 2005-03-15 | 2006-12-01 | 449d? | 350d |  | S1 | 16360h | 11574.6h | OSA7 | Eamonn Murray (AePONA) | eamonn.murray@aepona.com | Rel-7 | TSG | Michael |  |  |
| 157 | 32.1 | Service Requirements for OSA Service Broker |  | 62d? | 2005-03-15 A | 2005-06-08 A | 100% |  | 2005-03-15 | 2005-06-08 | 62d? |  | finish no earlier than 2005-06-08 | S1 | 496h | 496h | OSA7-SB | Eamonn Murray (AePONA) | eamonn.murray@aepona.com | Rel-7 | TSG | Michael | 22.127 |  |
| 158 | 32.2 | Stage 2 OSA API Service Brokering |  | 156d? | 2006-04-28 A | 2006-12-01 A | 100% |  | 2006-04-28 | 2006-12-01 | 156d? |  |  | C5 | 1248h | 1248h | OSA7-SB | AePONA | damian.oneill@aepona.com | Rel-7 | TSG | Adrian | 23.198 |  |
| 159 | 32.3 | Stage 3 OSA API Service Brokering |  | 156d? | 2006-04-28 A | 2006-12-01 A | 100% |  | 2006-04-28 | 2006-12-01 | 156d? |  | finish no earlier than 2006-12-01 | C5 | 1248h | 1248h | OSA7-SB | AePONA | damian.oneill@aepona.com | Rel-7 |  |  | 29.198-16 |  |
| 160 | 32.4 | **OSA Stage 2/3 enhancements** |  | 226d? | 2006-04-28 A | 2007-03-09 | 70% | 67.04d? | 2006-04-28 | 2006-12-01 | 156d? | 350d |  | C5 | 9216h | 5308h | OSA7 | AePONA | damian.oneill@aepona.com | Rel-7 |  | Adrian | 29.198/9, 23.198 |  |
| 161 | 32.4.1 | Parlay X Message Broadcast Web Service |  | 156d? | 2006-04-28 A | 2006-12-01 A | 100% |  | 2006-04-28 | 2006-12-01 | 156d? |  | finish no earlier than 2006-12-01 | C5 | 1248h | 1248h | OSA7-MesBcst | ETRI |  | Rel-7 |  |  | 29.199-15, 23.198 |  |
| 162 | 32.4.2 | Parlay X Geocoding Web Service |  | 156d? | 2006-04-28 A | 2006-12-01 A | 100% |  | 2006-04-28 | 2006-12-01 | 156d? |  | finish no earlier than 2006-12-01 | C5 | 1248h | 1248h | OSA7-Geoc | ETRI |  | Rel-7 |  |  | 29.199-16, 23.198 |  |
| 163 | 32.4.3 | Parlay X Application driven QoS Web Service |  | 226d? | 2006-04-28 A | 2007-03-09 | 60% | 90.4d? | 2006-04-28 | 2006-12-01 | 156d? | 350d | finish no earlier than 2007-03-09 | C5 | 1808h | 1084.8h | OSA7-ApliDriv | BT |  | Rel-7 |  |  | 29.199-17, 23.198 |  |
| 164 | 32.4.4 | Parlay-X Device Management Web Service |  | 97d? | 2006-10-26 A | 2007-03-09 | 30% | 67.9d? |  |  |  | 350d | start no earlier than 2006-10-26 | C5 | 776h | 232.8h | OSA7-DevMgt | Telenor |  | Rel-7 |  |  | 29.199-18, 23.198 |  |
| 165 | 32.4.5 | Parlay-X Multimedia Streaming Control Web Service |  | 97d? | 2006-10-26 A | 2007-03-09 | 60% | 38.8d? |  |  |  | 350d | start no earlier than 2006-10-26 | C5 | 776h | 465.6h | OSA7-MMStr | Telenor |  | Rel-7 |  |  | 29.199-19, 23.198 |  |
| 166 | 32.4.6 | Parlay-X Multimedia Multicast Control Web Service |  | 97d? | 2006-10-26 A | 2007-03-09 | 60% | 38.8d? |  |  |  | 350d | start no earlier than 2006-10-26 | C5 | 776h | 465.6h | OSA7-Mmmulti | Telenor |  | Rel-7 |  |  | 29.199-20, 23.198 |  |
| 167 | 32.4.7 | OSA API Conference Call Control SCF |  | 97d? | 2006-10-26 A | 2007-03-09 | 60% | 38.8d? |  |  |  | 350d | start no earlier than 2006-10-26 | C5 | 776h | 465.6h | OSA7-Conf | Ericsson |  | Rel-7 |  |  | 29.198-04-5, 23.198 |  |
| 168 | 33 | Dynamic and Interactive Multimedia Scenes |  | 523d? | 2005-03-15 A | 2007-03-15 | 60% | 209.2d? | 2005-03-15 | 2006-12-07 | 453d? | 346d | finish no earlier than 2007-03-15 | S4 | 4184h | 2510.4h | DIMS | Gaëlle MARTIN-COCHER (Streamezzo) | gaelle.martin-cocher@streamezzo.com | Rel-7 | TSG | Paolo | 26.140, 26.142, 26.234, 26.244, 23.346 |  |
| 169 | 34 | Liberty Alliance and 3GPP Security Interworking |  | 451d? | 2005-03-10 A | 2006-11-30 | 98% | 9.02d? | 2005-03-10 | 2006-11-30 | 451d? | 421d | finish no earlier than 2006-11-30 | S3 | 3608h | 3535.84h | LibSec | Silke Holtmanns, Nokia | Silke.Holtmanns@NOKIA.COM | Rel-7 | TSG | Maurice | 33.980 |  |
| 170 | 35 | **WLAN-UMTS Interworking Phase 2** |  | 371d? | 2004-01-05 A | 2005-06-07 | 99% | 0d? | 2004-01-05 | 2005-06-07 | 371d? | 809d |  | S1 | 3888h | 3888h | WLAN2 | Fredric Paint, Telenor | frederic.paint@telenor.com | Rel-7 | TSG | Michael |  |  |
| 171 | 35.1 | Stage 1 on Session Continuity |  | 115d? | 2004-01-05 A | 2004-06-11 A | 100% |  | 2004-01-05 | 2004-06-11 | 115d? |  | start no earlier than 2004-01-05 | S1 | 920h | 920h | WLAN-SC |  |  | Rel-7 |  |  |  | SP-24 |
| 172 | 35.2 | Stage 2 on Session Continuity: covered by SAE | milestone | 0d? | 2005-06-07 | 2005-06-07 |  |  | 2005-06-07 | 2005-06-07 | 0d? | 809d | finish no earlier than 2005-06-07 | S2 |  |  |  |  |  | Rel-7 |  |  |  |  |
| 173 | 36 | **WLAN Interworking – Private Network access from WLAN 3GPP IP Access** |  | 252d? | 2005-10-10 A | 2006-09-26 A | 100% |  | 2005-10-10 | 2006-09-26 | 252d? |  |  | S2 | 6920h | 6920h | WLANPNA |  |  | Rel-7 |  | Maurice |  |  |
| 174 | 36.1 | WLAN-PNA - Stage 2 |  | 185d? | 2005-10-10 A | 2006-06-23 A | 100% |  | 2005-10-10 | 2006-06-23 | 185d? |  | start no earlier than 2005-10-10 | S2 | 1480h | 1480h | WLANPNA-st2 | Toshiyuki Tamura (NEC) | tamurato@aj.jp.nec.com | Rel-7 |  | Maurice | 23.234, 33.234 |  |
| 175 | 36.2 | **WLAN-PNA - Stage 3** |  | 170d? | 2006-02-01 A | 2006-09-26 A | 100% |  | 2006-02-01 | 2006-09-26 | 170d? |  |  | C1 | 5440h | 5440h | WLANPNA-st3 | Pierre-Jean Muller (NEC) | pierre-jean.muller@nectech.fr | Rel-7 | TSG | Andrijana |  |  |
| 176 | 36.2.1 | CT1 aspets for WLAN-PNA |  | 170d? | 2006-02-01 A | 2006-09-26 A | 100% |  | 2006-02-01 | 2006-09-26 | 170d? |  | start no earlier than 2006-02-01 | C1 | 1360h | 1360h | WLANPNA-st3 | Pierre-Jean Muller (NEC) | pierre-jean.muller@nectech.fr | Rel-7 |  | Andrijana | 24.234 |  |
| 177 | 36.2.2 | CT3 aspets for WLAN-PNA |  | 170d? | 2006-02-01 A | 2006-09-26 A | 100% |  | 2006-02-01 | 2006-09-26 | 170d? |  | start no earlier than 2006-02-01 | C3 | 1360h | 1360h | WLANPNA-st3 | Pierre-Jean Muller (NEC) | pierre-jean.muller@nectech.fr | Rel-7 |  | Andrijana | 29.161 |  |
| 178 | 36.2.3 | CT4 aspets for WLAN-PNA |  | 170d? | 2006-02-01 A | 2006-09-26 A | 100% |  | 2006-02-01 | 2006-09-26 | 170d? |  | start no earlier than 2006-02-01 | C4 | 1360h | 1360h | WLANPNA-st3 | Pierre-Jean Muller (NEC) | pierre-jean.muller@nectech.fr | Rel-7 |  | Andrijana | 29.234 |  |
| 179 | 37 | **Enhancements to support QoS provisioning over 3GPP/WLAN Interworking** |  | 520d? | 2005-03-14 A | 2007-03-09 | 88% | 59.92d? | 2005-03-14 | 2007-03-09 | 520d? | 350d |  | S2 | 8360h | 7396.61h | WLANQOS | Osok Song, Samsung | osok.song@samsung.com | Rel-7 |  | Maurice | 23.836 |  |
| 180 | 37.1 | TR on support of QoS on WLAN |  | 232d? | 2005-03-14 A | 2006-01-31 A | 100% |  | 2005-03-14 | 2006-01-31 | 232d? |  | start no earlier than 2005-03-14 | S2 | 1856h | 1856h | WLANQoS-FS |  |  | Rel-7 |  |  |  |  |
| 181 | 37.2 | Stage 2 on support of QoS over 3GPP/WLAN interworking |  | 108d? | 2006-02-01 A | 2006-06-30 A | 100% |  | 2006-02-01 | 2006-06-30 | 108d? |  | start no earlier than 2006-02-01 | S2 | 864h | 864h | WLANQoS-s2 |  |  | Rel-7 |  |  |  |  |
| 182 | 37.3 | Stage 3 CT1 on support of QoS over 3GPP/WLAN Interworking |  | 64d? | 2006-09-04 A | 2006-11-30 A | 100% |  |  |  |  |  | finish no earlier than 2006-11-30 | C1 | 512h | 512h | WLANQoS-St3 |  |  | Rel-7 |  |  |  |  |
| 183 | 37.4 | Stage 3 CT4 on support of QoS over 3GPP/WLAN Interworking |  | 121d? | 2006-09-22 A | 2007-03-09 | 50% | 60.5d? | 2006-09-22 | 2007-03-09 | 121d? | 350d | finish no earlier than 2007-03-09 | C4 | 968h | 484h | WLAN-QOS | Peng Zhang, Huawei | zhang.peng@huawei.com | Rel-7 |  |  | 24.234, 29.234, 23.008 |  |

Notes:
- 157: az: WID URL corrected
- 160: CT#34: WID updated. Completion 12/06 =>03/07
- 169: WID approved SA#27.
- 170: Created at TSG#27 by A. Sultan because of WLAN items belonging to Rel-7
- 173: Placeholder created to Hold SA2 and CT1 BBs
- 174: Approved at SP#29
- 175: Approved at CP#29
- 176: Approved at CP#29
- 177: Approved at CP#29
- 178: CT4#31; no impacts identified, therefor completed
- 179: Moved from FS section Feb 06
- 182: Line added according to e-mail from Atle
- 183: WID was approved at CT#32...

| ID | WBS | Task | Duration | Start | Finish | Complete | Remaining | Baseline start | Baseline finish | Baseline duration | Total slack | Constraint | Resources | Work | Actual work | Text1 | Text4 | Text5 | Text6 | Text8 | Text7 |
| --- | --- | --- | --- | --- | --- | --- | --- | --- | --- | --- | --- | --- | --- | --- | --- | --- | --- | --- | --- | --- | --- |
| 184 | 38 | **Voice call continuity between CS and IMS (incl. I-WLAN)** | 640d? | 2004-12-31 A | 2007-06-14 | 57% | 272.98d? | 2004-12-31 | 2007-03-09 | 571d? | 281d |  | S2 | 20704h | 9299.51h | VCC | Andy Bennett, Lucent; Roger Bunting, Cingular | andybennett@lucent.com | Rel-7 | Maurice |  |
| 185 | 38.1 | TR for VCC | 245d? | 2004-12-31 A | 2005-12-08 A | 100% |  | 2004-12-31 | 2005-12-08 | 245d? |  | finish no earlier than 2005-12-08 | S2 | 1960h | 1960h | VCC-FS |  |  | Rel-7 |  |  |
| 186 | 38.2 | Stage 1 for VCC | 140d? | 2005-03-17 A | 2005-09-28 A | 100% |  | 2005-03-17 | 2005-09-28 | 140d? |  | finish no earlier than 2005-09-28 | S1 | 1120h | 1120h | VCC-s1 |  |  | Rel-7 | Mike |  |
| 187 | 38.3 | Stage 2 for VCC | 264d? | 2005-09-06 A | 2006-09-08 A | 100% |  | 2005-09-06 | 2006-09-08 | 264d? |  | finish no earlier than 2006-09-08 | S2 | 2112h | 2112h | VCC-s2 |  |  | Rel-7 |  |  |
| 188 | 38.4 | **Stage 3 for VCC** | 291d? | 2006-02-01 A | 2007-03-15 | 40% | 175.11d? | 2006-02-01 | 2007-03-09 | 288d? | 347d |  | C1 | 7792h | 3103.11h | VCC-St3 | Keith Drage (Lucent) | drage@lucent.com | Rel-7 |  |  |
| 189 | 38.4.1 | CT1 aspects of VCC | 291d? | 2006-02-01 A | 2007-03-15 | 80% | 58.2d? | 2006-02-01 | 2006-11-01 | 195d? | 347d | finish no earlier than 2007-03-15 | C1 | 2328h | 1862.4h | VCC-St3-c1 | Keith Drage (Lucent) | drage@lucent.com | Rel-7 | Andrijana |  |
| 190 | 38.4.2 | CT3 aspects of VCC | 196d? | 2006-02-01 | 2006-11-01 |  |  | 2006-02-01 | 2006-11-01 | 196d? | 442d | start no earlier than 2006-02-01 | C3 | 1568h |  | VCC-St3-c1 | Keith Drage (Lucent) | drage@lucent.com | Rel-7 |  |  |
| 191 | 38.4.3 | CT4 aspects of VCC | 196d? | 2006-06-09 A | 2007-03-09 | 20% | 156.8d? | 2006-06-09 | 2007-03-09 | 196d? | 350d | start no earlier than 2006-06-09 | C4 | 1568h | 313.6h | VCC-St3-c4 | Keith Drage (Lucent) | drage@lucent.com | Rel-7 |  |  |
| 192 | 38.5 | SA5 Charging aspects of VCC | 325d? | 2006-03-17 A | 2007-06-14 | 9% | 295.75d? | 2006-03-17 | 2006-12-15 | 196d? | 281d | finish no earlier than 2007-06-14 | S5 | 2600h | 234h | VCC-CH | Alain Bibas | alain.bibas@orange-ft.com | Rel-7 | Adrian |  |
| 193 | 39 | **OAM&P** | 939d? | 2004-02-16 A | 2007-09-20 | 70% | 284.22d? | 2004-02-16 | 2007-06-15 | 869d? | 211d |  | S5 | 107210h | 64524.1h | OAM7 | Toche | Christian.Toche@huawei.com | Rel-7 | Adrian | TSG |
| 194 | 39.1 | **Network Infrastructure Management** | 535d? | 2005-09-02 A | 2007-09-20 | 81% | 100.64d? | 2005-09-02 | 2006-12-15 | 336d? | 211d |  | S5 | 50968h | 37905.2h | OAM7-NIM |  |  | Rel-7 |  |  |
| 195 | 39.1.1 | Enhance NRM to accommodate NGN (IMS as basis of the Next Generation Network) | 400d? | 2005-09-02 A | 2007-03-15 | 50% | 200d? | 2005-09-02 | 2006-12-15 | 336d? | 346d | finish no earlier than 2007-03-15 | S5 | 3200h | 1600h |  | Ericsson |  | Rel-7 |  |  |
| 196 | 39.1.2 | Co-operative Element Management interface (CO-OP) (Study + Implementation) | 400d? | 2005-09-02 A | 2007-03-15 | 95% | 20d? | 2005-09-02 | 2006-12-15 | 336d? | 346d | finish no earlier than 2007-03-15 | S5 | 3200h | 3040h |  | Motorola |  | Rel-7 |  |  |
| 197 | 39.1.3 | Network Management (NM) Itf-N performance criteria | 400d? | 2005-09-02 A | 2007-03-15 | 90% | 40d? | 2005-09-02 | 2006-12-15 | 336d? | 346d | finish no earlier than 2007-03-15 | S5 | 3200h | 2880h |  | China Mobile |  | Rel-7 |  |  |
| 198 | 39.1.4 | Delta synchronization between IRP Manager and IRP Agent (Study + Implementation) | 400d? | 2005-09-02 A | 2007-03-15 | 80% | 80d? | 2005-09-02 | 2006-12-15 | 336d? | 346d | finish no earlier than 2007-03-15 | S5 | 3200h | 2560h |  | Siemens |  | Rel-7 |  |  |
| 199 | 39.1.5 | Subscription Management (SuM) IRP Solution Sets | 330d? | 2005-09-02 A | 2006-12-07 A | 100% |  | 2005-09-02 | 2006-12-15 | 336d? |  | finish no earlier than 2006-12-07 | S5 | 2640h | 2640h |  | Ericsson |  | Rel-7 |  |  |
| 200 | 39.1.6 | Integration Reference Point (IRP) Security Management | 400d? | 2005-09-02 A | 2007-03-15 | 95% | 20d? | 2005-09-02 | 2006-12-15 | 336d? | 346d | finish no earlier than 2007-03-15 | S5 | 3200h | 3040h |  | Huawei |  | Rel-7 |  |  |
| 201 | 39.1.7 | Integration Reference Point (IRP) Methodology | 400d? | 2005-09-02 A | 2007-03-15 | 75% | 100d? | 2005-09-02 | 2006-12-15 | 336d? | 346d | finish no earlier than 2007-03-15 | S5 | 3200h | 2400h |  | Ericsson |  | Rel-7 |  |  |
| 202 | 39.1.8 | Stopped - Partial suspension of Itf-N during maintenance/testing (Study + Implementation) | 465d? | 2005-09-02 A | 2007-06-14 A | 100% |  | 2005-09-02 | 2006-12-15 | 336d? |  | finish no earlier than 2007-06-14 | S5 | 3720h | 3720h |  | Siemens |  | Rel-7 |  |  |
| 203 | 39.1.9 | Stopped - Advanced Alarming on Itf-N (Study + Implementation) | 465d? | 2005-09-02 A | 2007-06-14 | 65% | 162.75d? | 2005-09-02 | 2006-12-15 | 336d? | 281d | finish no earlier than 2007-06-14 | S5 | 3720h | 2418h |  | Siemens |  | Rel-7 |  |  |
| 204 | 39.1.10 | Stopped - Management of Legacy Equipment | 336d? | 2005-09-02 A | 2006-12-15 A | 100% |  | 2005-09-02 | 2006-12-15 | 336d? |  | finish no earlier than 2006-12-15 | S5 | 2688h | 2688h |  | Siemens |  | Rel-7 |  |  |
| 205 | 39.1.11 | Rules for Vendor Specific Extensions | 400d? | 2005-09-02 A | 2007-03-15 | 80% | 80d? | 2005-09-02 | 2006-12-15 | 336d? | 346d | finish no earlier than 2007-03-15 | S5 | 3200h | 2560h |  | Siemens |  | Rel-7 |  |  |
| 206 | 39.1.12 | CN CS Bearer Transport Network (BTN) relative NRM | 400d? | 2005-09-02 A | 2007-03-15 | 75% | 100d? | 2005-09-02 | 2006-12-15 | 336d? | 346d | finish no earlier than 2007-03-15 | S5 | 3200h | 2400h |  | China Mobile |  | Rel-7 |  |  |
| 207 | 39.1.13 | Backward and Forward Compatibility of IRP systems | 336d? | 2005-09-02 A | 2006-12-15 A | 100% |  | 2005-09-02 | 2006-12-15 | 336d? |  | finish no earlier than 2006-12-15 | S5 | 2688h | 2688h |  | Ericsson |  | Rel-7 |  |  |
| 208 | 39.1.14 | Repeater Network Resource Model (NRM) definition | 214d? | 2006-02-13 A | 2006-12-07 A | 100% |  | 2006-02-13 | 2006-12-15 | 220d? |  | finish no earlier than 2006-12-07 | S5 | 1712h | 1712h |  | China Mobile |  | Rel-7 |  |  |
| 209 | 39.1.15 | UTRAN radio channel power monitoring | 284d? | 2006-02-13 A | 2007-03-15 | 65% | 99.4d? | 2006-02-13 | 2006-12-15 | 220d? | 346d | finish no earlier than 2007-03-15 | S5 | 2272h | 1476.8h |  | China Mobile |  | Rel-7 |  |  |
| 210 | 39.1.16 | NEW Notification XML Schema | 206d? | 2006-12-07 A | 2007-09-20 | 5% | 195.7d? |  |  |  | 211d | finish no earlier than 2007-09-20 | S5 | 1648h | 82.4h |  | Huawei |  | Rel-7 |  |  |

Notes:
- 184: WID approved SA#27. Revised at SA#28. WID update approved at SA#32 / Text3: 22.101, 23.228, 32.250, 32.260, 32.299, 32.298
- 185: Text3: 23.806
- 187: Text3: 23.206
- 188: Text3: new TS, 24.229, 23.008, 23.009, 23.078, 29.078, 29.163, 29.228, 29.229, 29.230, 29.278, 29.328, 29.329
- 189: Text3: new TS, 24.229
- 190: Text3: 29.163
- 191: No work done, because stage 2 is still open. / Text3: 23.008, 23.009, 23.078, 29.078, 29.228, 29.229, 29.230, 29.278, 29.328, 29.329
- 192: 03/2006 SA#31 WID approved / Text3: 32.250, 32.260, 32.298, 32.299
- 195: Text3: 32.731/2/3/5, 32.631/2/3/5
- 196: Text3: TR 32.806/814, 32.101
- 197: Text3: TR 32.811
- 198: Text3: new TR 32.8xy, new TSs 32.111-n,32.60n; For n = 1 to 5
- 199: Text3: 32.307/317/607/667/665, 32.101, 32.175
- 200: Text3: 32.372/3/5, 32.111,32.30x,32.32x,32.33x,32.34x,32.35x,32.36x,32.41x,32.60x,32.61x,32.66x
- 201: Text3: new TSs 32.15w,32.15x,32.15y,32.15z; 32.150,32.151,32.152
- 202: Text3: 32.381/2/3
- 203: Text3: TR 32.8xy
- 204: Text3: new TS 32.xxx
- 205: Text3: 32.62n; For n = 1 to 5
- 206: Text3: 32.74x
- 207: Text3: new TS 32.15X
- 208: Text3: 32.721/2/3/5
- 209: Text3: 32.405, 32.64n; For n = 1 to 5
- 210: 12/2006 SA#34 WID approved / Text3: New TS 32.325/345/365/415, CR to 32.335/615/665

| ID | WBS | Task | Type | Duration | Start | Finish | Complete | Remaining | Baseline start | Baseline finish | Baseline duration | Total slack | Constraint | Resources | Work | Actual work | Text1 | Text6 | Text4 | Text7 | Text12 | Text5 | Text8 |
| --- | --- | --- | --- | --- | --- | --- | --- | --- | --- | --- | --- | --- | --- | --- | --- | --- | --- | --- | --- | --- | --- | --- | --- |
| 211 | 39.2 | **Performance Management** |  | 400d? | 2005-09-02 A | 2007-03-15 | 75% | 101.79d? | 2005-09-02 | 2006-12-15 | 336d? | 346d |  | S5 | 24112h | 15590.4h | OAM7-PM | Rel-7 |  |  |  |  |  |
| 212 | 39.2.1 | Performance measurements definition for CN CS |  | 400d? | 2005-09-02 A | 2007-03-15 | 95% | 20d? | 2005-09-02 | 2006-12-15 | 336d? | 346d | finish no earlier than 2007-03-15 | S5 | 3200h | 3040h |  | Rel-7 | China Mobile |  |  |  |  |
| 213 | 39.2.2 | Enhancement UTRAN performance measurements definition |  | 400d? | 2005-09-02 A | 2007-03-15 | 85% | 60d? | 2005-09-02 | 2006-12-15 | 336d? | 346d | finish no earlier than 2007-03-15 | S5 | 3200h | 2720h |  | Rel-7 | China Mobile |  |  |  |  |
| 214 | 39.2.3 | Add TDD specific counters in Performance measurement |  | 330d? | 2005-09-02 A | 2006-12-07 A | 100% |  | 2005-09-02 | 2006-12-15 | 336d? |  | finish no earlier than 2006-12-15 | S5 | 2640h | 2640h |  | Rel-7 | CATT |  |  |  |  |
| 215 | 39.2.4 | ATM bearer network Performance measurements |  | 400d? | 2005-09-02 A | 2007-03-15 | 55% | 180d? | 2005-09-02 | 2006-12-15 | 336d? | 346d | finish no earlier than 2007-03-15 | S5 | 3200h | 1760h |  | Rel-7 | ZTE |  |  |  |  |
| 216 | 39.2.5 | IP bearer network Performance measurement definitions |  | 400d? | 2005-09-02 A | 2007-03-15 | 55% | 180d? | 2005-09-02 | 2006-12-15 | 336d? | 346d | finish no earlier than 2007-03-15 | S5 | 3200h | 1760h |  | Rel-7 | China Mobile |  |  |  |  |
| 217 | 39.2.6 | Performance measurements definition for IMS |  | 400d? | 2005-09-02 A | 2007-03-15 | 65% | 140d? | 2005-09-02 | 2006-12-15 | 336d? | 346d | finish no earlier than 2007-03-15 | S5 | 3200h | 2080h |  | Rel-7 | China Mobile |  |  |  |  |
| 218 | 39.2.7 | HSDPA performance measurements |  | 284d? | 2006-02-13 A | 2007-03-15 | 70% | 85.2d? | 2006-02-13 | 2006-12-15 | 220d? | 346d | finish no earlier than 2007-03-15 | S5 | 2272h | 1590.4h |  | Rel-7 | China Mobile |  |  |  |  |
| 219 | 44.5 | **Trace Management** |  | 869d? | 2004-02-16 A | 2007-06-15 | 37% | 551.58d? | 2004-02-16 | 2007-06-15 | 869d? | 281d |  | S5 | 24618.2h | 7236.53h | OAM7-Trace | Rel-7 | Vodafone | TSG |  |  |  |
| 220 | 39.3.1 | End-to-end Service Level tracing for IMS |  | 350d? | 2005-11-11 A | 2007-03-15 A | 100% |  | 2005-05-09 | 2006-12-15 | 420d? |  | finish no earlier than 2007-03-15 | S5 | 2800h | 2800h |  | Rel-7 | Vodafone | TSG | SP-31 |  |  |
| 221 | 39.3.2 | Trace record content for UTRAN TDD |  | 330d? | 2005-09-02 A | 2006-12-07 A | 100% |  | 2005-05-09 | 2006-12-15 | 420d? |  | finish no earlier than 2006-12-07 | S5 | 2640h | 2640h |  | Rel-7 | Nokia | TSG |  |  |  |
| 222 | 39.3.3 | IRP for Subscriber and Equipment Trace Management |  | 336d? | 2005-09-02 A | 2006-12-15 | 25% | 252d? | 2005-09-02 | 2006-12-15 | 336d? | 410d | finish no earlier than 2006-12-15 | S5 | 2688h | 672h |  | Rel-7 | Nokia | TSG |  |  |  |
| 223 | 39.3.4 | Service Level Tracing in IMS |  | 179.14d? | 2006-09-22 A | 2007-06-08 | 5% | 170.18d? | 2006-09-22 | 2007-06-08 | 179.14d? | 285d | finish no earlier than 2006-10-11 | C1 | 1433.12h | 71.65h | OAM7-Trace | Rel-7 | Jari Jansson, Nokia |  |  | jari.jansson@nokia.com | Andrijana |
| 224 | 39.3.5 | Deleted - SIP enhancements for trace |  | 862.14d? | 2004-02-16 A | 2007-06-15 | 2% | 844.9d? | 2004-02-16 | 2007-06-15 | 862.14d? | 281d | finish no earlier than 2007-06-15 | C1 | 6897.12h | 137.94h | OAM7-Trace | Rel-7 |  |  | CP-32 |  |  |
| 225 | 39.3.6 | Deleted - duplicated with UID 35063 - IRP for Subscriber and Equipment Trace Management |  | 336d? | 2005-09-02 A | 2006-12-15 | 25% | 252d? | 2005-09-02 | 2006-12-15 | 336d? | 410d | finish no earlier than 2006-12-15 | S5 | 2688h | 672h |  | Rel-7 | Nokia | TSG | SP-33 |  |  |
| 226 | 40 | Trust Requirements for Open Platforms in 3GPP |  | 499d? | 2005-01-03 A | 2006-11-30 | 70% | 149.7d? | 2005-01-03 | 2006-11-30 | 499d? | 421d | finish no earlier than 2006-11-30 | S3 | 3992h | 2794.4h | TrustOP | Rel-7 | Silke Holtmanns, Nokia | TSG |  | Silke.Holtmanns@NOKIA.COM | Michael |
| 227 | 41 | Development of UEA2 and UIA2 |  | 268d? | 2004-12-01 A | 2005-12-09 | 80% | 53.6d? | 2004-12-01 | 2005-12-09 | 268d? | 675d | finish no earlier than 2005-12-09 | S3 | 2144h | 1715.2h | AlgUEA2 | Rel-7 | Per Christoffersson, Teliasonera | TSG |  | per.christoffersson@teliasonera.com | Michael |
| 228 | 42 | Lawful Interception in the 3GPP Rel-7 architecture |  | 118d? | 2005-06-28 A | 2005-12-08 | 75% | 29.5d? | 2005-06-28 | 2005-12-08 | 118d? | 676d | start no earlier than 2005-06-28 | S3 | 944h | 708h | LI-7A | Rel-7 | Berthold Wilhelm, BMWI |  |  | berthold.wilhelm@regtp.de | Mike |
| 229 | 43 | **Support of Conversational Services in A/Gb mode via the PS domain** |  | 551d? | 2005-04-08 A | 2007-05-18 | 59% | 227.25d? | 2005-04-08 | 2007-11-16 | 681d? | 300d |  | GP | 13642.8h | 5758.45h | SCSAGB | Rel-7 | Gunnar Hedby, Ericsson |  |  | gunnar.hedby@ericsson.com | Paolo |
| 230 | 43.1 | Minimise the transfer delay between the SGSN and the MS |  | 529.95d? | 2005-04-08 A | 2007-05-18 | 60% | 211.98d? | 2005-04-08 | 2007-11-16 | 659.95d? | 300d | finish no earlier than 2007-05-18 | GP | 4239.6h | 2543.76h | SCSAGB-MTD | Rel-7 |  |  |  |  | Paolo |
| 231 | 43.2 | Definition of radio resource management functionality |  | 551d? | 2005-04-08 A | 2007-05-18 | 50% | 275.5d? | 2005-04-08 | 2007-11-16 | 681d? | 300d | finish no earlier than 2007-05-18 | G1 | 4408h | 2204h | SCSAGB-RRM | Rel-7 | Gunnar Hedby, Ericsson |  |  | gunnar.hedby@ericsson.com | Paolo |
| 232 | 43.3 | Support of Conversational Services in A/Gb mode via the PS domain – RLC Non-Persistent mode |  | 101d? | 2006-06-30 A | 2006-11-17 A | 100% |  | 2006-06-30 | 2007-11-16 | 361d? |  | finish no earlier than 2006-11-17 | G2 | 808h | 808h | SCSAGB-RLCNP | Rel-7 | Gunnar Hedby, Ericsson |  |  | gunnar.hedby@ericsson.com | Gert |
| 233 | 43.4 | Deleted- Radio Channel Support | milestone | 0d? | 2006-07-17 A | 2006-07-17 A | 100% |  | 2006-07-17 | 2006-07-17 | 0d? |  | start no earlier than 2006-07-17 | G2 |  |  | SCSAGB-RCHS | Rel-7 | Gunnar Hedby, Ericsson |  | SP-32 | gunnar.hedby@ericsson.com | Gert |
| 234 | 43.5 | Deleted- Modifications to FLO | milestone | 0d? | 2006-07-17 A | 2006-07-17 A | 100% |  | 2006-07-17 | 2006-07-17 | 0d? |  | start no earlier than 2006-07-17 | G2 |  |  | SCSAGB-FLO | Rel-7 | Gunnar Hedby, Ericsson |  | SP-32 | gunnar.hedby@ericsson.com | Gert |

Notes:
- 212: Text3: 32.407, 32.408
- 213: Text3: 32.405
- 214: Text3: 32.405
- 215: Text3: 32.404,32.405,32.406,32.407
- 216: Text3: 32.404,32.405,32.406,32.407
- 217: Text3: 32.404,32.409,32.437, 32.632/3/4/5
- 218: Text3: 32.405
- 220: 07/2005: OMA (Stage 1), Stage 2/3 SA5, CT1/3/4 / Text3: CR 32.101, 32.421/2/3.
- 221: Text3: CR 32.421/2/3.
- 222: Text3: 32.421,32.422,32.423. 3 new TS 32.4x1,2,3
- 223: Text3: 24.229, 24.167, 29.228,29.229,29.163,29.332
- 224: combined with UID 11067
- 225: Text3: 32.421,32.422,32.423. 3 new TS 32.4x1,2,3
- 226: WID approved SA#26. Record created after SA#27 / Text3: 33.905
- 227: WID approved SA#26, Dependant on Funding Availability. Record created after SA#27 / Text3: 35.919, 35.215, 35.216, 35.217, 35.218
- 228: Text3: 33.106, 33.107, 33.108
- 229: Originally started Nov. 2003 as GP-030443
- 232: Text3: 43.955, 43.064, 44.060, 45.001, 45.002, 45.003, 45.005, 45.010, 51.010, 51.021

| ID | WBS | Task | Type | Duration | Start | Finish | Complete | Remaining | Baseline start | Baseline finish | Baseline duration | Total slack | Constraint | Resources | Work | Actual work | Text1 | Text4 | Text5 | Text6 | Text8 | Text7 | Text12 |
| --- | --- | --- | --- | --- | --- | --- | --- | --- | --- | --- | --- | --- | --- | --- | --- | --- | --- | --- | --- | --- | --- | --- | --- |
| 235 | 44 | **Addition of new frequency band to GSM (T-GSM810)** |  | 486d? | 2005-04-08 A | 2007-02-16 | 97% | 15.79d? | 2005-04-08 | 2006-11-17 | 421d? | 365d |  | GP | 9872h | 5789.6h | TGSM810 | Chen De, Huawei | chende@huawei.com | Rel-7 | Paolo |  |  |
| 236 | 44.1 | Changes to core specification |  | 106d? | 2005-04-08 A | 2005-09-02 A | 100% |  | 2005-04-08 | 2005-09-02 | 106d? |  | finish no earlier than 2005-09-02 | GP | 848h | 848h | TGSM810-Core | Chen De, Huawei | chende@huawei.com | Rel-7 | Paolo |  |  |
| 237 | 44.2 | Changes to MS testing specification |  | 486d? | 2005-04-08 A | 2007-02-16 | 95% | 24.3d? | 2005-04-08 | 2006-11-17 | 421d? | 365d | finish no earlier than 2007-02-16 | G3 | 3888h | 3693.6h | TGSM810-MStest | Chen De, Huawei | chende@huawei.com | Rel-7 | Stoyan |  |  |
| 238 | 44.3 | Changes to BTS testing specification |  | 156d? | 2005-04-08 A | 2005-11-11 A | 100% |  | 2005-04-08 | 2005-11-11 | 156d? |  | finish no earlier than 2005-11-11 | G1 | 1248h | 1248h | TGSM810-BTStest | Chen De, Huawei | chende@huawei.com | Rel-7 | Paolo |  |  |
| 239 | 45 | **Handover of dedicated and shared resources while in dual transfer mode** |  | 421d? | 2005-04-08 A | 2006-11-17 A | 100% |  | 2005-04-08 | 2006-11-17 | 421d? |  |  | GP | 12672h | 12672h | HODSRDTM | Rami Vaittinen, Nokia | rami.vaittinen@nokia.com | Rel-7 | Paolo |  |  |
| 240 | 45.1 | Handover of dedicated and shared resources while in dual transfer mode |  | 321d? | 2005-04-08 A | 2006-06-30 A | 100% |  | 2005-04-08 | 2006-06-30 | 321d? |  | finish no earlier than 2006-06-30 | G2 | 2568h | 2568h | HODSRDTM-G2 | Rami Vaittinen, Nokia | rami.vaittinen@nokia.com | Rel-7 | Gert |  |  |
| 241 | 45.2 | MS Conformance Testing |  | 421d? | 2005-04-08 A | 2006-11-17 A | 100% |  | 2005-04-08 | 2006-11-17 | 421d? |  | finish no earlier than 2006-11-17 | G3 | 3368h | 3368h | HODSRDTM-Mstest | Rami Vaittinen, Nokia | rami.vaittinen@nokia.com | Rel-7 | Stoyan |  |  |
| 242 | 45.3 | BTS conformance testing |  | 421d? | 2005-04-08 A | 2006-11-17 A | 100% |  | 2005-04-08 | 2006-11-17 | 421d? |  | finish no earlier than 2006-11-17 | G1 | 3368h | 3368h | HODSRDTM-BTStest | Rami Vaittinen, Nokia | rami.vaittinen@nokia.com | Rel-7 | Paolo |  |  |
| 243 | 46 | Future GERAN Evolution |  | 486d? | 2005-04-08 A | 2007-02-16 | 90% | 48.6d? | 2005-04-08 | 2006-11-17 | 421d? | 365d | finish no earlier than 2007-02-16 | GP | 3888h | 3499.2h | FGE | Eddie Riddington, Nokia Corporation | eddie.riddington@nokia.com | Rel-7 | Paolo |  |  |
| 244 | 47 | 3G-324M Video Telephony Call Setup Times Improvements |  | 341d? | 2005-06-08 A | 2006-09-27 A | 100% |  | 2005-06-08 | 2006-09-27 | 341d? |  | finish no earlier than 2006-09-27 | S4 | 2728h | 2728h | VTCSTI | Edward Hall (Vodafone) | edward.hall@vodafone.co.uk | Rel-7 | Paolo |  |  |
| 245 | 48 | **Identification of Communication Services in IMS** |  | 554d? | 2005-05-02 A | 2007-06-14 | 54% | 255.22d? | 2005-05-02 | 2007-03-15 | 489d? | 281d |  | S2 | 11960h | 4188h | ServID | Stephen Terrill, Ericsson | stephen.terrill@ericsson.com | Rel-7 | Maurice |  |  |
| 246 | 48.1 | TR for ICS |  | 232d? | 2005-05-02 A | 2006-03-21 A | 100% |  | 2005-05-02 | 2006-03-21 | 232d? |  | finish no earlier than 2006-03-20 | S2 | 1856h | 1856h | ServID-FS |  |  | Rel-7 |  |  |  |
| 247 | 48.2 | Stage 2 of ICS |  | 144d? | 2005-11-11 A | 2006-05-31 A | 100% |  | 2005-11-11 | 2006-05-31 | 144d? |  | start no earlier than 2005-11-11 | S2 | 1152h | 1152h | ServID-s2 |  |  | Rel-7 |  |  |  |
| 248 | 48.3 | Stage 3 of ICS |  | 250d? | 2006-03-31 A | 2007-03-15 | 40% | 150d? | 2006-03-31 | 2007-03-15 | 250d? | 346d | finish no earlier than 2007-03-15 | C1 | 2000h | 800h | ServID-St3 | Christer Holmberg (Ericsson) | christer.holmberg@ericsson.com | Rel-7 | Andrijana |  |  |
| 249 | 48.4 | SA5 Charging aspects of ServID |  | 315d? | 2006-03-31 A | 2007-06-14 | 10% | 283.5d? | 2006-03-31 | 2006-12-15 | 186d? | 281d | finish no earlier than 2007-06-14 | S5 | 2520h | 252h | ServID-CH | Orange | alain.bibas@orange-ft.com | Rel-7 | Adrian |  |  |
| 250 | 49 | **VoIMS bearer related enhancements** |  | 354d? | 2005-03-15 A | 2006-07-21 | 99% | 0d? | 2005-03-15 | 2006-07-21 | 354d? | 0d |  | S2 | 4303.2h | 1576h | VoIMS |  |  | Rel-7 |  |  |  |
| 251 | 49.1 | Improved support of IMS Realtime Services using HSDPA/HSUPA |  | 197d? | 2005-03-15 A | 2005-12-14 A | 100% |  | 2005-03-15 | 2005-12-14 | 197d? |  | start no earlier than 2005-03-15 | R2 | 1576h | 1576h | RANimp-IMSRealTime | Don Zelmer | don.zelmer@CINGULAR.COM | Rel-7 | MCC_RAN | TSG |  |
| 252 | 49.2 | Deleted - FS on enhancement of radio performance for VoIMS | milestone | 0d? | 2006-07-21 A | 2006-07-21 A | 100% |  | 2006-07-21 | 2006-07-21 | 0d? |  | start no earlier than 2006-07-21 | S2 |  |  | VoIMS | Laurence Lautier, Nortel Networks | lautierl@nortel.com | Rel-7 | Maurice |  | SP-32 |
| 253 | 50 | Performance Characterization of VoIMS over HSDPA\EUL channels |  | 523d? | 2005-03-15 A | 2007-03-15 | 50% | 261.5d? | 2005-03-15 | 2007-03-15 | 523d? | 346d | finish no earlier than 2007-03-15 | S4 | 4184h | 2092h | VoIMS-PCVoIMS | Dimitris Vasilaras (Lucent Technologies) | dvasilaras@lucent.com | Rel-7 | Paolo | TSG |  |
| 254 | 51 | **Optimizations for Multimedia Telephony over IMS** |  | 382d? | 2005-09-28 A | 2007-03-15 | 55% | 171.9d? | 2005-09-28 | 2006-12-07 | 312d? | 346d |  | S4 | 6112h | 2411.6h | OMTIMS | Olle Franceschi (Ericsson) | olle.franceschi@ericsson.com | Rel-7 | Paolo |  |  |
| 255 | 51.1 | Characterisation of Adaptive Jitter Management Performance for VoIP Services |  | 382d? | 2005-09-28 A | 2007-03-15 | 55% | 171.9d? | 2005-09-28 | 2006-12-07 | 312d? | 346d | finish no earlier than 2007-03-15 | S4 | 3056h | 1680.8h | OMTIMS-CAJMP | David Huo (Lucent Technologies) | dhuo@lucent.com | Rel-7 | Paolo |  |  |
| 256 | 52 | End-to-End Multimedia Services Performance Metrics |  | 382d? | 2005-09-28 A | 2007-03-15 | 60% | 152.8d? | 2005-09-28 | 2006-12-07 | 312d? | 346d | finish no earlier than 2007-03-15 | S4 | 3056h | 1833.6h | E2EMSPM | Zhang Yan (China Mobile) | zhangyanyf@chinamobile.com | Rel-7 | Paolo |  |  |
| 257 | 53 | **Supporting Globally Routable User Agent URIs in IMS** |  | 349d? | 2005-11-14 A | 2007-03-15 | 96% | 14.63d? | 2005-11-14 | 2006-12-08 | 280d? | 346d |  | S2 | 4544h | 3748h | GRUU | Adrian Buckley (Research In Motion) | abuckley@rim.com | Rel-7 | Maurice |  |  |
| 258 | 53.1 | TR on GRUU |  | 219d? | 2005-11-14 A | 2006-09-14 A | 100% |  | 2005-11-14 | 2006-09-14 | 219d? |  | finish no earlier than 2006-09-14 | S2 | 1752h | 1752h | GRUU-FS |  |  | Rel-7 | Maurice |  |  |
| 259 | 53.2 | Stage 2 of GRUU |  | 65d? | 2006-07-03 A | 2006-09-29 A | 100% |  | 2006-07-03 | 2006-09-29 | 65d? |  | start no earlier than 2006-07-03 | S2 | 520h | 520h | GRUU-s2 |  |  | Rel-7 | Maurice |  |  |
| 260 | 53.3 | Stage 3 of GRUU |  | 205d? | 2006-06-02 A | 2007-03-15 | 90% | 20.5d? | 2006-06-02 | 2006-12-08 | 136d? | 346d | finish no earlier than 2007-03-15 | C1 | 1640h | 1476h | GRUU-St3 | Bernie McKibben, CableLabs |  | Rel-7 | Andrijana |  |  |
| 261 | 54 | ISIM API for Java Card |  | 200d? | 2005-03-14 A | 2005-12-16 | 90% | 20d? | 2005-03-14 | 2005-12-16 | 200d? | 670d | finish no earlier than 2005-12-16 | C6 | 1600h | 1440h | APIJAVA | Sebastian Hans, Sun Microsystems Ltd. |  | Rel-7 | Gaby |  |  |

Notes:
- 235: Text3: 45.005, 45.050, 24.008, 45.008, 45.001, 43.022, 43.030, 44.018, 44.060, 51.010-1, 51.021
- 236: Text3: 45.005, 45.050, 24.008, 45.008, 45.001, 43.022, 43.030, 44.018, 44.060
- 237: Started / Text3: 51010-1
- 238: Text3: 51021
- 239: Started at GERAN#24
- 240: Started at GERAN#24 / Text3: 43.055, 44.018, 44.060
- 241: Stopped, no work done / Text3: 51-010
- 242: Stopped, no work done / Text3: 51.026
- 243: Text3: 45.912
- 244: Text3: 26.911
- 245: WID approved SA#28. Updated WID approved SA#32 / Text3: 22.228, 23.228, 23.203, 32.260, 32.298, 32.299
- 246: Text3: 23.816
- 248: end date updated by CT1-chairman after CT#33
- 249: 03/2006 SA#31 WID approved / Text3: 32.260, 32.298, 32.299
- 250: Created by MCC to group all VoIMS related items, after consultation of chairs
- 252: WID approved SA#28: SA2#52: CLOSED - To be removed from the work plan / Text3: 23.807
- 253: Text3: 26.935
- 254: Text3: 26.235, 26.236
- 256: Text3: 26.944
- 257: Approved at SP#29 / Text3: 23.8XX, 22.228, 23.228, 23.218, 24.229
- 258: Abandomned
- 259: S2#52: "GURU" corrected to "GRUU"
- 260: S2#52: "GURU" corrected to "GRUU"
- 261: Text3: 31.103, TS 102 241

| ID | WBS | Task | Duration | Start | Finish | Complete | Remaining | Baseline start | Baseline finish | Baseline duration | Total slack | Constraint | Resources | Work | Actual work | Text1 | Text6 | Text4 | Text5 | Text8 | Text7 |
| --- | --- | --- | --- | --- | --- | --- | --- | --- | --- | --- | --- | --- | --- | --- | --- | --- | --- | --- | --- | --- | --- |
| 262 | 55 | **Rel7 Security enhancements** | 319d? | 2005-09-12 A | 2006-11-30 | 89% | 33.53d? | 2005-09-12 | 2006-11-30 | 319d? | 421d |  | S3 | 9336h | 7409.37h | SEC7 | Rel-7 |  |  |  |  |
| 263 | 55.1 | HTTPS connection between a UICC and a NAF | 1d? | 2005-09-12 A | 2005-09-12 A | 100% |  | 2005-09-12 | 2005-09-12 | 1d? |  | start no earlier than 2005-09-12 | S3 | 8h | 8h | SEC7-HSUN | Rel-7 | Jacques Seif (Axlato) | JSeif@axalto.com |  |  |
| 264 | 55.2 | 2G GBA: 2G SIM usage in 3GPP GAA framework | 61d? | 2005-09-12 A | 2005-12-05 A | 100% |  | 2005-09-12 | 2005-12-05 | 61d? |  | finish no earlier than 2005-12-05 | S3 | 488h | 488h | SEC7-2GGBA | Rel-7 | Silke Holtmanns (Nokia) | Silke.Holtmanns@nokia.com |  |  |
| 265 | 55.3 | Generic Authentication Architecture usage extensions and optimisations | 319d? | 2005-09-12 A | 2006-11-30 | 80% | 63.8d? | 2005-09-12 | 2006-11-30 | 319d? | 421d | finish no earlier than 2006-11-30 | S3 | 2552h | 2041.6h | GAA2 | Rel-7 | Silke Holtmanns (Nokia) | Silke.Holtmanns@nokia.com |  |  |
| 266 | 55.4 | **SS7 TCAP security Gateway** | 241d? | 2005-09-12 A | 2006-08-14 | 99% | 0d? | 2005-09-12 | 2006-08-14 | 241d? | 0d |  | S3 | 3736h | 2588h | SEC7-NDS-TCAPsec | Rel-7 | Marc Blommaert (Siemens) | marc.blommaert@siemens.com |  |  |
| 267 | 55.4.1 | SA3 aspects of SEC7-NDS-TCAPsec | 130d? | 2005-09-12 A | 2006-03-10 A | 100% |  | 2005-09-12 | 2006-03-10 | 130d? |  | finish no earlier than 2006-03-10 | S3 | 1040h | 1040h | SEC7-NDS-TCAPsec-SA3 | Rel-7 | Marc Blommaert (Siemens) | marc.blommaert@siemens.com |  |  |
| 268 | 55.4.2 | TCAPsec Gateway | 96d? | 2006-04-03 A | 2006-08-14 A | 100% |  | 2006-04-03 | 2006-08-14 | 96d? |  | start no earlier than 2006-04-01 | C4 | 768h | 768h | SEC7-NDS-TCAPsec-CT4 | Rel-7 | Ulrich Wiehe, Siemens | Ulrich.wiehe@gksag.de | Kimmo |  |
| 269 | 56 | Network Composition | 211d? | 2005-12-07 A | 2006-09-27 | 65% | 73.85d? | 2005-12-07 | 2006-09-27 | 211d? | 467d | finish no earlier than 2006-09-27 | S1 | 1688h | 1097.2h | NetComp | Rel-7 | Joerg Swetina (Siemens) | joerg.swetina@siemens.com |  |  |
| 270 | 57 | Key establishment between a UICC and a terminal | 201.45d? | 2005-12-07 A | 2006-09-28 | 70% | 60.44d? | 2005-12-07 | 2006-09-28 | 201.45d? | 466d | finish no earlier than 2006-09-28 | S3 | 1611.6h | 1128.12h | KeyEstUTerm | Rel-7 | Mireille Pauliac (Gemplus) | mireille.pauliac@gemplus.com |  |  |
| 271 | 58 | **Mobile Station Receive Diversity (DARP Phase II)** | 471d? | 2005-11-11 A | 2007-08-31 | 42% | 272.48d? | 2005-11-11 | 2007-02-16 | 331d? | 225d |  | GP | 15480h | 5159.78h | MSRD2 | Rel-7 | Kent Pedersen, Nokia Corporation (ETSI) | kent.pedersen@nokia.com | Paolo |  |
| 272 | 58.1 | Performance Requirements for Mobile Station Receive Diversity, DARP Phase II | 331d? | 2005-11-11 A | 2007-02-16 | 70% | 99.3d? | 2005-11-11 | 2007-02-16 | 331d? | 365d | finish no earlier than 2007-02-16 | GP | 2648h | 1853.6h | MSRD2-PerfReq | Rel-7 | Kent Pedersen, Nokia Corporation (ETSI) | kent.pedersen@nokia.com | Paolo |  |
| 273 | 58.2 | Capability signalling of Mobile Station Receive Diversity, DARP Phase II | 331d? | 2005-11-11 A | 2007-02-16 | 25% | 248.25d? | 2005-11-11 | 2007-02-16 | 331d? | 365d | finish no earlier than 2007-02-16 | GP | 2648h | 662h | MSRD2-CapSig | Rel-7 | Kent Pedersen, Nokia Corporation (ETSI) | kent.pedersen@nokia.com | Paolo, Gert |  |
| 274 | 58.3 | Test Scenarios for Mobile Station Receive Diversity, DARP Phase II | 331d? | 2005-11-11 A | 2007-02-16 | 90% | 33.1d? | 2005-11-11 | 2007-02-16 | 331d? | 365d | finish no earlier than 2007-02-16 | GP | 2648h | 2383.2h | MSRD2-TestSc | Rel-7 | Kent Pedersen, Nokia Corporation (ETSI) | kent.pedersen@nokia.com | Paolo |  |
| 275 | 58.4 | MS conformance test of DARP Phase II (MSRD) | 471d? | 2005-11-11 A | 2007-08-31 | 1% | 466.29d? | 2005-11-11 | 2007-01-19 | 311d? | 225d | finish no earlier than 2007-08-31 | GP | 3768h | 37.68h | MSRD2-Msconf | Rel-7 | Kent Pedersen, Nokia Corporation (ETSI) | kent.pedersen@nokia.com | Paolo, Stoyan |  |
| 276 | 59 | **MBMS Enhancements** | 439d? | 2005-07-11 A | 2007-03-15 | 11% | 391.25d? | 2005-07-11 | 2005-12-08 | 109d? | 346d |  | S1 | 9524.63h | 1308h | MBMSE | Rel-7 | Liu Hong, China Mobile | liuhongyfw@chinamobile.com | Mike |  |
| 277 | 59.1 | Stage 1 of MBMSE | 109d? | 2005-07-11 A | 2005-12-08 | 75% | 27.25d? | 2005-07-11 | 2005-12-08 | 109d? | 676d | finish no earlier than 2005-12-08 | S1 | 872h | 654h | MBMSE | Rel-7 | Liu Hong, China Mobile | liuhongyfw@chinamobile.com | Mike |  |
| 278 | 59.2 | MBMS FDD Physical layer Enhancements | 321.29d? | 2005-12-15 | 2007-03-15 |  |  | 2005-11-11 | 2007-01-19 | 311d? | 346d | finish no earlier than 2007-03-15 | R1 | 2570.32h |  | MBMSE-RANPhysFDD | Rel-7 | Lars Lindbom | Lars.Lindbom@ericsson.com |  |  |
| 279 | 59.3 | MBMS TDD Physical layer Enhancements | 321.29d? | 2005-12-15 | 2007-03-15 |  |  | 2005-11-11 | 2007-01-19 | 311d? | 346d | finish no earlier than 2007-03-15 | R1 | 2570.32h |  | MBMSE-RANPhysTDD | Rel-7 | Nicholas Anderson |  |  |  |
| 280 | 60 | MBMS User Service Extensions | 392d? | 2005-12-07 A | 2007-06-07 | 30% | 274.4d? | 2005-12-07 | 2007-06-07 | 392d? | 286d | finish no earlier than 2007-06-07 | S4 | 3136h | 940.8h | MBMSUSE | Rel-7 | Thorsten Lohmar (Ericsson) | Thorsten.Lohmar@ericsson.com | Paolo |  |
| 281 | 61 | IMS Support of Conferencing and Messaging Group Management | 354d? | 2005-11-04 A | 2007-03-15 | 25% | 265.5d? | 2005-11-04 | 2007-03-15 | 354d? | 347d | finish no earlier than 2007-03-15 | C1 | 2832h | 708h | IMSconf | Rel-7 | Keith Drage (Lucent) | drage@lucent.com | Andrijana |  |
| 282 | 62 | **Selective Disabling of UE Capabilities** | 558.36d? | 2005-01-24 A | 2007-03-15 | 95% | 29.47d? | 2005-01-24 | 2006-12-08 | 489.36d? | 346d |  | S1 | 10980.8h | 10401.3h | SDoUE | Rel-7 | Nigel Barnes (Motorola Ltd) | Nigel.Barnes@motorola.com | Michael | TSG |
| 283 | 62.1 | Stage 1 of SDoUE | 393.6d? | 2005-01-24 A | 2006-12-08 A | 100% |  | 2005-01-24 | 2006-12-08 | 393.6d? |  | finish no earlier than 2006-12-08 | S1 | 3148.8h | 3148.8h | SDoUE-CRs | Rel-7 | Nigel Barnes (Motorola Ltd) | Nigel.Barnes@motorola.com | Michael | TSG |
| 284 | 62.2 | TR on different possible architectures | 195d? | 2005-03-21 A | 2005-12-16 A | 100% |  | 2005-03-21 | 2005-12-16 | 195d? |  | finish no earlier than 2005-12-16 | S2 | 1560h | 1560h | SDoUE-FS | Rel-7 |  |  | Maurice |  |
| 285 | 62.3 | Stage 3 of SDoUE | 265d? | 2006-03-10 A | 2007-03-15 | 83% | 45.05d? | 2006-03-10 | 2006-10-30 | 166d? | 346d | finish no earlier than 2007-03-15 | C1 | 2120h | 1759.6h | SDOuE-St3 | Rel-7 | Christian Herrero (Ericsson) | christian.herrero@ericsson.com | Andrijana |  |

Notes:
- 263: Text3: 33.222, 24.109, 33.918
- 264: Text3: 33.220, 33.920
- 265: Text3: 33.220, 29.109, 33.223
- 266: Text3: 33.200, 33.204
- 267: Text3: 33.200, 33.204
- 268: Study WI... / Text3: new TS 29.204
- 269: Text3: 22.980
- 270: Text3: 33.110
- 271: Started / Text3: 24.008, 45.005, 51.010
- 272: Text3: 45.005
- 273: Text3: 24.008
- 274: Text3: 45.005
- 275: Text3: 51.010
- 277: Strucutre created by MCC to include RAN aspects under SA1 Feature
- 278: Text3: 25.211, 25.212, 25.213, 25.101, 25.104, 25.331, 25.433, 25.346, 25.306
- 279: Text3: 25.346, 25.221, 25.222, 25.223, 25.224, 25.306, 25.331, 25.402, 25.433, 25.102, 25.105, 25.123
- 280: Text3: 26.346, 26.946
- 282: Moved from FS section Feb 06 / Text3: 22.xxx
- 283: Moved from FS section Feb 06 / Text3: 22.011, 22.060, 23.060, 24.008, 23.805, 24.305
- 284: Moved from FS section Feb 06 / Text3: 23.805
- 285: Text3: New TS 24.305

| ID | WBS | Task | Duration | Start | Finish | Complete | Remaining | Baseline start | Baseline finish | Baseline duration | Total slack | Constraint | Resources | Work | Actual work | Text1 | Text4 | Text5 | Text6 | Text8 | Text7 |
| --- | --- | --- | --- | --- | --- | --- | --- | --- | --- | --- | --- | --- | --- | --- | --- | --- | --- | --- | --- | --- | --- |
| 286 | 63 | **Personal Network Management (PNM)** | 601.6d? | 2005-07-11 A | 2007-10-30 | 59% | 245.04d? | 2005-07-11 | 2006-07-31 | 276d? | 183.4d |  | S1 | 10171.2h | 6028.27h | PNPAN | Armin Toepfer, Vodafone | armin.toepfer@vodafone.com | Rel-7 | Mike |  |
| 287 | 63.1 | Study of PNPAM | 167d? | 2005-07-11 A | 2006-02-28 A | 100% |  | 2005-07-11 | 2006-02-28 | 167d? |  | start no earlier than 2005-07-11 | S1 | 1336h | 1336h | PNPAN-FS |  |  | Rel-7 |  |  |
| 288 | 63.2 | Stage 1 of PNPAM | 276d? | 2005-07-11 A | 2006-07-31 | 85% | 41.4d? | 2005-07-11 | 2006-07-31 | 276d? | 509d | start no earlier than 2005-07-11 | S1 | 2208h | 1876.8h | PNPAN-s1 |  |  | Rel-7 |  |  |
| 289 | 63.3 | Key establishment between a UICC hosting device and a remote device | 234.6d? | 2006-12-06 | 2007-10-30 |  |  | 2005-07-11 | 2006-07-31 | 276d? | 183.4d | start no earlier than 2006-12-06 | S3 | 1876.8h |  | PNPAN-Key | Vesa Lehtovirta (Ericsson) | Vesa.Lehtovirta@ericsson.com | Rel-7 | Michael |  |
| 290 | 64 | **Multimedia Telephony Service for IMS** | 265d? | 2006-03-10 A | 2007-03-15 | 74% | 68.01d? | 2006-03-10 | 2007-03-15 | 265d? | 346d |  | S1 | 7832h | 4272h | MTSI | Peter Bleckert, Ericsson | peter.bleckert @ericsson.com | Rel-7 | Mike |  |
| 291 | 64.1 | Stage 1 of MTSI | 191d? | 2006-03-15 A | 2006-12-06 A | 100% |  | 2006-03-15 | 2006-12-06 | 191d? |  | start no earlier than 2006-03-15 | S1 | 1528h | 1528h | MTSI-REQ | Peter Bleckert, Ericsson | peter.bleckert @ericsson.com | Rel-7 | Mike |  |
| 292 | 64.2 | Stage 3 of MTSI | 264d? | 2006-03-10 A | 2007-03-15 | 70% | 79.2d? | 2006-03-10 | 2007-03-15 | 264d? | 347d | finish no earlier than 2007-03-15 | C1 | 2112h | 1478.4h | MTSI-St3 | Christer Holmberg (Ericsson) | christer.holmberg@ericsson.com | Rel-7 | Andrijana |  |
| 293 | 64.3 | Media handling and interaction in MTSI | 262d? | 2006-03-15 A | 2007-03-15 | 60% | 104.8d? | 2006-03-15 | 2007-03-15 | 262d? | 346d | finish no earlier than 2007-03-15 | S4 | 2096h | 1257.6h | MTSI-MHI | Olle Franceschi, Ericsson | olle.franceschi@ericsson.com | Rel-7 | Paolo |  |
| 294 | 65 | **Multimedia interworking between IMS and CS networks** | 381d? | 2005-09-23 A | 2007-03-09 | 87% | 50.64d? | 2005-09-23 | 2007-03-09 | 381d? | 350d |  | C3 | 6487.99h | 3026.23h | MIWIMS | Nico Gabriele, Vodafone UK | nico.gabriele@vodafone.com | Rel-7 | Seung Don |  |
| 295 | 65.1 | Note: Stages 1 and 2 defined in earlier Release | 49d? | 2005-09-23 A | 2005-11-30 A | 100% |  | 2005-09-23 | 2005-11-30 | 49d? |  | start no earlier than 2005-09-23 | S2 | 392h | 392h |  |  |  | Rel-7 |  |  |
| 296 | 65.2 | Stage 3 of MW-IMS | 381d? | 2005-09-23 A | 2007-03-09 | 85% | 57.15d? | 2005-09-23 | 2007-03-09 | 381d? | 350d | finish no earlier than 2007-03-09 | C3 | 3048h | 2590.8h | MWIMS-St3 |  |  | Rel-7 |  |  |
| 297 | 66 | **Network selection enhancements** | 260d? | 2006-03-15 A | 2007-03-13 | 80% | 52.79d? | 2006-03-15 | 2006-12-07 | 192d? | 348d |  | S1 | 5232h | 3156h | NSP-CR | Chris Friel, O2 | chris.friel@o2.com | Rel-7 | Michael |  |
| 298 | 66.1 | Stage 1 of NSP | 191d? | 2006-03-15 A | 2006-12-06 | 90% | 19.1d? | 2006-03-15 | 2006-12-06 | 191d? | 417d | start no earlier than 2006-03-15 | S1 | 1528h | 1375.2h | NSP-TS | Chris Friel, O2 | chris.friel@o2.com | Rel-7 | Michael |  |
| 299 | 66.2 | Procedural aspects of NSP | 203d? | 2006-06-02 A | 2007-03-13 | 70% | 60.9d? | 2006-06-02 | 2006-12-07 | 135d? | 348d | finish no earlier than 2007-03-13 | C1 | 1624h | 1136.8h | NSPCR-c1 | Andrew Howell (Motorola) | andrew.howell@motorola.com | Rel-7 | Andrijana |  |
| 300 | 67 | **Interoperability between VGCS/VBS and A/Gb flexibility** | 253d? | 2006-03-22 A | 2007-03-09 | 97% | 7.77d? | 2006-03-22 | 2006-12-01 | 183d? | 350d |  | C1 | 5320h | 5156.65h | VGCSFlex | Robert Zaus (Siemens) | robert.zaus@siemens.com | Rel-7 | Andrijana |  |
| 301 | 67.1 | CT1 aspects of VGCSFlex | 159d? | 2006-03-22 A | 2006-10-30 A | 100% |  | 2006-03-22 | 2006-10-30 | 159d? |  | finish no earlier than 2006-10-30 | C1 | 1272h | 1272h | VGCSFlex-c1 |  |  | Rel-7 |  |  |
| 302 | 67.2 | CT4 aspects of VGCSFlex | 253d? | 2006-03-22 A | 2007-03-09 | 95% | 12.65d? | 2006-03-22 | 2006-12-01 | 183d? | 350d | finish no earlier than 2007-03-09 | C4 | 2024h | 1922.8h | VGCSFlex-c4 |  |  | Rel-7 |  |  |
| 303 | 68 | **One Tunnel solution for Optimisation of Packet Data Traffic** | 245d? | 2006-03-27 A | 2007-03-02 | 49% | 125.46d? | 2006-03-27 | 2006-12-15 | 190d? | 355d |  | S2 | 4280h | 2088.34h | OPTUNEL | Antti Pasanen (Nokia) |  | Rel-7 | Maurice |  |
| 304 | 68.1 | Discontinued - Stage 2 Study for One Tunnel solution | 125d? | 2006-03-27 A | 2006-09-15 A | 100% |  | 2006-03-27 | 2006-09-15 | 125d? |  | finish no earlier than 2005-09-12 | S2 | 1000h | 1000h | OPTUNEL-Study | Antti Pasanen (Nokia) | antti.j.pasanen@nokia.com | Rel-7 | Maurice | TSG |
| 305 | 68.2 | One Tunnel Deployment Guideline | 95d? | 2006-10-23 A | 2007-03-02 | 10% | 85.5d? | 2006-03-27 | 2006-09-15 | 125d? | 355d | finish no earlier than 2005-09-12 | S2 | 760h | 76h | OPTUNEL-Guide | Lan Liu (Huawei) | lan.liu@huawei.com | Rel-7 | Maurice | TSG |
| 306 | 68.3 | Stage 2 specification for One Tunnel solution | 70d? | 2006-09-11 A | 2006-12-15 | 10% | 63d? | 2006-09-11 | 2006-12-15 | 70d? | 410d | finish no earlier than 2006-12-15 | S2 | 560h | 56h | OPTUNEL-Stage2 | Antti Pasanen (Nokia) | antti.j.pasanen@nokia.com | Rel-7 | Maurice | TSG |
| 307 | 69 | **Downlink Dual Carrier** | 346d? | 2006-01-20 A | 2007-05-18 | 36% | 222.25d? | 2006-01-20 | 2007-05-18 | 346d? | 300d |  | GP | 12000h | 3696h | GDCDL | Leonardo Provvedi, Siemens AG | leonardo.provvedi@roke.co.uk | Rel-7 | Paolo |  |
| 308 | 69.1 | Downlink Dual Carrier Stage 2 | 116d? | 2006-01-20 A | 2006-06-30 A | 100% |  | 2006-01-20 | 2006-06-30 | 116d? |  | finish no earlier than 2006-06-30 | G1 | 928h | 928h | GDCDL-Stage2 | Leonardo Provvedi, Siemens AG | leonardo.provvedi@roke.co.uk | Rel-7 | Paolo |  |
| 309 | 69.2 | Downlink Dual Carrier Stage 3 | 346d? | 2006-01-20 A | 2007-05-18 | 50% | 173d? | 2006-01-20 | 2006-11-17 | 216d? | 300d | finish no earlier than 2007-05-18 | G2;; G1 | 5536h | 2768h | GDCDL-Stage3 | Leonardo Provvedi, Siemens AG | leonardo.provvedi@roke.co.uk | Rel-7 | Gert, Paolo |  |
| 310 | 69.3 | Downlink Dual Carrier – MS Conformance Test | 346d? | 2006-01-20 | 2007-05-18 |  |  | 2006-01-20 | 2007-05-18 | 346d? | 300d | start no earlier than 2006-01-20 | G3 | 2768h |  | GDCDL-MStest | Leonardo Provvedi, Siemens AG | leonardo.provvedi@roke.co.uk | Rel-7 | Stoyan |  |
| 311 | 70 | Support of SIGTRAN in GERAN | 116d? | 2006-01-20 A | 2006-06-30 A | 100% |  | 2006-01-20 | 2006-06-30 | 116d? |  | finish no earlier than 2006-06-30 | GP | 928h | 928h | GSIGT | Peter Ostrup, Ericsson | peter.ostrup@ericsson.com | Rel-7 | Paolo |  |
| 312 | 71 | Packet Switched Streaming Enhancements | 261d? | 2006-06-08 A | 2007-06-07 | 25% | 195.75d? | 2006-06-08 | 2007-06-07 | 261d? | 286d | finish no earlier than 2007-06-07 | S4 | 2088h | 522h | PSSe | Olle Franceschi (Ericsson) | olle.franceschi@ericsson.com | Rel-7 | Paolo |  |

Notes:
- 286: Moved from FS section Feb 06. SP-33: Create new section to capture the PNM stage 2 aspects and identify any impacts to existing stage 2 specifications. S2 added as secondary responsibility
- 287: Moved from FS section Feb 06
- 288: Moved from FS section Feb 06: SP-33: Create new section to capture the PNM stage 2 aspects and identify any impacts to existing stage 2 specifications. / Text3: 22.259, 23.818
- 289: Text3: 33.xxx
- 291: Text3: 22.173
- 292: TS 24.173:IMS Multimedia telephony service and supplementary services / Text3: New TS 24.173
- 293: Text3: 26.114, 26.235, 26.236
- 294: Moved from FS section Feb 06 / Text3: 29.163, 29.332
- 295: Moved from FS section Feb 06
- 296: Text3: 29.163
- 297: Text3: 22.101, 22.011, 23.122, 24.008, 25.304, 31.102, 45.008
- 298: Text3: 22.101, 22.011, 23.122, 24.008, 25.304, 31.102, 45.008
- 299: Text3: 23.122, 24.008, 31.102
- 300: Text3: 43.068, 43.069, 29.002
- 301: Text3: 43.068, 43.069
- 302: CT4#33: The work is 95% complited / Text3: 29.002
- 304: S2#52 CREATED. TR for Info SP-33. SP-34: S2 Report intention to discontinue TR / Text3: 23.809
- 305: S2#55 CREATED: SP-34 Approved and exception request granted until 03/07 / Text3: 23.9de
- 306: S2#52 CREATED / Text3: 23.060
- 307: Text3: 24.008, 43.055, 43.064, 44.018, 44.060, 45.001, 45.002, 45.005, 45.008, 51.010
- 308: Text3: 43.055, 43.064
- 309: Text3: 24.008, 44.018, 44.060, 45.001, 45.002, 45.005, 45.008
- 310: Text3: 51.010
- 311: Text3: 48.001, 48.006, 43.059, 49.031
- 312: Text3: 26.234, 26.244

| ID | WBS | Task | Type | Duration | Start | Finish | Complete | Remaining | Baseline start | Baseline finish | Baseline duration | Total slack | Constraint | Resources | Work | Actual work | Text1 | Text4 | Text5 | Text6 | Text8 | Text12 | Text7 |
| --- | --- | --- | --- | --- | --- | --- | --- | --- | --- | --- | --- | --- | --- | --- | --- | --- | --- | --- | --- | --- | --- | --- | --- |
| 313 | 72 | **Charging Management small Enhancements** |  | 214d? | 2006-05-22 A | 2007-03-15 | 44% | 118.88d? | 2006-05-22 | 2006-12-15 | 150d? | 346d |  | S5 | 4392h | 1952.14h | CH7 | Orange | alain.bibas@francetelecom.com | Rel-7 | Adrian |  |  |
| 314 | 72.1 | Alternate Charged Party (ACP) for IMS |  | 214d? | 2006-05-22 A | 2007-03-15 | 30% | 149.8d? | 2006-05-22 | 2006-12-15 | 150d? | 346d | finish no earlier than 2007-03-15 | S5 | 1712h | 513.6h | CH7-IMS-ACP | Lucent | njmazzarella@lucent.com | Rel-7 |  |  |  |
| 315 | 72.2 | Align 3GPP Charging with OMA PoC Enabler Release 2.0 |  | 121d? | 2006-09-28 A | 2007-03-15 | 70% | 36.3d? | 2006-09-28 | 2006-12-07 | 51d? | 346d | finish no earlier than 2007-03-15 | S5 | 968h | 677.6h | CH7-PoC | Siemens | gerald.goermer@siemens.com | Rel-7 | Adrian |  |  |
| 316 | 73 | **Latency Reductions** |  | 231d? | 2006-06-30 A | 2007-05-18 | 50% | 115.5d? | 2006-06-30 | 2007-11-16 | 361d? | 300d |  | GP | 5544h | 1848h | LATRED | Håkan Persson, Ericsson | Hakan.Persson@Ericsson.com | Rel-7 | Paolo |  |  |
| 317 | 73.1 | Improved Ack/Nack reporting |  | 231d? | 2006-06-30 A | 2007-05-18 | 50% | 115.5d? | 2006-06-30 | 2007-11-16 | 361d? | 300d | finish no earlier than 2007-05-18 | G2 | 1848h | 924h | LATRED-ACKNAR | Håkan Persson, Ericsson | Hakan.Persson@Ericsson.com | Rel-7 | Gert |  |  |
| 318 | 73.2 | Reduced TTI |  | 231d? | 2006-06-30 A | 2007-05-18 | 50% | 115.5d? | 2006-06-30 | 2007-05-18 | 231d? | 300d | finish no earlier than 2007-05-18 | G2 | 1848h | 924h | LATRED-REDTTI | Håkan Persson, Ericsson | Hakan.Persson@Ericsson.com | Rel-7 | Gert |  |  |
| 319 | 74 | PS Handover between GERAN/UTRAN mode and GAN Mode |  | 166d? | 2006-06-30 A | 2007-02-16 | 60% | 66.4d? | 2006-06-30 | 2007-02-16 | 166d? | 365d | finish no earlier than 2007-02-16 | G2 | 1328h | 796.8h | GUGAN | John Diachina, Ericsson | John.Diachina@Ericsson.com | Rel-7 | Gert |  |  |
| 320 | 75 | **CSI Terminating Session handling** |  | 200d? | 2006-06-08 A | 2007-03-14 | 42% | 115.06d? | 2006-06-08 | 2006-11-30 | 126d? | 347d |  | S2 | 3656h | 1552.73h | CSItermS | Osok Song (Samsung) |  | Rel-7 | Maurice |  |  |
| 321 | 75.1 | Stage 2 of CStermS |  | 192d? | 2006-06-08 A | 2007-03-02 | 45% | 105.6d? |  |  |  | 355d | start no earlier than 2006-06-08 | S2 | 1536h | 691.2h | CSItermS | Osok Song (Samsung) |  | Rel-7 | Maurice |  |  |
| 322 | 75.2 | Stage 3 of CStermS |  | 65d? | 2006-12-14 A | 2007-03-14 | 35% | 42.25d? |  |  |  | 347d | start no earlier than 2006-12-14 | C1 | 520h | 182h | CSItermS | Chen-Ho CHIN, Samsung | chenho.chin@samsung.com | Rel-7 | Andrijana |  |  |
| 323 | 75.3 | Deleted - duplicated with UID 340015 -Stage 3 CSI Terminating Session handling | milestone | 0d? | 2007-03-09 A | 2007-03-09 A | 100% |  |  |  |  |  | start no earlier than 2007-03-09 | C1 |  |  | CSItermS | Chen-Ho CHIN, Samsung | chenho.chin@samsung.com | Rel-7 | Andrijana | CP-34 |  |
| 324 | 76 | High speed interface between the UICC and the ME |  | 121d? | 2006-09-22 A | 2007-03-09 | 5% | 114.95d? | 2006-09-22 | 2007-03-09 | 121d? | 350d | start no earlier than 2006-09-22 | C6 | 968h | 48.4h | HSI | Stefan Kaliner, T-Mobile |  | Rel-7 | Gaby |  |  |
| 325 | 77 | Interworking between the 3GPP CS domain with BICC or ISUP as signalling protocol and external SIP-I networks |  | 136d? | 2006-09-22 A | 2007-03-30 | 60% | 54.4d? | 2006-09-22 | 2007-03-30 | 136d? | 335d | finish no earlier than 2007-03-09 | C3 | 1088h | 652.8h | ExtSIPI | Thomas Belling, Siemens | thomas.belling@SIEMENS.COM | Rel-7 | Seung Don |  |  |
| 326 | 78 | **Higher Uplink performance for GERAN Evolution** |  | 311d? | 2006-09-08 A | 2007-11-16 | 1% | 308.91d? | 2006-09-08 | 2007-11-16 | 311d? | 170d |  | GP | 13256h | 89.13h | HUGE | E. Riddington (Nokia) and S. Eriksson (Ericsson) | eddie.riddington@nokia.com, stefan.g.eriksson@ericsson.com | Rel-7 | Paolo |  |  |
| 327 | 78.1 | Stage 2 of HUGE |  | 181d? | 2006-09-08 A | 2007-05-18 | 5% | 171.95d? | 2006-09-08 | 2006-11-17 | 51d? | 300d | finish no earlier than 2007-05-18 | G1 | 1448h | 72.4h | HUGE-Stage2 | E. Riddington (Nokia) and S. Eriksson (Ericsson) | eddie.riddington@nokia.com, stefan.g.eriksson@ericsson.com | Rel-7 | Paolo |  |  |
| 328 | 78.2 | Layer 1 Support of HUGE |  | 181d? | 2006-09-08 | 2007-05-18 |  |  | 2006-09-08 | 2007-05-18 | 181d? | 300d | finish no earlier than 2007-05-18 | G1 | 1448h |  | HUGE-Layer1 | E. Riddington (Nokia) and S. Eriksson (Ericsson) | eddie.riddington@nokia.com, stefan.g.eriksson@ericsson.com | Rel-7 | Paolo |  |  |
| 329 | 78.3 | Layer 2/3 Support of HUGE |  | 181d? | 2006-09-08 | 2007-05-18 |  |  | 2006-09-08 | 2007-05-18 | 181d? | 300d | finish no earlier than 2007-05-18 | G2 | 1448h |  | HUGE-Layer23 | E. Riddington (Nokia) and S. Eriksson (Ericsson) | eddie.riddington@nokia.com, stefan.g.eriksson@ericsson.com | Rel-7 | Gert |  |  |
| 330 | 78.4 | Performance requirements |  | 181d? | 2006-09-08 | 2007-05-18 |  |  | 2006-09-08 | 2007-05-18 | 181d? | 300d | start no earlier than 2006-09-08 | G1 | 1448h |  | HUGE-Perfreq | E. Riddington (Nokia) and S. Eriksson (Ericsson) | eddie.riddington@nokia.com, stefan.g.eriksson@ericsson.com | Rel-7 | Paolo |  |  |
| 331 | 78.5 | MS Conformance Test |  | 311d? | 2006-09-08 | 2007-11-16 |  |  | 2006-09-08 | 2007-11-16 | 311d? | 170d | finish no earlier than 2007-11-16 | G3 | 2488h |  | HUGE-Mstest | E. Riddington (Nokia) and S. Eriksson (Ericsson) | eddie.riddington@nokia.com, stefan.g.eriksson@ericsson.com | Rel-7 | Stoyan |  |  |
| 332 | 78.6 | BTS Conformance Test |  | 311d? | 2006-09-08 | 2007-11-16 |  |  | 2006-09-08 | 2007-11-16 | 311d? | 170d | start no earlier than 2006-09-08 | G1 | 2488h |  | HUGE-BTStest | E. Riddington (Nokia) and S. Eriksson (Ericsson) | eddie.riddington@nokia.com, stefan.g.eriksson@ericsson.com | Rel-7 | Paolo |  |  |
| 333 | 79 | Routeing of MT-SMs via the HPLMN |  | 71d? | 2006-12-01 A | 2007-03-09 | 20% | 56.8d? | 2005-10-07 | 2006-12-01 | 301d? | 350d | finish no earlier than 2007-03-09 | C4 | 568h | 113.6h | SMSviaH | Nick Russell, Vodafone UK | Nick.Russell@vodafone.com | Rel-7 | Kimmo |  |  |
| 334 | 80 | (Small) Technical Enhancements and Improvements for Rel-7 |  | 490d? | 2005-05-09 | 2007-03-23 |  |  | 2005-05-09 | 2007-03-23 | 490d? | 340d | start no earlier than 2005-05-09 | All | 3920h |  | TEI7 |  |  | Rel-7 |  |  |  |
| 335 | 81 | **Deleted - PS domain and IMS support for IMS Emergency sessions** |  | 63.69d? | 2006-06-23 A | 2006-09-21 A | 100% |  | 2006-06-23 | 2006-09-21 | 63.69d? |  |  | S2 |  |  | IMS-EMER | Curt Wong (Nokia) | curt.c.wong@nokia.com | Rel-7 | Maurice | SP-30 |  |
| 336 | 81.1 | Deleted - IMS aspects to support IMS Emergency sessions | milestone | 0d? | 2006-06-23 A | 2006-09-21 A | 100% |  | 2006-06-23 | 2006-09-21 | 0d? |  | start no earlier than 2006-06-23 | S2 |  |  |  | Curt Wong (Nokia) | curt.c.wong@nokia.com | Rel-7 | Maurice | SP-30 | TSG |
| 337 | 81.2 | Deleted - PS domain aspects to support IMS Emergency sessions | milestone | 0d? | 2006-06-23 A | 2006-09-21 A | 100% |  | 2006-06-23 | 2006-09-21 | 0d? |  | start no earlier than 2006-06-23 | S2 |  |  |  | Curt Wong (Nokia) | curt.c.wong@nokia.com | Rel-7 | Maurice | SP-30 | TSG |
| 338 | 82 | Deleted - Covered by SI - Personal Network (PN) and Personal Area Network (PAN) | milestone | 0d? | 2005-12-08 A | 2005-12-20 A | 100% |  | 2005-12-08 | 2005-12-20 | 0d? |  | start no earlier than 2005-12-08 | S1 |  |  | PNPAN | Armin Toepfer, Vodafone | armin.toepfer@vodafone.com | Rel-7 | Mike | SP-30 |  |
| 339 | 83 | Deleted - Covered by SI - Multimedia Telephony Capabilities for IMS | milestone | 0d? | 2005-12-08 A | 2005-12-20 A | 100% |  | 2005-12-08 | 2005-12-20 | 0d? |  | start no earlier than 2005-12-08 | S1 |  |  | MITE | Peter Bleckert, Ericsson | peter.bleckert @ericsson.com | Rel-7 | Mike | SP-30 |  |
| 340 | 84 | Deleted - Covered by SI - Transferring of emergency Call data | milestone | 0d? | 2005-12-08 A | 2005-12-08 A | 100% |  | 2005-12-08 | 2005-12-08 | 0d? |  | start no earlier than 2005-12-08 | S1 |  |  | eCALL | Steve Vardy, (Motorola S.A.S) | steven.vardy@motorola.com | Rel-7 | Mike | SP-30 |  |
| 341 | 85 | Deleted - Covered by SI - MBMS Enhancements | milestone | 0d? | 2005-12-08 A | 2005-12-08 A | 100% |  | 2005-12-08 | 2005-12-08 | 0d? |  | start no earlier than 2005-12-08 | S1 |  |  | MBMSE | Liu Hong, China Mobile | liuhongyfw@chinamobile.com | Rel-7 | Mike | SP-30 |  |
| 342 | 86 | Rel-7 Feasibility Studies |  | 1d? | 2000-01-03 | 2000-01-03 |  |  | 2000-01-03 | 2000-01-03 | 1d? | 2224d |  | CT;RAN;SA | 8h |  |  |  |  | Rel-7 |  |  |  |

Notes:
- 313: Text3: 32.2xy
- 314: Text3: 32.240, 32.260, 32.298, 32.299
- 315: 09/2006 SA#33 WID approved / Text3: 32.240, 32.272, 32.299, 32.298
- 316: Text3: 45.001, 45.002, 45.003, 45.005, 45.010, 43.055, 43.064, 44.060, 51.010-1, 51.021
- 317: Text3: 45.001, 45.002, 45.003, 45.005, 45.010, 43.055, 43.064, 44.060, 51.010-1, 51.021
- 318: Text3: 45.001, 45.002, 45.003, 45.005, 45.010, 43.055, 43.064, 44.060, 51.010-1, 51.021
- 319: Text3: 43.318, 44.318, 43.129, 25.306, 24.008, 44.060, 25.331, 51.010
- 320: Not to be confused with FS with same name / Text3: 23.228, 23.279
- 321: Created to dissociate Stage 2 line from feature line / Text3: 23.228, 23.279
- 322: WID approved in CT#34 / Text3: 24.229, 24.179, 24.279
- 323: WID approved in CT#34 / Text3: 24.229, 24.179, 24.279
- 324: Text3: 31.101, 31.102, 31.103
- 325: Text3: new TS 29.164
- 326: Text3: 24.008, 43.055, 43.064, 44.018, 44.060, 45.001, 45.002, 45.003, 45.004, 45.005, 45.008, 45.010, 51.010, 51.021
- 327: Text3: 43.055, 43.064
- 328: Text3: 45.001, 45.002, 45.003, 45.004, 45.008
- 329: Text3: 24.008, 44.018, 44.060
- 330: Text3: 45.005
- 331: Text3: 51.010
- 332: Text3: 51.021
- 333: WID approved in CT#34 / Text3: 23.040, 23.003, 29.002
- 335: Approved at SP#29 / Text3: 23.867, TS 23.abc, 23.060, 23.002, 23.271
- 336: Approved at SP#29 / Text3: 23.867, TS 23.abc, 23.060, 23.002, 23.271
- 337: Approved at SP#29 / Text3: 23.867, TS 23.abc, 23.060, 23.002, 23.271

| ID | WBS | Task | Duration | Start | Finish | Complete | Remaining | Baseline start | Baseline finish | Baseline duration | Total slack | Constraint | Resources | Work | Actual work | Text1 | Text4 | Text5 | Text6 | Text8 | Text3 | Text7 |
| --- | --- | --- | --- | --- | --- | --- | --- | --- | --- | --- | --- | --- | --- | --- | --- | --- | --- | --- | --- | --- | --- | --- |
| 343 | 87 | **(FS on) Multimedia Telephony Capabilities for IMS** | 320d? | 2005-07-11 A | 2006-09-29 A | 100% |  | 2005-07-11 | 2006-09-29 | 320d? |  |  | S1 | 6089.6h | 6089.6h | MITE | Peter Bleckert, Ericsson | peter.bleckert @ericsson.com | Rel-7 | Mike |  |  |
| 344 | 87.1 | Study of (MITe) - IMS Multimedia Telephony Communication Enabler and supplementary services | 276d? | 2005-07-11 A | 2006-07-31 A | 100% |  | 2005-07-11 | 2006-07-31 | 276d? |  | start no earlier than 2005-07-11 | S1 | 2208h | 2208h |  | Peter Bleckert, Ericsson | peter.bleckert @ericsson.com | Rel-7 | Mike | 22.973 |  |
| 345 | 87.2 | IMS Multimedia Telephony Service | 173d? | 2006-02-01 A | 2006-09-29 A | 100% |  | 2006-02-01 | 2006-09-29 | 173d? |  | start no earlier than 2006-02-01 | S1 | 1384h | 1384h |  | Peter Bleckert, Ericsson | peter.bleckert @ericsson.com | Rel-7 | Mike | 22.173 |  |
| 346 | 88 | Study Item on IMS enhancements and optimisations for real time communication. | 430d? | 2005-10-10 A | 2007-06-01 | 65% | 150.5d? | 2005-10-10 | 2006-12-22 | 315d? | 290d | finish no earlier than 2007-06-01 | S2 | 3440h | 2236h | IMS-RT | Stephen Terrill (Ericsson) | stephen.terrill@ericsson.com | Rel-7 | Maurice | 23.818 |  |
| 347 | 89 | (FS on) Behaviour of Multi system UEs | 480d? | 2004-06-28 A | 2006-04-28 | 90% | 48d? | 2004-06-28 | 2006-04-28 | 480d? | 575d | start no earlier than 2004-06-28 | S1 | 3840h | 3456h | BMSU | D Williams (QUALCOMM) | dwilliams@qualcomm.com | Rel-7 | Michael | 22.936 | TSG |
| 348 | 90 | **FS on IMS with real time services deployment** | 384d? | 2004-06-28 A | 2005-12-15 | 99% | 0d? | 2004-06-28 | 2005-12-15 | 384d? | 0d |  | S1 | 8672h | 6304.24h | IRTSD |  |  | Rel-7 | Maurice |  | TSG |
| 349 | 90.1 | Feasibility Study on Combining CS calls and IMS sessions | 384d? | 2004-06-28 A | 2005-12-15 A | 100% |  | 2004-06-28 | 2005-12-15 | 384d? |  | start no earlier than 2004-06-28 | S1 | 3072h | 3072h | IRTSD-CS_IMS |  |  | Rel-7 | Michael | 22.979, 23.899 | TSG |
| 350 | 90.2 | TR on Stage 2 (IMS services using CS bearers) | 316d? | 2004-06-28 A | 2005-09-12 A | 100% |  | 2004-06-28 | 2005-09-12 | 316d? |  | finish no earlier than 2005-09-12 | S2 | 2528h | 2528h | IRTSD-IMSCS | Mark Watson (Nortel Networks) |  | Rel-7 | Maurice | 23.899 | TSG |
| 351 | 91 | (FS on) Terminating Session handling | 255d? | 2006-01-09 A | 2006-12-29 | 80% | 51d? | 2006-01-09 | 2006-12-29 | 255d? | 400d | finish no earlier than 2006-12-29 | S2 | 2040h | 1632h | CSIterm | Osok Song (Samsung) | osok.song@samsung.com | Rel-7 | Maurice | 23.819 |  |
| 352 | 92 | FS on Performance Evaluation of the UE behaviour in high speed trains with speeds up to 350 kmph | 328d? | 2005-03-15 A | 2006-06-15 A | 100% |  | 2005-03-15 | 2006-06-15 | 328d? |  | finish no earlier than 2006-06-15 | R4 | 2624h | 2624h | RANFS-HSTrains | Mike Vogel | Mike.vogel@vodafone.com | Rel-7 | MCC_RAN |  | TSG |
| 353 | 93 | FS on Evolved UTRA and UTRAN | 458d? | 2004-12-15 A | 2006-09-15 A | 100% |  | 2004-12-15 | 2006-09-15 | 458d? |  | finish no earlier than 2006-09-15 | RP | 3664h | 3664h | RANFS-Evo | Takehiro Nakamura (NTT DoCoMo) | nakamurata@NTTDOCOMO.CO.JP | Rel-7 | MCC_RAN |  | TSG |
| 354 | 94 | **Study on Videotelephony teleservice** | 231d? | 2005-03-01 A | 2006-01-17 A | 100% |  | 2005-03-01 | 2006-01-17 | 231d? |  |  | S1 | 3696h | 3696h | VidTel | Kurt Bischinger (T-Mobile) | kurt.bischinger@t-mobile.at | Rel-7 | Michael |  | TSG |
| 355 | 94.1 | Study on Videotelephony service requirements | 231d? | 2005-03-01 A | 2006-01-17 A | 100% |  | 2005-03-01 | 2006-01-17 | 231d? |  | start no earlier than 2005-03-01 | S1 | 1848h | 1848h |  | Kurt Bischinger (T-Mobile) | kurt.bischinger@t-mobile.at | Rel-7 | Michael | 22.903 | TSG |
| 356 | 95 | **Study of Network Selection Principles** | 193d? | 2005-03-15 A | 2005-12-08 | 99% | 0d? | 2005-03-15 | 2005-12-08 | 193d? | 0d |  | S1 | 3088h | 2658.02h | NetSel | Chris Friel (O2) | chris.friel@o2.com | Rel-7 | Michael |  | TSG |
| 357 | 95.1 | Review of Network Selection Principles | 193d? | 2005-03-15 A | 2005-12-08 A | 100% |  | 2005-03-15 | 2005-12-08 | 193d? |  | finish no earlier than 2005-12-08 | S1 | 1544h | 1544h |  | Chris Friel (O2) | chris.friel@o2.com | Rel-7 | Michael | 22.811 | TSG |
| 358 | 96 | FS on Continuous connectivity for packet data users | 132d? | 2005-03-15 A | 2005-09-15 A | 100% |  | 2005-03-15 | 2005-09-15 | 132d? |  | finish no earlier than 2005-09-15 | R1 | 1056h | 1056h | RANFS-cont-packet | Joerg Gustrau | joerg.gustrau@siemens.com | Rel-7 | MCC_RAN |  | TSG |
| 359 | 97 | FS on UTRA Tower Mounted Amplifier (FDD) | 195d? | 2005-06-15 A | 2006-03-14 A | 100% |  | 2005-06-15 | 2006-03-14 | 195d? |  | finish no earlier than 2006-03-15 | R4 | 1560h | 1560h | RANFS-TMA | Klas Sjerling | Klas.Sjerling@ericsson.com | Rel-7 | MCC_RAN |  | TSG |
| 360 | 98 | (FS on) Multimedia Priority Service | 851d? | 2003-03-28 A | 2006-06-30 A | 100% |  | 2003-03-28 | 2006-06-30 | 851d? |  | finish no earlier than 2005-12-16 | S1 | 6808h | 6808h | PRIOR-MM | Jim Garrahan (Telcordia) | jgarraha@telcordia.com | Rel-7 | Michael | 22.953 |  |
| 361 | 99 | (FS on) Transferring of emergency Call data | 190d? | 2005-07-11 A | 2006-03-31 A | 100% |  | 2005-07-11 | 2006-03-31 | 190d? |  | finish no earlier than 2005-12-08 | S1 | 1520h | 1520h | eCALL | Steve Vardy, (Motorola S.A.S) | steven.vardy@motorola.com | Rel-7 | Mike | 22.967 |  |
| 362 | 100 | FS on Routeing of MT-SMs via the HPLMN | 301d? | 2005-10-07 A | 2006-12-01 A | 100% |  | 2005-10-07 | 2006-12-01 | 301d? |  | finish no earlier than 2006-12-01 | C4 | 2408h | 2408h | SMS7 | Nick Russell, Vodafone UK | Nick.Russell@vodafone.com | Rel-7 | Kimmo | 23.840 |  |
| 363 | 101 | FS on Improvement of the Multimedia Broadcast Multicast Service (MBMS) in UTRAN | 262d? | 2005-12-15 A | 2006-12-15 | 90% | 26.2d? | 2005-12-15 | 2006-12-15 | 262d? | 410d | finish no earlier than 2006-12-15 | R2 | 2096h | 1886.4h | RANFS-MBMSImp | YoungDae Lee, LG | leego@lge.com | Rel-7 | MCC_RAN |  |  |
| 364 | 102 | FS on Performance Improvements in Small Cells using HSDPA/EDCH | 131d? | 2005-12-15 A | 2006-06-15 A | 100% |  | 2005-12-15 | 2006-06-15 | 131d? |  | finish no earlier than 2006-06-15 | R4 | 1048h | 1048h | SMALLCELLS | Marc Grant, Cingular | marc.grant@cingular.com | Rel-7 | MCC_RAN |  |  |
| 365 | 103 | FS on Further Improved Performance Requirements for UMTS/HSDPA UE (FDD) | 326d? | 2005-12-15 A | 2007-03-15 | 60% | 130.4d? | 2005-12-15 | 2007-03-15 | 326d? | 346d | finish no earlier than 2007-03-15 | R4 | 2608h | 1564.8h | RANFS-IC | Marc Grant, Cingular | marc.grant@cingular.com | Rel-7 | MCC_RAN |  |  |
| 366 | 104 | FS on the TCAPsec Gateway concept | 96d? | 2005-10-28 A | 2006-03-10 A | 100% |  | 2005-10-28 | 2006-03-10 | 96d? |  | finish no earlier than 2006-03-10 | C4 | 768h | 768h | SEC7-TCAP | Ulrich Wiehe, Siemens | Ulrich.wiehe@gksag.de | Rel-7 | Kimmo | 29.800 |  |
| 367 | 105 | Study of Customised Alerting Tone (CAT) Requirements | 191d? | 2005-10-07 A | 2006-06-30 | 60% | 76.4d? | 2005-10-07 | 2006-06-30 | 191d? | 530d | start no earlier than 2005-10-07 | S1 | 1528h | 916.8h | CAT | Feng Lingjuan, China Mobile | fenglingjuan@chinamobile.com | Rel-7 | Michael | 22.982 |  |
| 368 | 106 | SI on Scope of future FDD HSPA Evolution | 262d? | 2006-03-15 A | 2007-03-15 | 70% | 78.6d? | 2006-03-15 | 2006-12-15 | 198d? | 346d | finish no earlier than 2007-03-15 | RP | 2096h | 1467.2h | RANFS-HSPAEvo | Don Zelmer | don.zelmer@cingular.com | Rel-7 | MCC_RAN |  |  |

Notes:
- 343: Moved from FS section Feb 06
- 346: Approved at SP#29. To be shown as feature - END Sept 06
- 347: The WID still calls it a BB, not a Feature.
- 351: S2#52: Split into Study and Specification phases.
- 360: Moved from Rel6, "FS on" added by MCC to distinguish from actual feature
- 362: Previously known as "Study of a SMS Centre for MT SMS"
- 363: Completed at RP#34 as RP-060692
- 366: Study WI / TR presented for information in CT#30
- 367: Awaiting MCC SA3 input; No input from SA3 at this time

| ID | WBS | Task | Type | Duration | Start | Finish | Complete | Remaining | Baseline start | Baseline finish | Baseline duration | Total slack | Constraint | Resources | Work | Actual work | Text1 | Text4 | Text5 | Text6 | Text7 | Text8 | Text3 | Text12 |
| --- | --- | --- | --- | --- | --- | --- | --- | --- | --- | --- | --- | --- | --- | --- | --- | --- | --- | --- | --- | --- | --- | --- | --- | --- |
| 369 | 107 | **OAM&P Studies** |  | 466d? | 2005-09-02 A | 2007-06-15 | 71% | 135.72d? | 2005-09-02 | 2007-03-30 | 411d? | 280d |  | S5 | 23472h | 16681.6h | OAM7-Study | Toche | Christian.Toche@huawei.com | Rel-7 | TSG | Adrian |  |  |
| 370 | 107.1 | Study of Element Operations Systems Function (EOSF) definition |  | 400d? | 2005-09-02 A | 2007-03-15 | 55% | 180d? | 2005-09-02 | 2006-12-15 | 336d? | 346d | finish no earlier than 2007-03-15 | S5 | 3200h | 1760h |  | China Mobile |  | Rel-7 |  |  | new TR 32.8xy | SP-32 |
| 371 | 107.2 | Study of SOAP/HTTP IRP Solution Sets |  | 330d? | 2005-09-02 A | 2006-12-07 A | 100% |  | 2005-09-02 | 2006-12-15 | 336d? |  | finish no earlier than 2006-12-07 | S5 | 2640h | 2640h |  | Nortel |  | Rel-7 |  |  | TR 32.809 | SP-32 |
| 372 | 107.3 | Study of Itf-N Implementation Conformance Statement (ICS) template |  | 400d? | 2005-09-02 A | 2007-03-15 | 90% | 40d? | 2005-09-02 | 2006-12-15 | 336d? | 346d | finish no earlier than 2007-03-15 | S5 | 3200h | 2880h |  | China Mobile |  | Rel-7 |  |  | TR 32.812 | SP-32 |
| 373 | 107.4 | Study of IRP Information Model |  | 400d? | 2005-09-02 A | 2007-03-15 | 80% | 80d? | 2005-09-02 | 2006-12-15 | 336d? | 346d | finish no earlier than 2007-03-15 | S5 | 3200h | 2560h |  | Motorola |  | Rel-7 |  |  | TR 32.810 | SP-32 |
| 374 | 107.5 | Study on SA5 MTOSI XML Harmonization |  | 288d? | 2006-05-10 A | 2007-06-15 | 25% | 216d? | 2006-12-15 | 2006-12-15 | 0d? | 280d |  | S5 | 2304h | 576h |  | Nortel |  | Rel-7 |  |  | new TR 32.8xy | SP-32 |
| 375 | 107.6 | Study of Common Profile Storage (CPS) Framework of User Data for network services and management |  | 184d? | 2006-07-03 A | 2007-03-15 | 60% | 73.6d? | 2006-07-03 | 2007-03-30 | 195d? | 346d | finish no earlier than 2007-03-15 | S5 | 1472h | 883.2h |  | T-Mobile |  | Rel-7 |  |  | TR 32.808 |  |
| 376 | 107.7 | Study of Management for LTE and SAE |  | 136d? | 2006-12-07 A | 2007-06-14 | 5% | 129.2d? |  |  |  | 281d | finish no earlier than 2007-06-14 | S5 | 1088h | 54.4h |  | Ericsson |  | Rel-7 |  |  | TR 32.816 |  |
| 377 | 107.8 | Stopped - Study on IRP usage scenarios |  | 330d? | 2005-09-02 A | 2006-12-07 A | 100% |  | 2005-09-02 | 2006-12-15 | 336d? |  | finish no earlier than 2006-12-07 | S5 | 2640h | 2640h |  | Lucent |  | Rel-7 |  |  | new TR 32.8xy | SP-32 |
| 378 | 107.9 | **Deleted - Network Infrastructure Management** |  | 0d? | 2006-12-15 A | 2006-12-15 A | 100% |  | 2006-12-15 | 2006-12-15 | 0d? |  |  | S5 |  |  | OAM7-NIM |  |  | Rel-7 |  |  |  | SP-32 |
| 379 | 107.9.1 | Delete - was duplicated - Study on SA5 MTOSI XML Harmonization | milestone | 0d? | 2006-12-15 A | 2006-12-15 A | 100% |  | 2006-12-15 | 2006-12-15 | 0d? |  | start no earlier than 2006-12-15 | S5 |  |  | OAM7-NIM-XML | Nortel |  | Rel-7 |  |  | new TR 32.8xy | SP-30 |
| 380 | 108 | SI on AS-MRFC media server control protocol |  | 318d? | 2006-03-22 A | 2007-06-08 | 30% | 222.6d? | 2006-03-22 | 2007-03-09 | 253d? | 285d | finish no earlier than 2007-06-08 | C1 | 2544h | 763.2h | MRFC | Mark Syrett (Hewlett-Packard) |  | Rel-7 |  |  | New TR 24.880 |  |
| 381 | 109 | FS of using M2PA in 3GPP network |  | 318d? | 2006-03-22 A | 2007-06-08 | 60% | 127.2d? | 2006-03-22 | 2006-12-15 | 193d? | 285d | finish no earlier than 2007-06-08 | C4 | 2544h | 1526.4h | FS-M2PA | Zhao Yuyi | zhaoyuyi@chinamobile.com | Rel-7 |  | Kimmo |  |  |
| 382 | 110 | (FS on) Enhancement of E2E QoS |  | 336.4d? | 2004-06-28 A | 2005-12-01 A | 100% |  | 2004-06-28 | 2005-12-01 | 336.4d? |  | finish no earlier than 2005-12-01 | S2 | 2691.2h | 2691.2h | QoS7 |  |  | Rel-7 | TSG | Maurice | 23.802 |  |
| 383 | 111 | FS WID on Bandwidth Saving at Nb Interface with IP transport |  | 261d? | 2006-03-10 A | 2007-03-09 | 80% | 52.2d? | 2006-03-10 | 2007-03-09 | 261d? | 350d | finish no earlier than 2007-03-09 | C3 | 2088h | 1670.4h | BSNbIP | Thomas BELLING(Siemens) | thomas.belling@siemens.com | Rel-7 |  | Seung Don | new TR 29.814 |  |
| 384 | 112 | **(FS on) 3GPP System Architecture Evolution** |  | 526d? | 2004-12-03 A | 2006-12-08 | 69% | 161.42d? | 2004-12-03 | 2006-12-08 | 526d? | 415d |  | S2 | 8504h | 5894.2h | SAE |  |  | Rel-7 | TSG |  |  |  |
| 385 | 112.1 | Stage 2 Interim conclusion for RAN Work to start |  | 211d? | 2004-12-03 A | 2005-09-23 A | 100% |  | 2004-12-03 | 2005-09-23 | 211d? |  | finish no earlier than 2005-09-23 | S2 | 1688h | 1688h |  |  |  | Rel-7 |  |  | 23.882 |  |
| 386 | 112.2 | Stage 2 Feasibility study on 3GPP architectural development |  | 240d? | 2006-01-09 A | 2006-12-08 | 60% | 96d? | 2006-01-09 | 2006-12-08 | 240d? | 415d | finish no earlier than 2005-09-23 | S2 | 1920h | 1152h |  | Chris Pudney |  | Rel-7 |  | Maurice | 23.882 |  |
| 387 | 112.3 | Security study for Inter-access mobility between non 3GPP and 3GPP system |  | 86d? | 2006-02-03 A | 2006-06-02 | 20% | 68.8d? | 2006-02-03 | 2006-06-02 | 86d? | 550d | start no earlier than 2006-02-03 | S3 | 688h | 137.6h | SAE-Sec | Dajiang Zhang (Nokia) | dajiang.zhang@NOKIA.COM | Rel-7 |  |  | 23.882 |  |
| 388 | 112.4 | Deleted - Duplicateed with 32087 - Stage 2 Feasibility study on 3GPP architectural development | milestone | 0d? | 2006-09-27 A | 2006-09-27 A | 100% |  | 2006-09-27 | 2006-09-27 | 0d? |  | start no earlier than 2006-09-27 | S2 |  |  |  |  |  | Rel-7 |  |  | 23.882 | SP-32 |
| 389 | 113 | **FS WID on Support of (G)MSC-S - (G)MSC-S Nc Interface based on the SIP-I protocol** |  | 215d? | 2006-05-15 A | 2007-03-09 | 45% | 119.27d? | 2006-05-15 | 2006-12-15 | 155d? | 350d |  | C4 | 4680h | 2083.86h | NcSIP | David Hutton, Vodafone Group | david.hutton@vodafone.com | Rel-7 |  | Kimmo | 29.802 |  |
| 390 | 113.1 | CT4 aspects of NcSIP |  | 215d? | 2006-05-15 A | 2007-03-09 | 55% | 96.75d? | 2006-05-15 | 2006-12-15 | 155d? | 350d | finish no earlier than 2007-03-09 | C4 | 1720h | 946h |  |  |  | Rel-7 |  |  | 29.802 |  |
| 391 | 113.2 | CT3 aspects of NcSIP |  | 155d? | 2006-05-15 A | 2006-12-15 | 30% | 108.5d? | 2006-05-15 | 2006-12-15 | 155d? | 410d | start no earlier than 2006-05-15 | C3 | 1240h | 372h |  | Ragnar Huslende, Ericsson | ragnar.huslende@ericsson.com | Rel-7 |  |  |  |  |
| 392 | 114 | (FS on) Transferring of emergency call data – in-band modem solution |  | 206d? | 2006-12-07 | 2007-09-20 |  |  |  |  |  | 211d | finish no earlier than 2007-09-20 | S4 | 1648h |  | eCALLIBMS | Leon Hong, Airbiquity | lhong@airbiquity.com | Rel-7 |  | Paolo | 26.9xy |  |
| 393 | 115 | deleted - covered by UID33027 - IMS security extensions | milestone | 0d? | 2005-12-08 A | 2005-12-08 A | 100% |  | 2005-12-08 | 2005-12-08 | 0d? |  | start no earlier than 2005-12-08 | S3 |  |  | IMS-SE | Bengt Sahlin, Ericsson | Bengt.Sahlin@ericsson.com | Rel-7 |  | Mike |  | SP-30 |
| 394 | 116 | Deleted - covered by 32108 - Study of work on an LCS architecture for I-WLAN |  | 120d? | 2006-06-26 A | 2006-12-08 | 80% | 24d? | 2006-06-26 | 2006-12-08 | 120d? | 415d | finish no earlier than 2006-12-08 | S2 | 960h | 768h |  | Donghee Shim (LG Electronics Inc.) | dhshim@lge.com ; phede@lge.com | Rel-7 |  | Maurice |  | SP-33 |

Notes:
- 376: 12/2006 SA#34 WID approved
- 382: Moved to a FS as SA32 (in line with slides)
- 383: Moved to FS at CT32 (in line with slides)
- 385: RAN work started
- 386: S2#52: Study phase created
- 389: Study WI
- 394: S2#52: Entry created

| ID | WBS | Task | Type | Duration | Start | Finish | Complete | Remaining | Baseline start | Baseline finish | Baseline duration | Total slack | Constraint | Resources | Work | Actual work | Text1 | Text6 | Text12 | Text4 | Text5 | Text7 | Text8 |
| --- | --- | --- | --- | --- | --- | --- | --- | --- | --- | --- | --- | --- | --- | --- | --- | --- | --- | --- | --- | --- | --- | --- | --- |
| 395 | 117 | **Deleted: FS on applicability of GALILEO for LCS** |  | 484d? | 2003-08-25 A | 2005-06-30 A | 100% |  | 2003-08-25 | 2005-06-30 | 484d? |  |  | S2 | 3872h | 3872h | Galileo | Rel-7 | SP-25 |  |  |  |  |
| 396 | 117.1 | Deleted - TR on Stage 2 | milestone | 0d? | 2005-06-30 A | 2005-06-30 A | 100% |  | 2005-06-30 | 2005-06-30 | 0d? |  | finish no earlier than 2005-06-30 | S2 |  |  |  | Rel-7 | SP-25 |  |  |  |  |
| 397 | 117.2 | deleted - GERAN review of the TR | milestone | 0d? | 2003-08-25 A | 2003-08-25 A | 100% |  | 2003-08-25 | 2003-08-25 | 0d? |  | finish no earlier than 2003-08-25 | GP |  |  |  | Rel-7 | SP-26 |  |  |  |  |
| 398 | 16.7 | **Deleted - IMS Local services** |  | 984d? | 2002-03-29 A | 2006-01-06 A | 100% |  | 2002-03-29 | 2006-01-06 | 984d? |  |  | S2 | 7872h | 7872h | IMSLocal | Rel-7 | SP-28 |  |  |  |  |
| 399 | 16.7.1 | Deleted - Stage 2 | milestone | 0d | 2002-03-29 A | 2002-03-29 A | 100% |  | 2002-03-29 | 2002-03-29 | 0d |  | start no earlier than 2002-03-29 | S2 |  |  |  | Rel-7 | SP-26 |  |  |  |  |
| 400 | 118.2 | Delete - Stage 3 for IMS Local services | milestone | 0d? | 2006-01-06 A | 2006-01-06 A | 100% |  | 2006-01-06 | 2006-01-06 | 0d? |  | finish no earlier than 2006-01-06 | C1 |  |  |  | Rel-7 | SP-25 | Keith Drage, Lucent | drage@lucent.com |  |  |
| 401 | 119 | Deleted - IMS Phase 3 | milestone | 0d? | 2005-06-08 A | 2005-06-08 A | 100% |  | 2005-06-08 | 2005-06-08 | 0d? |  | finish no earlier than 2005-06-08 | S2 |  |  |  | Rel-7 | SP-25 |  |  |  |  |
| 402 | 120 | Deleted - Improvements of Radio Interface | milestone | 0d? | 2004-09-15 A | 2004-09-15 A | 100% |  | 2004-09-15 | 2004-09-15 | 0d? |  | start no earlier than 2004-09-15 | RP |  |  | RInImp | Rel-7 | SP-24 |  | Rel-7 | TSG | Claude |
| 403 | 121 | **Deleted: Generic User Profile Phase 2** |  | 234.4d | 2004-11-12 A | 2005-10-06 A | 100% |  | 2004-11-12 | 2005-10-06 | 234.4d |  |  | C4 |  |  |  | Rel-7 | SP-27 |  |  |  | Gaby |
| 404 | 30.4 | Deleted - Stage 3 - Common objects | milestone | 0d | 2004-11-12 A | 2005-10-06 A | 100% |  | 2004-11-12 | 2005-10-06 | 0d |  | finish no earlier than 2005-10-06 | C4 |  |  |  | Rel-7 | SP-27 |  |  | TSG | Gaby |
| 405 | 122 | Delete was duplicated- Study of Customised Alerting Tone (CAT) Requirements | milestone | 0d? | 2006-06-30 A | 2006-06-30 A | 100% |  | 2006-06-30 | 2006-06-30 | 0d? |  | start no earlier than 2006-06-30 | S1 |  |  | CAT | Rel-7 | SP-31 |  |  |  |  |
| 406 | 123 | Delete - was duplicated - Facilitating Machine to Machine Communication in GSM and UMTS (M2M) | milestone | 0d? | 2006-06-16 A | 2006-06-16 A | 100% |  | 2006-06-16 | 2006-06-16 | 0d? |  | start no earlier than 2006-06-16 | S1 |  |  | M2M | Rel-7 | SP-32 | Juergen Merkel, Siemens AG |  |  | Michael |
| 407 | 124 | Deleted - FS of enhanced support of Video Telephony | milestone | 0d? | 2006-06-30 A | 2006-06-30 A | 100% |  | 2006-06-30 | 2006-06-30 | 0d? |  | start no earlier than 2006-06-30 | GP |  |  | VIDGER | Rel-7 | SP-32 | Stefan Eriksson, Ericsson | stefan.g.eriksson@ericsson.com | TSG | Paolo |
| 408 | 125 | Release 8 Features |  | 1d? | 2000-01-03 | 2000-01-03 |  |  | 2000-01-03 | 2000-01-03 | 1d? | 2224d |  | CT;RAN;SA | 8h |  |  | Rel-8 |  |  |  |  |  |
| 409 | 126 | **Unified Network over IP** |  | 462d? | 2006-06-08 A | 2008-03-14 | 5% | 437.33d? |  |  |  | 85d |  | CT;RAN;SA | 45064h | 2627.66h | UNIP | Rel-8 |  |  |  |  |  |
| 410 | 126.1 | **3G Long Term Evolution** |  | 385d? | 2006-09-25 A | 2008-03-14 | 8% | 352.94d? | 2006-09-25 | 2007-11-30 | 310d? | 85d |  | RP | 12280h | 1131.6h | LTE | Rel-8 |  | Takehiro Nakamura (NTT DoCoMo) |  |  | MCC_RAN |
| 411 | 126.1.1 | 3G Long Term Evolution – Physical Layer |  | 255d? | 2006-09-25 A | 2007-09-14 | 10% | 229.5d? | 2006-09-25 | 2007-08-31 | 245d? | 215d | finish no earlier than 2007-09-14 | R1 | 2040h | 204h | LTE-Phys | Rel-8 |  | Sadayuki Abeta, NTT DoCoMo |  |  | MCC_RAN |
| 412 | 126.1.2 | 3G Long Term Evolution – Radio Interface Layer 2 and 3 Protocol Aspect |  | 255d? | 2006-09-25 A | 2007-09-14 | 10% | 229.5d? | 2006-09-25 | 2007-08-31 | 245d? | 215d | finish no earlier than 2007-09-14 | R2 | 2040h | 204h | LTE-L23 | Rel-8 |  | Benoist Sebire, Nokia |  |  | MCC_RAN |
| 413 | 126.1.3 | 3G Long Term Evolution – eUTRAN Interfaces |  | 255d? | 2006-09-25 A | 2007-09-14 | 10% | 229.5d? | 2006-09-25 | 2007-08-31 | 245d? | 215d | finish no earlier than 2007-09-14 | R3 | 2040h | 204h | LTE-interfaces | Rel-8 |  | Mattias Wahlqvist, Ericsson |  |  | MCC_RAN |
| 414 | 126.1.4 | 3G Long Term Evolution – RF Radio Transmission/Reception, System Performance Requirements and Conformance Testing |  | 385d? | 2006-09-25 A | 2008-03-14 | 5% | 365.75d? | 2006-09-25 | 2007-11-30 | 310d? | 85d | finish no earlier than 2008-03-14 | R4 | 3080h | 154h | LTE-RF | Rel-8 |  | Frank Lamprecht, Siemens |  |  | MCC_RAN |
| 415 | 126.2 | **3GPP System Architecture Evolution Specification** |  | 332d? | 2006-06-08 A | 2007-09-14 | 17% | 275.09d? | 2006-06-08 | 2007-07-09 | 283d? | 215d |  | S2 | 8728h | 1496.06h | SAES | Rel-8 |  | Osok Song (Samsung) | osok.song@samsung.com |  | Maurice |
| 416 | 126.2.1 | Requirements for evolution of the 3GPP system architecture |  | 157d? | 2006-06-08 A | 2007-01-12 | 70% | 47.1d? | 2006-06-08 | 2007-01-12 | 157d? | 390d | finish no earlier than 2007-01-12 | S1 | 1256h | 879.2h | AIPN-SAE | Rel-8 |  | Michael Kurz (T-Mobile International) | michael.kurz@t-mobile.at |  | Michael |
| 417 | 126.2.2 | GPRS enhancements for LTE access |  | 198d? | 2006-12-01 A | 2007-09-04 | 5% | 188.1d? | 2006-06-08 | 2007-01-12 | 157d? | 223d | start no earlier than 2006-12-01 | S2 | 1584h | 79.2h | SAES-GPRS_LTE | Rel-8 |  | Chris Pudney (Vodafone) | chris.pudney@vodafone.com |  | Maurice |
| 418 | 126.2.3 | Architecture enhancements for non-3GPP accesses |  | 198d? | 2006-12-01 | 2007-09-04 |  |  | 2006-06-08 | 2007-01-12 | 157d? | 223d | start no earlier than 2006-12-01 | S2 | 1584h |  | SAES-non_3GPP | Rel-8 |  | Irfan Ali (Motorola) | Irfan.Ali@motorola.com |  | Maurice |
| 419 | 126.2.4 | Deleted: Stage 2 of architecture for the 3GPP System Architecture Evolution |  | 206d? | 2006-12-01 A | 2007-09-14 | 5% | 195.7d? | 2006-12-01 | 2007-07-09 | 157d? | 215d | finish no earlier than 2007-09-14 | S2 | 1648h | 82.4h | SAES-St2 | Rel-8 | SP-34 | Chris Pudney (Vodafone) | chris.pudney@vodafone.com |  | Maurice |

Notes:
- 398: Text3: 23.228
- 399: DAB - Not yet required in SA2 as it exists in previous releases
- 402: Stage 2 description of Interim conclusion
- 403: Created at TSG#27 by A. Sultan because of the move to Rel-7 of "Common Objects".
- 404: No progress in CN4#26. This have to be moved to Rel-7. It was deleted from WID / Text3: 24.241
- 405: Awaiting MCC SA3 input
- 406: Text3: 22.868
- 407: FS CLOSED at G#28 (no input)
- 409: Not an official Feature - created by MCC to group all the LTE/SAE/All-IP items
- 411: Text3: 36.2xy
- 412: Text3: 36.3xy
- 413: Text3: 36.4xy
- 414: Text3: 36.1xy
- 415: S2#52: Specification phase created. New WID approved SA#32 / Text3: 23.228, 23.279
- 416: Moved to SA2 at SA#32 / Text3: 22.278
- 417: SP-34: GPRS enhancements for LTE access item created. / Text3: 23.401
- 418: SP-34: Architecture enhancements for non-3GPP accesses item created. / Text3: 23.402
- 419: THIS LINE IS DELETED, replaced by the 2 Architecture parallel tracks. / Text3: 23.002, 23.060, 23.107, 23.203, 23.228, 23.234, 23.246, 23.271, 23.279

| ID | WBS | Task | Duration | Start | Finish | Complete | Remaining | Baseline start | Baseline finish | Baseline duration | Total slack | Constraint | Resources | Work | Actual work | Text1 | Text4 | Text5 | Text6 | Text8 |
| --- | --- | --- | --- | --- | --- | --- | --- | --- | --- | --- | --- | --- | --- | --- | --- | --- | --- | --- | --- | --- |
| 420 | 126.3 | **CT aspects of System Architecture Evolution** | 290d? | 2007-02-05 | 2008-03-14 |  |  | 2006-12-01 | 2007-07-09 | 157d? | 85d |  | CP | 17880h |  | SAES-St3 | Hannu Hietalahti, Nokia | hannu.hietalahti@nokia.com | Rel-8 | Andrijana, Seung Don, Kimmo |
| 421 | 126.3.1 | NAS functions related to MS in idle mode | 290d? | 2007-02-05 | 2008-03-14 |  |  | 2006-12-01 | 2007-07-09 | 157d? | 85d | start no earlier than 2007-02-05 | C1 | 2320h |  | SAES-St3-idle |  |  | Rel-8 |  |
| 422 | 126.3.2 | UE to EPC NAS signalling (incl. MBMS and QoS aspects) | 290d? | 2007-02-05 | 2008-03-14 |  |  | 2006-12-01 | 2007-07-09 | 157d? | 85d | start no earlier than 2007-02-05 | C1 | 2320h |  | SAES-St3-sig |  |  | Rel-8 |  |
| 423 | 126.3.3 | PCC aspects of SAE | 290d? | 2007-02-05 | 2008-03-14 |  |  | 2006-12-01 | 2007-07-09 | 157d? | 85d | start no earlier than 2007-02-05 | C3 | 2320h |  | SAES-St3-PCC |  |  | Rel-8 |  |
| 424 | 126.3.4 | Interworking between LTE/SAE and PDN | 290d? | 2007-02-05 | 2008-03-14 |  |  | 2006-12-01 | 2007-07-09 | 157d? | 85d | start no earlier than 2007-02-05 | C3 | 2320h |  | SAES-St3-intwk |  |  | Rel-8 |  |
| 425 | 126.3.5 | Upgrades to QoS mechanism for SAE | 290d? | 2007-02-05 | 2008-03-14 |  |  | 2006-12-01 | 2007-07-09 | 157d? | 85d | start no earlier than 2007-02-05 | C3 | 2320h |  | SAES-St3-QoS |  |  | Rel-8 |  |
| 426 | 126.3.6 | EPC - HSS interface | 165d? | 2007-02-05 | 2007-09-21 |  |  | 2006-12-01 | 2007-07-09 | 157d? | 210d | finish no earlier than 2007-09-21 | C4 | 1320h |  | SAES-St3-EPC_HSS |  |  | Rel-8 |  |
| 427 | 126.3.7 | User and Control plane protocols | 165d? | 2007-02-05 | 2007-09-21 |  |  | 2006-12-01 | 2007-07-09 | 157d? | 210d | finish no earlier than 2007-09-21 | C4 | 1320h |  | SAES-St3-prot |  |  | Rel-8 |  |
| 428 | 126.3.8 | SAE/LTE Identities | 165d? | 2007-02-05 | 2007-09-21 |  |  | 2006-12-01 | 2007-07-09 | 157d? | 210d | finish no earlier than 2007-09-21 | C4 | 1320h |  | SAES-St3-IDs |  |  | Rel-8 |  |
| 429 | 126.4 | GERAN support for GERAN - 3G Long Term Evolution interworking | 376d? | 2006-09-08 | 2008-02-15 |  |  | 2006-09-08 | 2008-02-15 | 376d? | 105d | finish no earlier than 2008-02-15 | GP | 3008h |  | GELTE | Han van Bussel, T-Mobile | han.van.bussel@t-mobile.de | Rel-8 | Paolo |
| 430 | 127 | **Enhanced USIM Phonebook** | 261d? | 2006-06-22 | 2007-06-21 |  |  | 2006-06-22 | 2007-06-21 | 261d? | 276d |  | C6 | 5224h |  | eUPHBOOK | Claus Dietze (Giesecke & Devrient) |  | Rel-8 |  |
| 431 | 127.1 | Requirements for eUPHBOOK | 131d? | 2006-06-22 | 2006-12-21 |  |  | 2006-06-22 | 2006-12-21 | 131d? | 406d | start no earlier than 2006-06-22 | C6 | 1048h |  | eUPHBOOK-St1 |  |  | Rel-8 |  |
| 432 | 127.2 | Implementation of eUPHBOOK | 261d? | 2006-06-22 | 2007-06-21 |  |  | 2006-06-22 | 2007-06-21 | 261d? | 276d | finish no earlier than 2007-06-21 | C6 | 2088h |  | eUPHBOOK-St23 |  |  | Rel-8 |  |
| 433 | 128 | **Enhancements for VGCS Applications** | 328d? | 2006-03-15 A | 2007-06-15 | 45% | 178.9d? | 2006-03-15 | 2007-03-15 | 261d? | 280d |  | S1 | 9256h | 3167.6h | EVA | Amar Deol, Nortel Networks | deola@nortel.com | Rel-8 | Michael |
| 434 | 128.1 | SA1 aspects for EVA | 191d? | 2006-03-15 A | 2006-12-06 | 90% | 19.1d? | 2006-03-15 | 2006-12-06 | 191d? | 417d | finish no earlier than 2006-12-06 | S1 | 1528h | 1375.2h | EVA-s1 | Amar Deol, Nortel Networks | deola@nortel.com | Rel-8 | Michael |
| 435 | 128.2 | C1 aspects for EVA | 271d? | 2006-06-02 A | 2007-06-15 | 25% | 203.25d? | 2006-06-02 | 2007-03-15 | 204d? | 280d | finish no earlier than 2007-06-15 | C1 | 2168h | 542h | EVA-c1 | Milan Patel | milanpa@nortel.com | Rel-8 | Andrijana |
| 436 | 128.3 | C4 aspects for EVA | 201d? | 2006-06-02 A | 2007-03-09 | 60% | 80.4d? | 2006-06-02 | 2006-12-08 | 136d? | 350d | finish no earlier than 2007-03-09 | C4 | 1608h | 964.8h | EVA-c4 |  |  | Rel-8 | Kimmo |
| 437 | 128.4 | GERAN2 Aspects of EVA | 166d? | 2006-06-30 A | 2007-02-16 | 10% | 149.4d? | 2006-06-30 | 2007-02-16 | 166d? | 365d | finish no earlier than 2007-02-16 | G2 | 1328h | 132.8h | EVA-EVGCSA | Frank Billenkamp (Notrtel Networks) | frank.billenkamp@nortel.com | Rel-8 | Gert |
| 438 | 129 | **IMS Service Brokering enhancements** | 69d? | 2005-12-07 A | 2006-03-13 A | 100% |  | 2005-12-07 | 2006-03-13 | 69d? |  |  | S1 | 1104h | 1104h | ISB | John-Luc Bakker (Telcordia) | jbakker@telcordia.com | Rel-8 | Michael |
| 439 | 129.1 | Stage 1 of ISB | 69d? | 2005-12-07 A | 2006-03-13 A | 100% |  | 2005-12-07 | 2006-03-13 | 69d? |  | finish no earlier than 2006-03-13 | S1 | 552h | 552h | ISB-s1 | John-Luc Bakker (Telcordia) | jbakker@telcordia.com | Rel-8 | Michael |
| 440 | 130 | **Multimedia Priority Service** | 337d? | 2006-06-08 A | 2007-09-21 | 31% | 233.5d? | 2006-06-08 | 2007-09-20 | 336d? | 210d |  | S1 | 7072h | 2688h | PRIOR | Jim Garrahan (Telcordia) | jgarraha@telcordia.com | Rel-8 | Michael |
| 441 | 130.1 | Service Requirements for PRIOR | 336d? | 2006-06-08 A | 2007-09-20 | 50% | 168d? | 2006-06-08 | 2007-09-20 | 336d? | 211d | finish no earlier than 2007-09-20 | S1 | 2688h | 1344h | PRIOR-EMR | Jim Garrahan (Telcordia) | jgarraha@telcordia.com | Rel-8 | Michael |
| 442 | 130.2 | Multimedia Priority Service for PRIOR | 211d? | 2006-12-01 | 2007-09-21 |  |  |  |  |  | 210d | finish no earlier than 2007-09-21 | C1 | 1688h |  | PRIOR-MM | Keith Drage, Alcatel-Lucent | drage@lucent.com | Rel-8 | Andrijana |
| 443 | 131 | eCall Data Transfer – Requirements | 51d? | 2006-09-28 A | 2006-12-07 | 55% | 22.95d? | 2006-09-28 | 2006-12-07 | 51d? | 416d | finish no earlier than 2006-12-07 | S1 | 408h | 224.4h | EData | Rhys Robinson (Airbiquity) | rrobinson@airbiquity.com | Rel-8 | Maurice |
| 444 | 132 | Local Charging Zone Requirements | 51d? | 2006-09-28 A | 2006-12-07 | 50% | 25.5d? | 2006-09-28 | 2006-12-07 | 51d? | 416d | finish no earlier than 2006-12-07 | S1 | 408h | 204h | LCZR | Hong Liu (China Mobile) | liuhongyfw@chinamobile.com | Rel-8 | Michael |
| 445 | 133 | Enhancements to BS30 Bearer service for Videotelephony | 51d? | 2007-01-04 A | 2007-03-15 | 10% | 45.9d? | 2007-01-04 | 2007-03-15 | 51d? | 346d | finish no earlier than 2007-03-15 | S1 | 408h | 40.8h | BS30 | Andre Jarvis (3) | andre.jarvis@three.co.uk | Rel-8 | Michael |
| 446 | 134 | NDS Authentication Framework Extension for TLS | 50d? | 2006-09-28 A | 2006-12-06 | 99% | 0.5d? | 2006-09-28 | 2006-12-06 | 50d? | 417d | finish no earlier than 2006-09-28 | S3 | 400h | 396h | NDSAFTLS | Tiina Koskinen (Nokia) | tiina.s.koskinen@nokia.com | Rel-8 | Michael |

Notes:
- 420: CT wide WID approved ib CT#34 / Text3: 24.8yz, 29.8ab, 29.8cd
- 429: Text3: 24.008, 43.055, 43.129, 43.246, 44.018, 44.060, 45.002, 45.008, 45.010, 48.008,48.018, 51.010
- 430: Moved from Rel-7 to Rel-8 at CT#33
- 431: Text3: 21.111
- 432: Text3: 31.102
- 433: Text3: 42.068
- 434: Text3: 42.068
- 435: Text3: 43.068, 44.068
- 436: CT4#32: Crs are presented and in principle agreed, waiting for the approval of stage2 / Text3: 29.002
- 437: Text3: 44.018, 48.008
- 438: Text3: 22.228
- 439: Text3: 22.228
- 440: Created by MCC to group 320023 (Stage 1) and 340012 (Stage 3) wrongly shown as idependent Features / Text3: 22.153
- 441: Official name is "Multimedia Priority Service" but this is identical to UID 31041 / Text3: 22.153
- 442: "CT1" corrected into "C1" / Text3: 24.229
- 443: Text3: 22.101, 22.105
- 444: Text3: 22.115
- 445: Text3: 22.002, 22.004, 22.101, 22.105, 24.008
- 446: Text3: 33.310

| ID | WBS | Task | Duration | Start | Finish | Complete | Remaining | Baseline start | Baseline finish | Baseline duration | Total slack | Constraint | Resources | Work | Actual work | Text1 | Text6 | Text7 | Text8 | Text4 | Text5 |
| --- | --- | --- | --- | --- | --- | --- | --- | --- | --- | --- | --- | --- | --- | --- | --- | --- | --- | --- | --- | --- | --- |
| 447 | 135 | **FBI Phase 2 - NOT YET OFFICIAL** | 349d? | 2006-06-30 A | 2007-10-31 | 9% | 316.76d? | 2006-06-30 | 2007-10-31 | 349d? | 182d |  | S2 | 10000h | 923.91h | FBI2 | Rel-8 | TSG | Maurice |  |  |
| 448 | 135.1 | **System enhancements for TISPAN Rel 2** | 349d? | 2006-06-30 A | 2007-10-31 | 9% | 316.76d? | 2006-06-30 | 2007-10-31 | 349d? | 182d |  | S2 | 7208h | 665.96h | FBI2-TISP2 | Rel-8 |  |  |  |  |
| 449 | 135.1.1 | Stage 2 of FBI for TISPAN R2 - Rel 8 | 349d? | 2006-06-30 | 2007-10-31 |  |  | 2006-06-30 | 2007-10-31 | 349d? | 182d | finish no earlier than 2007-10-31 | S2 | 2792h |  | FBI2-TISP2-s2 | Rel-8 |  |  |  |  |
| 450 | 135.1.2 | Protocol impact of FBI for TISPAN R2 | 152d? | 2006-08-16 | 2007-03-15 |  |  | 2006-08-16 | 2007-03-15 | 152d? | 346d | finish no earlier than 2007-03-15 | C1 | 1216h |  | FBI2-TISP2-c1 | Rel-8 |  |  |  |  |
| 451 | 135.1.3 | Charging harmonization for NGN between 3GPP and ATIS-TMOC | 51d? | 2006-09-28 A | 2006-12-07 A | 100% |  | 2006-09-28 | 2006-12-07 | 51d? |  | finish no earlier than 2006-12-07 | S5 | 408h | 408h | FBI2-TISP2-CH | Rel-8 |  | Adrian | Amdocs | yishai.brown@amdocs.com |
| 452 | 136 | Services Alignment (also known as Service Migration) | 256d? | 2006-09-28 A | 2007-09-20 | 15% | 217.6d? | 2006-09-28 | 2007-09-20 | 256d? | 211d | finish no earlier than 2007-09-20 | S1 | 2048h | 307.2h | ServAl | Rel-8 |  | Michael | Chris Friel (O2) | chris.friel@o2.com |
| 453 | 137 | GAN Enhancements | 131d? | 2006-11-17 | 2007-05-18 |  |  |  |  |  | 300d | finish no earlier than 2007-05-18 | GP | 1048h |  | EGAN | Rel-7 |  | Paolo | Janne Linkola (T-Mobile) | janne.linkola@t-mobile.com |
| 454 | 138 | **REduced symbol Duration, Higher Order modulation and Turbo coding (RED HOT) for downlink** | 326d? | 2006-11-17 | 2008-02-15 |  |  |  |  |  | 105d |  | GP | 10000h |  | REDHOT | Rel-7 |  | Paolo | Stefan Eriksson (Ericsson) | stefan.g.eriksson@ericsson.com |
| 455 | 138.1 | Stage 2 for REDHOT | 131d? | 2006-11-17 | 2007-05-18 |  |  |  |  |  | 300d | finish no earlier than 2007-05-18 | G1 | 1048h |  | REDHOT-Stage2 | Rel-7 |  | Paolo | Stefan Eriksson (Ericsson) | stefan.g.eriksson@ericsson.com |
| 456 | 138.2 | Stage 3 for REDHOT | 206d? | 2006-11-17 | 2007-08-31 |  |  |  |  |  | 225d | finish no earlier than 2007-08-31 | G1 | 1648h |  | REDHOT-Stage3 | Rel-7 |  | Paolo | Stefan Eriksson (Ericsson) | stefan.g.eriksson@ericsson.com |
| 457 | 138.3 | MS Conformance Tests | 326d? | 2006-11-17 | 2008-02-15 |  |  |  |  |  | 105d | finish no earlier than 2008-02-15 | G3 | 2608h |  | REDHOT-MStests | Rel-7 |  | Stoyan | Stefan Eriksson (Ericsson) | stefan.g.eriksson@ericsson.com |
| 458 | 138.4 | BTS Conformance Tests | 261d? | 2006-11-17 | 2007-11-16 |  |  |  |  |  | 170d | finish no earlier than 2007-11-16 | G1 | 2088h |  | REDHOT-BTStests | Rel-7 |  | Paolo | Stefan Eriksson (Ericsson) | stefan.g.eriksson@ericsson.com |
| 459 | 139 | Support of Customised Alerting Tone Service | 207d? | 2006-12-06 | 2007-09-20 |  |  | 2005-06-06 | 2006-12-15 | 400d? | 211d | finish no earlier than 2007-09-20 | S1 | 1656h |  | CusAlert | Rel-8 |  | Michael | Feng Lingjuan (China Mobile) | (fenglingjuan@chinamobile.com) |
| 460 | 140 | I-WLAN NSP | 6d? | 2006-12-06 | 2006-12-13 |  |  | 2005-06-06 | 2006-12-15 | 400d? | 412d | finish no earlier than 2006-12-13 | S1 | 48h |  | IWLANNSP | Rel-8 |  | Michael | Chris Friel (O2) | chris.friel@o2.com |
| 461 | 141 | Support of Service-Level Interworking for Messaging Services | 132d? | 2006-12-06 | 2007-06-07 |  |  | 2005-06-06 | 2006-12-15 | 400d? | 286d | finish no earlier than 2007-06-07 | S1 | 1056h |  | MESSIW | Rel-8 |  | Michael | Liu Ling (Huawei) | ling.liu@huawei.com |
| 462 | 142 | LCS for 3GPP Interworking WLAN | 245d? | 2006-10-23 | 2007-09-28 |  |  | 2006-03-27 | 2006-12-15 | 190d? | 205d | finish no earlier than 2007-09-28 | S2 | 1960h |  | LCS4_IWLAN | Rel-8 |  | Maurice | Donghee Shim (LG Electronics Inc.) | dhshim@lge.com |
| 463 | 143 | (Small) Technical Enhancements and Improvements for Rel-8 | 400d? | 2007-01-01 | 2008-07-11 |  |  | 2007-01-01 | 2008-07-11 | 400d? | 0d | start no earlier than 2007-01-01 | All | 3200h |  | TEI8 | Rel-8 |  |  |  |  |
| 464 | 144 | Rel-8 Feasibility Studies | 1d? | 2000-01-03 | 2000-01-03 |  |  | 2000-01-03 | 2000-01-03 | 1d? | 2224d |  | CT;RAN;SA | 8h |  |  | Rel-8 |  |  |  |  |
| 465 | 145 | Facilitating Machine to Machine Communication in GSM and UMTS (M2M) | 161d? | 2005-11-04 A | 2006-06-16 | 65% | 56.35d? | 2005-11-04 | 2006-06-16 | 161d? | 540d | finish no earlier than 2006-06-16 | S1 | 1288h | 837.2h | M2M | Rel-8 |  | Michael | Juergen Merkel, Siemens AG |  |
| 466 | 146 | **All-IP Network (AIPN)** | 448d? | 2004-06-28 A | 2006-03-15 A | 100% |  | 2004-06-28 | 2006-03-15 | 448d? |  |  | S1 | 8672h | 8672h | AIPN | Rel-8 | TSG | Michael | Chris Sachno (NTT DoCoMo) | c.masyu@nttdocomo.co.jp |
| 467 | 146.1 | All-IP Network Feasibility Study | 188d? | 2004-06-28 A | 2005-03-16 A | 100% |  | 2004-06-28 | 2005-03-16 | 188d? |  | start no earlier than 2004-06-28 | S1 | 1504h | 1504h | AIPFS | Rel-8 | TSG | Michael | Chris Sachno (NTT DoCoMo) | c.masyu@nttdocomo.co.jp |
| 468 | 146.2 | Stage1 | 448d? | 2004-06-28 A | 2006-03-15 A | 100% |  | 2004-06-28 | 2006-03-15 | 448d? |  | finish no earlier than 2006-03-15 | S1 | 3584h | 3584h | AIPN | Rel-8 | TSG | Michael | Chris Sachno (NTT DoCoMo) | c.masyu@nttdocomo.co.jp |
| 469 | 147 | Study on Stage 2 aspects of IMS Service Brokering | 265d? | 2006-06-19 A | 2007-06-22 | 12% | 233.2d? | 2006-06-19 | 2007-06-22 | 265d? | 275d | start no earlier than 2006-06-19 | S2 | 2120h | 254.4h | ISB_ST2_SDY | Rel-8 |  | Maurice | John-Luc Bakker (Telcordia) | jbakker@telcordia.com |
| 470 | 148 | Study of Requirements of IP-Multimedia Subsystem (IMS) Multimedia Conferencing | 205d? | 2006-06-08 A | 2007-03-21 | 15% | 174.25d? | 2006-06-08 | 2007-03-21 | 205d? | 342d | finish no earlier than 2007-03-21 | S1 | 1640h | 246h | SI-IMSconf | Rel-8 |  | Michael | Zheng Jianping (China Mobile ) | zhengjianping@chinamobile.com |
| 471 | 149 | Study on support of a Public Warning System (PWS) | 205d? | 2006-06-08 A | 2007-03-21 | 25% | 153.75d? | 2006-06-08 | 2007-03-21 | 205d? | 342d | start no earlier than 2006-06-08 | S1 | 1640h | 410h | PWS-SI | Rel-8 |  | Michael | Mark Young (T-mobile) | mark.younge@t-mobile.com |
| 472 | 150 | Protection against SMS and MMS spam | 205d? | 2006-06-08 | 2007-03-21 |  |  | 2006-06-08 | 2007-03-21 | 205d? | 342d | start no earlier than 2006-06-08 | S3 | 1640h |  | CPSMal | Rel-8 |  | Michael | Eric Gauthier (Orange SA) | eric.gauthier@orange.ch |
| 473 | 151 | Study of VCC support for Emergency Calls | 207d? | 2006-06-08 A | 2007-03-23 | 15% | 175.95d? | 2006-06-08 | 2007-03-23 | 207d? | 340d | finish no earlier than 2007-03-23 | S2 | 1656h | 248.4h | FSVCCEm | Rel-8 |  | Maurice | Bob Beeson, Lucent |  |
| 474 | 152 | Study on Centralised IMS Service Control | 235d? | 2006-10-23 A | 2007-09-14 | 15% | 199.75d? | 2006-10-23 | 2007-09-14 | 235d? | 215d | finish no earlier than 2007-09-14 | S2 | 1880h | 282h | IMS_CSC | Rel-8 |  | Maurice | Andy Bennett (Lucent Technologies) | andybennett@lucent.com |
| 475 | 153 | Study on IMS utilizing multicast bearer services | 248d? | 2006-03-22 A | 2007-03-02 | 50% | 124d? | 2006-03-22 | 2006-12-15 | 193d? | 355d | finish no earlier than 2007-03-02 | S2 | 1984h | 992h | FS-MLTICAST-IMS | Rel-8 |  | Maurice | Fiona Zhu (Siemens AG) |  |

Notes:
- 447: Added by MCC as a consequence of the move to Rel8 of TISPAN Rel-2 impacts on 3GPP
- 451: 09/2006 SA#33 WID approved / Text3: 32.297
- 452: Text3: 22.9xx
- 454: Text3: 24.008, 43.064, 43.055, 44.018, 44.060, 45.001, 45.002, 45.003, 45.004, 45.005, 45.008, 51.010, 51.021
- 455: Text3: 43.055, 43.064
- 456: Text3: 24.008, 44.018, 44.060, 45.001, 45.002, 45.003, 45.004, 45.005, 45.008
- 457: Text3: 51.010
- 458: Text3: 51.021
- 459: Text3: 22.182
- 460: Text3: 22.234
- 461: Text3: 22.105, 22.340
- 462: New WID approved SP-34. Supporting companies: Telcordia, Samsung, Qualcomm, BT, LG Electronics, Cingular, Lucent. No scheduled end date! / Text3: 23.234, 23.271, 23.167
- 465: Text3: 22.868
- 466: Text3: 22.978
- 467: Text3: 22.978
- 468: Text3: 22.258
- 469: Study approved SA#32 / Text3: 23.810
- 470: Text3: 22.948
- 471: Text3: 22.968
- 472: Formerly called "Consumer protection against spam and malware" / Text3: 33.9xx
- 473: Text3: 23.826
- 474: Approved at SP#33 / Text3: 23.9de
- 475: Text3: 23.847

| ID | WBS | Task | Duration | Start | Finish | Complete | Remaining | Baseline start | Baseline finish | Baseline duration | Total slack | Constraint | Resources | Work | Actual work | Text1 | Text3 | Text4 | Text5 | Text6 | Text8 |
| --- | --- | --- | --- | --- | --- | --- | --- | --- | --- | --- | --- | --- | --- | --- | --- | --- | --- | --- | --- | --- | --- |
| 476 | 154 | **Study on Dynamically reconfiguring a FDD UE receiver to reduce power consumption when desired Quality of Service is met** | 120d? | 2006-09-25 | 2007-03-09 |  |  | 2006-09-25 | 2007-03-09 | 120d? | 350d |  | RP | 2880h |  | FSUEPow | 25.xxx | Chris Callender, Nokia | Chris.callender@nokia.com | Rel-8 | MCC_RAN |
| 477 | 154.1 | RAN2 aspects of FSUEPow | 120d? | 2006-09-25 | 2007-03-09 |  |  | 2006-09-25 | 2007-03-09 | 120d? | 350d | start no earlier than 2006-09-22 | R2 | 960h |  | FSUEPow |  | Tiina Koskinen (Nokia) | tiina.s.koskinen@nokia.com | Rel-8 | MCC_RAN |
| 478 | 154.2 | RAN4 aspects of FSUEPow | 120d? | 2006-09-25 | 2007-03-09 |  |  | 2006-09-25 | 2007-03-09 | 120d? | 350d | start no earlier than 2006-09-22 | R4 | 960h |  | FSUEPow |  | Tiina Koskinen (Nokia) | tiina.s.koskinen@nokia.com | Rel-8 | MCC_RAN |
| 479 | 155 | Study on Paging Permission with Access Control (PPAC) | 256d? | 2006-09-28 A | 2007-09-20 | 20% | 204.8d? | 2006-09-28 | 2007-09-20 | 256d? | 211d | finish no earlier than 2007-09-20 | S1 | 2048h | 409.6h | PPAC | 22.908 | Katsuhiro Noguchi (NTT DoCoMo Inc.) | noguchi@nttdocomo.co.jp | Rel-8 | Michael |
| 480 | 156 | Study on Non 3GPP access NSP | 207d? | 2006-12-06 | 2007-09-20 |  |  | 2006-09-28 | 2007-09-20 | 256d? | 211d | start no earlier than 2006-12-06 | S1 | 1656h |  | N3GtoNSP | 22.8xx | Chris Friel (O2) | chris.friel@o2.com | Rel-8 | Michael |
| 481 | 157 | Study on Value Added Services for Short Message Service | 263d? | 2006-12-06 | 2007-12-07 |  |  | 2006-09-28 | 2007-09-20 | 256d? | 155d | finish no earlier than 2007-12-07 | S1 | 2104h |  | VAS4SMS | 22.xxx | Wu Bin (China Mobile Communications Corporation) | wubin@chinamobile.com | Rel-8 | Michael |
| 482 | 158 | Study on Requirements for seamless roaming and service continuity between mobile and WLAN networks | 132d? | 2006-12-06 | 2007-06-07 |  |  | 2006-09-28 | 2007-09-20 | 256d? | 286d | finish no earlier than 2007-06-07 | S1 | 1056h |  | SMLSWLAN | 22.xxx | Mike Meyerstein (BT) | mike.meyerstein@bt.com | Rel-8 | Michael |
